# IMPACT Master Schedule

How a schedule from MS Project changed from version to version. A marks actual dates.

## Version 1 (data date 2003-12-31, saved 2004-02-06, file IMPACT Master Schedule_February 6 2004.mpp)

| ID | WBS | Task | Duration | Start | Finish | Predecessors | Complete | Total float | Constraint |
| --- | --- | --- | --- | --- | --- | --- | --- | --- | --- |
| 1 | 1 | **IMPACT - Dave Curtis (UCB) & Lil Reichenthal (GSFC)** | 673d | 2003-02-26 A | 2005-10-14 |  | 38% | 0d |  |
| 2 | 1.1 | **Suite Deliveries to APL** | 51d | 2004-08-13 | 2004-10-28 |  |  | 0d |  |
| 3 |  | FM 1 Target Delivery Date | 0d | 2004-10-07 | 2004-10-07 | 5, 7 |  | 0d | must start on 2004-10-07 |
| 4 |  | FM 1 Target Delivery Date | 0d | 2004-10-28 | 2004-10-28 | 8, 6 |  | 0d | must start on 2004-10-28 |
| 5 |  | Boom Suite FM 1 Ready for Delivery to APL | 0d | 2004-08-13 | 2004-08-13 | 360 |  | 37d |  |
| 6 |  | Boom Suite FM 2 Ready for Delivery to APL | 0d | 2004-09-09 | 2004-09-09 | 367 |  | 33d |  |
| 7 |  | SEP Suite FM 1 Ready for Delivery to APL | 0d | 2004-09-07 | 2004-09-07 | 788, 596, 525 |  | 21d |  |
| 8 |  | SEP Suite FM 2 Ready for Delivery to APL | 0d | 2004-10-04 | 2004-10-04 | 795, 599, 528 |  | 16d |  |
| 9 | 1.2 | **Environmental Testing - PER, Impact Suite EMC, Snapshots of Boom & SEP Suite Test Flows** | 181d | 2004-01-14 A | 2004-09-28 |  |  | 270d |  |
| 10 | 1.2.1 | **Reviews (PER and TRR's) - TRR Dates are Tentative** | 107d | 2004-01-14 A | 2004-06-15 |  | 14% | 344d |  |
| 11 |  | Instrument PER at UCB | 1d | 2004-01-14 A | 2004-01-14 A |  | 100% |  | start no earlier than 2004-01-14 |
| 12 |  | TRR 1 - Prior to FM 1 SEPT Thermal Vac | 1d | 2004-02-13 | 2004-02-13 | 41SS-6d |  | 179d |  |
| 13 |  | TRR 2 - Prior to FM 1 IDPU Vibration | 1d | 2004-04-14 | 2004-04-14 | 20SS-5d |  | 137d |  |
| 14 |  | TRR 3 - Prior to FM 1 STE-U Thermal Vac/Thermal Balance | 1d | 2004-03-10 | 2004-03-10 | 23SS-5d |  | 162d |  |
| 15 |  | TRR 4 - Prior to FM 1 Boom Structure Vibration | 1d | 2004-04-08 | 2004-04-08 | 22SS-5d |  | 141d |  |
| 16 |  | TRR 5 - Prior to FM 1 SWEA Vibration | 1d | 2004-05-04 | 2004-05-04 | 25SS-5d |  | 123d |  |
| 17 |  | TRR 6 - Prior to FM 1 Impact Suite EMC (for Boom and SEP) | 1d | 2004-06-15 | 2004-06-15 | 18SS-5d |  | 344d |  |
| 18 |  | IMPACT Suite FM 1 EMC Testing at UCB | 10d | 2004-06-22 | 2004-07-05 | 358, 766, 426 |  | 14d |  |
| 19 | 1.2.3 | **Boom Suite FM 1 Environmental Test Flow Snapshot - UCB** | 97d | 2004-03-17 | 2004-07-30 |  |  | 311d |  |
| 20 |  | IDPU Vibration | 5d | 2004-04-21 | 2004-04-27 | 179SS |  | 128d |  |
| 21 |  | IDPU Thermal Vac | 10d | 2004-04-28 | 2004-05-11 | 180SS |  | 118d |  |
| 22 |  | Boom Structure Vibration | 4d | 2004-04-15 | 2004-04-20 | 218SS |  | 133d |  |
| 23 |  | STE-U Thermal Vac and Thermal Balance | 14d | 2004-03-17 | 2004-04-05 | 278SS |  | 144d |  |
| 24 |  | Boom Structure Thermal Vac | 15d | 2004-04-21 | 2004-05-11 | 219SS |  | 118d |  |
| 25 |  | SWEA/STE Vibration | 5d | 2004-05-11 | 2004-05-17 | 344SS |  | 114d |  |
| 26 |  | SWEA/STE Thermal Vac and Thermal Balance | 14d | 2004-07-06 | 2004-07-23 | 345SS |  | 316d |  |
| 27 |  | IDPU Bake Out | 5d | 2004-07-06 | 2004-07-12 | 181SS |  | 325d |  |
| 28 |  | Boom Suite Bake Out | 5d | 2004-07-26 | 2004-07-30 | 359SS |  | 311d |  |
| 29 | 1.2.4 | **Boom Suite FM 2 Environmental Test Flow Snapshot - UCB** | 93d | 2004-04-16 | 2004-08-25 |  |  | 293d |  |
| 30 |  | Boom Structure Vibration | 4d | 2004-04-16 | 2004-04-21 | 240SS |  | 132d |  |
| 31 |  | IDPU Vibration | 5d | 2004-05-10 | 2004-05-14 | 184SS |  | 115d |  |
| 32 |  | IDPU Thermal Vac | 10d | 2004-05-17 | 2004-05-28 | 185SS |  | 105d |  |
| 33 |  | Boom Structure Thermal Vac | 15d | 2004-05-12 | 2004-06-02 | 241SS |  | 103d |  |
| 34 |  | SWEA/STE Vibration | 5d | 2004-07-14 | 2004-07-20 | 352SS |  | 69d |  |
| 35 |  | SWEA/STE Thermal Vac | 10d | 2004-07-21 | 2004-08-03 | 353SS |  | 59d |  |
| 36 |  | Boom Suite FM 2 EMC | 5d | 2004-08-12 | 2004-08-18 | 365SS |  | 48d |  |
| 37 |  | IDPU Bake Out | 5d | 2004-08-19 | 2004-08-25 | 186SS |  | 43d |  |
| 38 |  | Boom Suite Bake Out | 5d | 2004-08-19 | 2004-08-25 | 366SS |  | 43d |  |
| 39 | 1.2.5 | **SEP Suite FM 1 Environmental Test Flow Snapshot** | 149d | 2004-02-09 | 2004-09-07 |  |  | 285d |  |
| 40 |  | SEPT Vibe and Acoustics (in Europe) | 10d | 2004-02-09 | 2004-02-23 | 566SS, 573SS |  | 424d |  |
| 41 |  | SEPT Thermal Vac (in Europe) | 10d | 2004-02-24 | 2004-03-08 | 567SS, 574SS |  | 414d |  |
| 42 |  | SEPT Bake Out (in Europe) | 3d | 2004-03-09 | 2004-03-11 | 568SS, 575SS |  | 411d |  |
| 43 |  | LET/HET/SEP Cen Accelerator Test (at MSU) | 11d | 2004-07-06 | 2004-07-20 | 797SS |  | 319d |  |
| 44 |  | SEPT Thermal Balance (at GSFC) | 10d | 2004-07-06 | 2004-07-19 | 569SS, 576SS |  | 320d |  |
| 45 |  | LET/HET/SEP Cen Vibe and Acoustics (at JPL) | 10d | 2004-07-16 | 2004-07-29 | 783SS |  | 312d |  |
| 46 |  | LET/HET/SEP Cen Thermal Balance (at JPL) | 5d | 2004-07-30 | 2004-08-05 | 784SS |  | 307d |  |
| 47 |  | LET/HET/SEP Cen Thermal Vac (at JPL) | 15d | 2004-08-12 | 2004-09-01 | 785SS |  | 288d |  |
| 48 |  | LET/HET/SEP Cen Bake Out (at JPL) | 3d | 2004-09-02 | 2004-09-07 | 788SS |  | 285d |  |
| 49 |  | SIT Vibe and Acoustics (at GSFC) | 10d | 2004-07-08 | 2004-07-21 | 718SS |  | 318d |  |
| 50 |  | SIT Thermal Balance (at GSFC) | 5d | 2004-07-23 | 2004-07-29 | 720SS |  | 312d |  |
| 51 |  | SIT Thermal Vac (at GSFC) | 10d | 2004-07-30 | 2004-08-12 | 721SS |  | 302d |  |
| 52 |  | SIT Bake Out (at GSFC) | 3d | 2004-08-17 | 2004-08-19 | 723SS |  | 297d |  |
| 53 | 1.2.6 | **SEP Suite FM 2 Environmental Test Flow Snapshot** | 168d | 2004-02-03 | 2004-09-28 |  |  | 270d |  |
| 54 |  | SEPT Vibe and Acoustics (in Europe) | 10d | 2004-02-03 | 2004-02-17 | 581SS, 588SS |  | 428d |  |
| 55 |  | SEPT Thermal Vac (in Europe) | 10d | 2004-02-18 | 2004-03-02 | 582SS, 589SS |  | 418d |  |
| 56 |  | SEPT Bake Out (in Europe) | 3d | 2004-03-03 | 2004-03-05 | 583SS, 590SS |  | 415d |  |
| 57 |  | SEP Suite FM 2 EMC (at Caltech) | 5d | 2004-08-05 | 2004-08-11 | 790SS |  | 303d |  |
| 58 |  | LET/HET/SEP Cen Accelerator Test (at MSU) | 11d | 2004-07-06 | 2004-07-20 | 798SS |  | 319d |  |
| 59 |  | SEPT Thermal Balance (at GSFC) | 10d | 2004-07-06 | 2004-07-19 | 584SS, 591SS |  | 320d |  |
| 60 |  | LET/HET/SEP Cen Vibe and Acoustics (at JPL) | 10d | 2004-07-16 | 2004-07-29 | 791SS |  | 312d |  |
| 61 |  | LET/HET/SEP Cen Thermal Vac (at JPL) | 15d | 2004-08-12 | 2004-09-01 | 792SS |  | 288d |  |
| 62 |  | LET/HET/SEP Cen Bake Out (at JPL) | 3d | 2004-09-02 | 2004-09-07 | 795SS |  | 285d |  |
| 63 |  | SIT Vibe and Acoustics (at GSFC) | 10d | 2004-08-16 | 2004-08-27 | 727SS |  | 291d |  |
| 64 |  | SIT Thermal Balance (at GSFC) | 5d | 2004-08-31 | 2004-09-07 | 729SS |  | 285d |  |
| 65 |  | SIT Thermal Vac (at GSFC) | 10d | 2004-09-08 | 2004-09-21 | 730SS |  | 275d |  |
| 66 |  | SIT Bake Out (at GSFC) | 3d | 2004-09-24 | 2004-09-28 | 732SS |  | 270d |  |
| 67 | 1.3 | **Power Converters - UCB** | 330d | 2003-02-26 A | 2004-06-16 |  | 45% | 343d |  |
| 68 | 1.3.1 | **Deliveries** | 100d | 2003-12-09 A | 2004-04-30 |  | 20% | 44d |  |
| 69 | 1.3.1.1 | **FM 1** | 87d | 2003-12-09 A | 2004-04-13 |  | 40% | 33d |  |
| 70 |  | Deliver IDPU FM 1 LVPS (stays at UCB) | 0d | 2004-04-13 | 2004-04-13 | 124 |  | 33d |  |

| ID | WBS | Task | Duration | Start | Finish | Predecessors | Complete | Total float | Constraint |
| --- | --- | --- | --- | --- | --- | --- | --- | --- | --- |
| 71 |  | Deliver SEP FM 1 LVPS (to Caltech) | 1d | 2004-03-17 | 2004-03-17 | 128 |  | 50d |  |
| 72 |  | Deliver SWEA/STE FM 1 LVPS (stays at UCB) | 0d | 2004-03-22 | 2004-03-22 | 132 |  | 27d |  |
| 73 |  | Deliver PLASTIC FM 1 LVPS (to UNH) | 2d | 2004-03-04 | 2004-03-05 | 136 |  | 42d | finish no later than 2004-05-04 |
| 74 |  | Deliver SIT FM 1 HVPS (to UMD) | 2d | 2003-12-09 A | 2003-12-10 A | 138 | 100% |  |  |
| 75 | 1.3.1.2 | **FM 2** | 28d | 2004-03-24 | 2004-04-30 |  |  | 44d |  |
| 76 |  | Deliver IDPU FM 2 LVPS (stays at UCB) | 0d | 2004-04-30 | 2004-04-30 | 145 |  | 37d |  |
| 77 |  | Deliver SEP FM 2 LVPS (to Caltech) | 1d | 2004-04-19 | 2004-04-19 | 149 |  | 27d |  |
| 78 |  | Deliver SWEA/STE FM 2 LVPS (stays at UCB) | 0d | 2004-04-26 | 2004-04-26 | 153 |  | 48d |  |
| 79 |  | Deliver PLASTIC FM 2 LVPS (to UNH) | 2d | 2004-04-12 | 2004-04-13 | 157 |  | 41d | finish no later than 2004-06-10 |
| 80 |  | Deliver SIT FM 2 HVPS (to UMD) | 2d | 2004-03-24 | 2004-03-25 | 161 |  | 44d |  |
| 81 | 1.3.2 | **Remaining Flight Procurements** | 71d | 2003-10-24 A | 2004-02-06 |  | 75% | 33d |  |
| 82 |  | Procure IDPU Flight Printed Wiring Board | 10d | 2004-01-26 | 2004-02-06 | 88 |  | 33d | start no earlier than 2004-01-26 |
| 83 |  | Procure SEP Flight Printed Wiring Board | 10d | 2003-11-24 A | 2003-12-08 A | 89 | 100% |  | start no earlier than 2003-11-24 |
| 84 |  | Procure SWEA Flight Printed Wiring Board | 10d | 2003-12-04 A | 2003-12-17 A | 90 | 100% |  |  |
| 85 |  | Procure PLASTIC Flight Printed Wiring Board | 10d | 2003-10-24 A | 2003-11-06 A |  | 100% |  | start no earlier than 2003-10-24 |
| 86 | 1.3.3 | **Fabrication** | 226d | 2003-02-26 A | 2004-01-20 |  | 86% | 71d |  |
| 87 | 1.3.3.1 | **FM 1 & FM 2** | 195d | 2003-02-26 A | 2003-12-03 A |  | 100% |  |  |
| 88 |  | Re-layout IDPU LVPS Flight Printed Wiring Board | 186d | 2003-02-26 A | 2003-11-19 A |  | 100% |  | start no earlier than 2003-02-26 |
| 89 |  | Re-layout SEP LVPS Flight Printed Wiring Board | 32d | 2003-09-24 A | 2003-11-07 A |  | 100% |  | start no earlier than 2003-09-24 |
| 90 |  | Re-layout SWEA LVPS Flight Printed Wiring Board | 5d | 2003-11-26 A | 2003-12-03 A |  | 100% |  | start no earlier than 2003-11-26 |
| 91 | 1.3.3.2 | **FM 1** | 45d | 2003-09-29 A | 2003-12-03 A |  | 100% |  |  |
| 92 |  | Wind IDPU LVPS FM 1 Magnets | 10d | 2003-10-17 A | 2003-10-30 A |  | 100% |  | start no earlier than 2003-10-17 |
| 93 |  | Wind SEP LVPS FM 1 Magnets | 15d | 2003-09-29 A | 2003-10-20 A |  | 100% |  | start no earlier than 2003-09-29 |
| 94 |  | Wind SWEA LVPS FM 1 Magnets | 5d | 2003-11-26 A | 2003-12-03 A |  | 100% |  | start no earlier than 2003-11-26 |
| 95 |  | Wind PLASTIC LVPS FM 1 Magnets | 45d | 2003-09-29 A | 2003-12-03 A |  | 100% |  | start no earlier than 2003-09-29 |
| 96 | 1.3.3.3 | **FM 2** | 15d | 2003-12-29 A | 2004-01-20 |  | 30% | 71d |  |
| 97 |  | Wind HVPS FM 2 Magnets | 15d | 2003-12-29 A | 2004-01-20 |  | 30% | 44d | start no earlier than 2003-12-29 |
| 98 |  | Wind IDPU LVPS FM 2 Magnets | 15d | 2003-12-29 A | 2004-01-20 | 97SS | 30% | 64d |  |
| 99 |  | Wind SEP LVPS FM 2 Magnets | 15d | 2003-12-29 A | 2004-01-20 | 97SS | 30% | 44d |  |
| 100 |  | Wind SWEA LVPS FM 2 Magnets | 15d | 2003-12-29 A | 2004-01-20 | 97SS | 30% | 71d |  |
| 101 |  | Wind PLASTIC LVPS FM 2 Magnets | 15d | 2003-12-29 A | 2004-01-20 | 97SS | 30% | 54d |  |
| 102 | 1.3.4 | **Assembly** | 57d | 2003-12-29 A | 2004-03-19 |  | 2% | 44d |  |
| 103 | 1.3.4.1 | **FM 1** | 44d | 2003-12-29 A | 2004-03-02 |  | 5% | 33d |  |
| 104 |  | Assemble IDPU FM 1 LVPS | 12d | 2004-02-13 | 2004-03-02 | 92, 116 |  | 33d |  |
| 105 |  | Assemble SEP FM 1 LVPS | 15d | 2004-01-12 | 2004-02-02 | 117, 93 |  | 50d | start no earlier than 2004-01-12 |
| 106 |  | Assemble SWEA FM 1 LVPS | 14d | 2004-01-20 | 2004-02-06 | 94, 118 |  | 27d | start no earlier than 2004-01-12 |
| 107 |  | Assemble PLASTIC FM 1 LVPS | 15d | 2003-12-29 A | 2004-01-20 | 119, 95 | 20% | 42d | start no earlier than 2003-12-29 |
| 108 | 1.3.4.2 | **FM 2** | 42d | 2004-01-21 | 2004-03-19 |  |  | 44d |  |
| 109 |  | Assemble IDPU FM 2 LVPS | 15d | 2004-03-01 | 2004-03-19 | 98 |  | 37d | start no earlier than 2004-03-01 |
| 110 |  | Assemble SEP FM 2 LVPS | 15d | 2004-02-13 | 2004-03-05 | 99 |  | 27d | start no earlier than 2004-02-13 |
| 111 |  | Assemble SWEA FM 2 LVPS | 15d | 2004-02-24 | 2004-03-15 | 100 |  | 48d | start no earlier than 2004-02-24 |
| 112 |  | Assemble PLASTIC FM 2 LVPS | 14d | 2004-02-09 | 2004-02-27 | 101 |  | 41d | start no earlier than 2004-02-09 |
| 113 |  | Assemble SIT FM 2 HVPS | 14d | 2004-01-21 | 2004-02-09 | 97 |  | 44d |  |
| 114 | 1.3.5 | **Testing** | 157d | 2003-10-31 A | 2004-06-16 |  | 12% | 343d |  |
| 115 | 1.3.5.1 | **FM 1 & FM 2** | 55d | 2003-11-24 A | 2004-02-12 |  | 80% | 33d |  |
| 116 |  | Coupon Test IDPU Flight Printed Wiring Board | 4d | 2004-02-09 | 2004-02-12 | 82 |  | 33d |  |
| 117 |  | Coupon Test SEP Flight Printed Wiring Board | 5d | 2003-12-09 A | 2003-12-15 A | 83 | 100% |  |  |
| 118 |  | Coupon Test SWEA Flight Printed Wiring Board | 6d | 2004-01-09 A | 2004-01-16 A | 84 | 100% |  | start no earlier than 2004-01-09 |
| 119 |  | Coupon Test PLASTIC Flight Printed Wiring Board | 5d | 2003-11-24 A | 2003-12-01 A | 85 | 100% |  | start no earlier than 2003-11-24 |
| 120 | 1.3.5.2 | **FM 1** | 157d | 2003-10-31 A | 2004-06-16 |  | 16% | 343d |  |
| 121 | 1.3.5.2.1 | **IDPU** | 30d | 2004-03-03 | 2004-04-13 |  |  | 33d |  |
| 122 |  | Test IDPU FM 1 LVPS | 15d | 2004-03-03 | 2004-03-23 | 104 |  | 33d |  |
| 123 |  | Coat & Stake IDPU LVPS FM 1 Boards | 5d | 2004-03-24 | 2004-03-30 | 122 |  | 33d |  |
| 124 |  | Retest IDPU LVPS FM 1 Boards | 10d | 2004-03-31 | 2004-04-13 | 123 |  | 33d |  |
| 125 | 1.3.5.2.2 | **SEP** | 30d | 2004-02-03 | 2004-03-16 |  |  | 50d |  |
| 126 |  | Test SEP FM 1 LVPS | 15d | 2004-02-03 | 2004-02-24 | 105 |  | 50d |  |
| 127 |  | Coat & Stake SEP LVPS FM 1 Boards | 5d | 2004-02-25 | 2004-03-02 | 126 |  | 50d |  |
| 128 |  | Retest SEP LVPS FM 1 Boards | 10d | 2004-03-03 | 2004-03-16 | 127, 379 |  | 50d |  |
| 129 | 1.3.5.2.3 | **SWEA** | 30d | 2004-02-09 | 2004-03-22 |  |  | 27d |  |
| 130 |  | Test SWEA FM 1 LVPS | 15d | 2004-02-09 | 2004-03-01 | 106 |  | 27d |  |
| 131 |  | Coat & Stake SWEA LVPS FM 1 Boards | 5d | 2004-03-02 | 2004-03-08 | 130 |  | 27d |  |
| 132 |  | Retest SWEA LVPS FM 1 Boards | 10d | 2004-03-09 | 2004-03-22 | 131 |  | 27d |  |
| 133 | 1.3.5.2.4 | **PLASTIC** | 30d | 2004-01-21 | 2004-03-03 |  |  | 42d |  |
| 134 |  | Test PLASTIC FM 1 LVPS | 15d | 2004-01-21 | 2004-02-10 | 107 |  | 42d |  |
| 135 |  | Coat & Stake PLASTIC LVPS FM 1 Boards | 5d | 2004-02-11 | 2004-02-18 | 134 |  | 42d |  |
| 136 |  | Retest PLASTIC LVPS FM 1 Boards | 10d | 2004-02-19 | 2004-03-03 | 135 |  | 42d |  |
| 137 | 1.3.5.2.5 | **SIT** | 157d | 2003-10-31 A | 2004-06-16 |  | 63% | 343d |  |
| 138 |  | Test SIT FM 1 HVPS | 25d | 2003-10-31 A | 2003-12-08 A |  | 100% |  | start no earlier than 2003-10-31 |
| 139 |  | Coat & Stake SIT FM 1 HVPS Boards (at UMD) | 5d | 2004-05-26 | 2004-06-02 | 690SS |  | 343d |  |
| 140 |  | Retest SIT FM 1 HVPS Boards (at UMD) | 10d | 2004-06-03 | 2004-06-16 | 139 |  | 343d |  |

| ID | WBS | Task | Duration | Start | Finish | Predecessors | Complete | Total float | Constraint |
| --- | --- | --- | --- | --- | --- | --- | --- | --- | --- |
| 141 | 1.3.5.3 | **FM 2** | 58d | 2004-02-10 | 2004-04-30 |  |  | 44d |  |
| 142 | 1.3.5.3.1 | **IDPU** | 30d | 2004-03-22 | 2004-04-30 |  |  | 37d |  |
| 143 |  | Test IDPU FM 2 LVPS | 15d | 2004-03-22 | 2004-04-09 | 109 |  | 37d |  |
| 144 |  | Coat & Stake IDPU LVPS FM 2 Boards | 5d | 2004-04-12 | 2004-04-16 | 143 |  | 37d |  |
| 145 |  | Retest IDPU LVPS FM 2 Boards | 10d | 2004-04-19 | 2004-04-30 | 144 |  | 37d |  |
| 146 | 1.3.5.3.2 | **SEP** | 30d | 2004-03-08 | 2004-04-16 |  |  | 27d |  |
| 147 |  | Test SEP FM 2 LVPS | 15d | 2004-03-08 | 2004-03-26 | 110 |  | 27d |  |
| 148 |  | Coat & Stake SEP LVPS FM 2 Boards | 5d | 2004-03-29 | 2004-04-02 | 147 |  | 27d |  |
| 149 |  | Retest SEP LVPS FM 2 Boards | 10d | 2004-04-05 | 2004-04-16 | 148, 379 |  | 27d |  |
| 150 | 1.3.5.3.3 | **SWEA** | 30d | 2004-03-16 | 2004-04-26 |  |  | 48d |  |
| 151 |  | Test SWEA FM 2 LVPS | 15d | 2004-03-16 | 2004-04-05 | 111 |  | 48d |  |
| 152 |  | Coat & Stake SWEA LVPS FM 2 Boards | 5d | 2004-04-06 | 2004-04-12 | 151 |  | 48d |  |
| 153 |  | Retest SWEA LVPS FM 2 Boards | 10d | 2004-04-13 | 2004-04-26 | 152 |  | 48d |  |
| 154 | 1.3.5.3.4 | **PLASTIC** | 30d | 2004-03-01 | 2004-04-09 |  |  | 41d |  |
| 155 |  | Test PLASTIC FM 2 LVPS | 15d | 2004-03-01 | 2004-03-19 | 112 |  | 41d |  |
| 156 |  | Coat & Stake PLASTIC LVPS FM 2 Boards | 5d | 2004-03-22 | 2004-03-26 | 155 |  | 41d |  |
| 157 |  | Retest PLASTIC LVPS FM 2 Boards | 10d | 2004-03-29 | 2004-04-09 | 156 |  | 41d |  |
| 158 | 1.3.5.3.5 | **SIT** | 30d | 2004-02-10 | 2004-03-23 |  |  | 44d |  |
| 159 |  | Test SIT FM 2 HVPS | 15d | 2004-02-10 | 2004-03-02 | 113 |  | 44d |  |
| 160 |  | Coat & Stake SIT FM 2 HVPS Boards | 5d | 2004-03-03 | 2004-03-09 | 159 |  | 44d |  |
| 161 |  | Retest SIT FM 2 HVPS Boards | 10d | 2004-03-10 | 2004-03-23 | 160 |  | 44d |  |
| 162 | 1.4 | **IDPU - UCB** | 340d | 2003-05-05 A | 2004-09-07 |  | 59% | 285d |  |
| 163 | 1.4.1 | **Deliveries** | 78d | 2004-02-09 | 2004-05-28 |  |  | 98d |  |
| 164 |  | IDPU FM 1 Complete (to UCB for Boom I&T, then to CIT for SEP I&T, Suite EMC, BO & Final Boom I&T) | 0d | 2004-05-11 | 2004-05-11 | 180 |  | 33d |  |
| 165 |  | IDPU FM 2 Complete (to CIT for SEP I&T, then to UCB for Boom I&T, Boom EMC, BO & Final Boom I&T) | 0d | 2004-05-28 | 2004-05-28 | 185 |  | 37d |  |
| 166 |  | Deliver IDPU S/W Build 3 (to UNH) | 0d | 2004-02-09 | 2004-02-09 | 169 |  | 433d |  |
| 167 | 1.4.2 | **Flight Software** | 192d | 2003-05-05 A | 2004-02-09 |  | 81% | 105d |  |
| 168 |  | IDPU S/W Build #2.5 | 131d | 2003-05-05 A | 2003-11-07 A |  | 100% |  | start no earlier than 2003-05-05 |
| 169 |  | IDPU S/W Build #3 | 120d | 2003-08-15 A | 2004-02-09 |  | 60% | 105d | start no earlier than 2003-08-15 |
| 170 | 1.4.3 | **GSE** | 301d | 2003-06-30 A | 2004-09-07 |  | 50% | 285d |  |
| 171 |  | STE Science Display | 27d | 2003-10-23 A | 2003-12-02 A |  | 100% |  | start no earlier than 2003-10-23 |
| 172 |  | SWEA Science Display | 140d | 2003-06-30 A | 2004-01-21 |  | 62% | 446d | start no earlier than 2003-06-30 |
| 173 |  | GSE Continued Development | 291d | 2003-07-15 A | 2004-09-07 |  | 40% | 285d | start no earlier than 2003-07-15 |
| 174 | 1.4.4 | **Integration & Test** | 224d | 2003-10-07 A | 2004-08-25 |  | 33% | 33d |  |
| 175 |  | IDPU DCB FM 2 Board Level Testing | 15d | 2003-10-07 A | 2003-10-28 A |  | 100% |  | start no earlier than 2003-10-07 |
| 176 |  | IDPU DCB Clean/Stake/Coat (FM 1 & FM 2) | 10d | 2003-12-26 A | 2004-01-09 A | 175 | 100% |  | start no earlier than 2003-12-26 |
| 177 | 1.4.4.3 | **FM 1** | 63d | 2004-04-14 | 2004-07-12 |  |  | 33d |  |
| 178 |  | IDPU FM 1 I & T | 5d | 2004-04-14 | 2004-04-20 | 168, 70, 245, 289, 176 |  | 33d |  |
| 179 |  | IDPU FM 1 Vibration | 5d | 2004-04-21 | 2004-04-27 | 178 |  | 33d |  |
| 180 |  | IDPU FM 1 Thermal Vacuum | 10d | 2004-04-28 | 2004-05-11 | 179 |  | 33d |  |
| 181 |  | IDPU FM 1 Bakeout | 5d | 2004-07-06 | 2004-07-12 | 18, 180 |  | 51d |  |
| 182 | 1.4.4.4 | **FM 2** | 82d | 2004-05-03 | 2004-08-25 |  |  | 33d |  |
| 183 |  | IDPU FM 2 I & T | 5d | 2004-05-03 | 2004-05-07 | 76, 246, 290, 175, 176 |  | 37d |  |
| 184 |  | IDPU FM 2 Vibration | 5d | 2004-05-10 | 2004-05-14 | 183 |  | 37d |  |
| 185 |  | IDPU FM 2 Thermal Vacuum | 10d | 2004-05-17 | 2004-05-28 | 169, 184 |  | 37d |  |
| 186 |  | IDPU FM 2 Bakeout | 5d | 2004-08-19 | 2004-08-25 | 185, 366SS |  | 33d |  |
| 187 | 1.5 | **BOOM Suite - UCB** | 302d | 2003-07-01 A | 2004-09-09 |  | 56% | 283d |  |
| 188 | 1.5.1 | **BOOM Structure - UCB** | 187d | 2003-09-10 A | 2004-06-08 |  | 59% | 73d |  |
| 189 | 1.5.1.1 | **Deliveries** | 104d | 2004-01-09 A | 2004-06-08 |  |  | 73d |  |
| 190 |  | Protoflight Boom available for I&T (if needed) | 0d | 2004-01-09 A | 2004-01-09 A | 195 | 100% |  |  |
| 191 |  | Deliver Boom Structure FM 1 (stays at UCB for Boom Suite FM 1 I&T) | 0d | 2004-05-17 | 2004-05-17 | 220 |  | 27d |  |
| 192 |  | Deliver Boom Structure FM 2 (stays at UCB for Boom Suite FM 2 I&T) | 0d | 2004-06-08 | 2004-06-08 | 242 |  | 73d |  |
| 193 | 1.5.1.2 | **Protoflight** | 79d | 2003-09-16 A | 2004-01-09 A |  | 100% |  |  |
| 194 |  | Protoflight Boom Post Environmental Deployment Test | 35d | 2003-09-16 A | 2003-11-04 A |  | 100% |  | start no earlier than 2003-09-16 |
| 195 |  | Document Protoflight Boom Test Results | 44d | 2003-11-05 A | 2004-01-09 A | 194 | 100% |  |  |
| 196 | 1.5.1.3 | **Flight Procurements** | 40d | 2003-09-10 A | 2003-11-05 A |  | 100% |  |  |
| 197 |  | Receive and Inspect Flight Boom Structure Tubes (FM 1) | 32d | 2003-09-10 A | 2003-10-24 A |  | 100% |  | start no earlier than 2003-09-10 |
| 198 |  | Receive and Inspect Flight Boom Structure Tubes (FM 2) | 40d | 2003-09-10 A | 2003-11-05 A |  | 100% |  | start no earlier than 2003-09-10 |
| 199 | 1.5.1.4 | **FM 1** | 159d | 2003-09-29 A | 2004-05-17 |  | 46% | 27d |  |
| 200 | 1.5.1.4.1 | **Telescoping** | 81d | 2003-10-27 A | 2004-02-24 |  | 59% | 29d |  |
| 201 | 1.5.1.4.1.1 | **Fabrication, Assembly & Test** | 81d | 2003-10-27 A | 2004-02-24 |  | 59% | 29d |  |
| 202 |  | Machine FM 1 Boom Structure Tubes as necessary | 5d | 2003-10-27 A | 2003-10-31 A | 197 | 100% |  |  |
| 203 |  | Machine FM 1 Boom Structure Parts (Rings) | 38d | 2003-11-07 A | 2004-01-05 A | 197FF+47d | 100% |  |  |
| 204 |  | Assemble FM 1 Boom Structure Telescoping Assembly | 20d | 2004-01-12 | 2004-02-09 | 202, 203 |  | 29d | start no earlier than 2004-01-12 |
| 205 |  | Test FM 1 Boom Structure Telescoping Assembly | 10d | 2004-02-10 | 2004-02-24 | 204 |  | 29d |  |
| 206 | 1.5.1.4.2 | **Harness** | 102d | 2003-09-29 A | 2004-02-26 |  | 41% | 27d |  |
| 207 | 1.5.1.4.2.1 | **Fabrication** | 72d | 2003-09-29 A | 2004-01-13 |  | 59% | 27d |  |
| 208 |  | Machine FM 1 Harness Parts | 72d | 2003-09-29 A | 2004-01-13 |  | 59% | 27d | start no earlier than 2003-09-29 |
| 209 | 1.5.1.4.2.2 | **Assembly & Test** | 30d | 2004-01-14 | 2004-02-26 |  |  | 27d |  |
| 210 |  | Assemble FM 1 Harness subassembly | 20d | 2004-01-14 | 2004-02-11 | 208 |  | 27d |  |

| ID | WBS | Task | Duration | Start | Finish | Predecessors | Complete | Total float | Constraint |
| --- | --- | --- | --- | --- | --- | --- | --- | --- | --- |
| 211 |  | FM1 Harness Test | 10d | 2004-02-12 | 2004-02-26 | 210 |  | 27d |  |
| 212 | 1.5.1.4.3 | **Mounting** | 38d | 2003-09-29 A | 2003-11-21 A |  | 100% |  |  |
| 213 |  | FM 1Boom Structure Mounting Fabrication | 28d | 2003-09-29 A | 2003-11-06 A |  | 100% |  | start no earlier than 2003-09-29 |
| 214 |  | FM 1Boom Structure Mounting Assembly | 10d | 2003-11-07 A | 2003-11-21 A | 213 | 100% |  |  |
| 215 | 1.5.1.4.4 | **Integration & Test** | 57d | 2004-02-27 | 2004-05-17 |  |  | 27d |  |
| 216 |  | Integrate FM 1 Boom Structure subassemblies | 20d | 2004-02-27 | 2004-03-25 | 205, 211 |  | 27d |  |
| 217 |  | FM 1 Boom Structure Deployment Test | 10d | 2004-03-26 | 2004-04-08 | 216 |  | 27d |  |
| 218 |  | FM 1 Boom Structure Vibration Testing Completed | 4d | 2004-04-15 | 2004-04-20 | 217, 356 |  | 27d |  |
| 219 |  | FM 1 Boom Structure Themal Vac Testing Completed | 15d | 2004-04-21 | 2004-05-11 | 218 |  | 27d |  |
| 220 |  | FM 1 Boom Structure Post Environmental Deployment Test Completed | 4d | 2004-05-12 | 2004-05-17 | 219 |  | 27d |  |
| 221 | 1.5.1.5 | **FM 2** | 174d | 2003-09-29 A | 2004-06-08 |  | 47% | 73d |  |
| 222 | 1.5.1.5.1 | **Telescoping** | 73d | 2003-11-06 A | 2004-02-24 |  | 62% | 90d |  |
| 223 | 1.5.1.5.1.1 | **Fabrication, Assembly & Test** | 73d | 2003-11-06 A | 2004-02-24 |  | 62% | 90d |  |
| 224 |  | Machine FM 2 Boom Structure Tubes as necessary | 11d | 2003-11-06 A | 2003-11-21 A | 198 | 100% |  |  |
| 225 |  | Machine FM 2 Boom Structure Parts (Rings) | 38d | 2003-11-07 A | 2004-01-05 A | 203SS | 100% |  |  |
| 226 |  | Assemble FM 2 Boom Structure Telescoping Assembly | 20d | 2004-01-12 | 2004-02-09 | 224, 225 |  | 90d | start no earlier than 2004-01-12 |
| 227 |  | Test FM 2 Boom Structure Telescoping Assembly | 10d | 2004-02-10 | 2004-02-24 | 226 |  | 90d |  |
| 228 | 1.5.1.5.2 | **Harness** | 102d | 2003-09-29 A | 2004-02-26 |  | 41% | 88d |  |
| 229 | 1.5.1.5.2.1 | **Fabrication** | 72d | 2003-09-29 A | 2004-01-13 |  | 59% | 88d |  |
| 230 |  | Machine FM 2 Harness Parts | 72d | 2003-09-29 A | 2004-01-13 | 208SS | 59% | 88d |  |
| 231 | 1.5.1.5.2.2 | **Assembly & Test** | 30d | 2004-01-14 | 2004-02-26 |  |  | 88d |  |
| 232 |  | Assemble FM 2 Harness subassembly | 20d | 2004-01-14 | 2004-02-11 | 230 |  | 88d |  |
| 233 |  | FM 2 Harness Test | 10d | 2004-02-12 | 2004-02-26 | 232 |  | 88d |  |
| 234 | 1.5.1.5.3 | **Mounting** | 38d | 2003-09-29 A | 2003-11-21 A |  | 100% |  |  |
| 235 |  | FM 2 Boom Structure Mountings Fabrication | 28d | 2003-09-29 A | 2003-11-06 A | 213SS | 100% |  |  |
| 236 |  | FM 2 Boom Structure Mountings Assembly | 10d | 2003-11-07 A | 2003-11-21 A | 235 | 100% |  |  |
| 237 | 1.5.1.5.4 | **Integration & Test** | 72d | 2004-02-27 | 2004-06-08 |  |  | 73d |  |
| 238 |  | Integrate FM 2 Boom Structure subassemblies | 20d | 2004-02-27 | 2004-03-25 | 227, 233 |  | 88d |  |
| 239 |  | FM 2 Boom Structure Deployment Test | 10d | 2004-03-26 | 2004-04-08 | 238 |  | 88d |  |
| 240 |  | FM 2 Boom Structure Vibration Test | 4d | 2004-04-16 | 2004-04-21 | 239, 362 |  | 87d |  |
| 241 |  | FM 2 Boom Structure Themal Vac Testing | 15d | 2004-05-12 | 2004-06-02 | 240, 219 |  | 73d |  |
| 242 |  | FM 2 Boom Structure Post Environmental Deployment Test | 4d | 2004-06-03 | 2004-06-08 | 241 |  | 73d |  |
| 243 | 1.5.2 | **MAG - GSFC** | 47d | 2004-01-09 | 2004-03-17 |  |  | 63d |  |
| 244 | 1.5.2.1 | **Deliveries** | 22d | 2004-02-17 | 2004-03-17 |  |  | 63d |  |
| 245 |  | Deliver MAG FM 1 (to UCB for IDPU/BOOM Suite FM 1 I&T) | 2d | 2004-02-17 | 2004-02-18 | 249 |  | 63d |  |
| 246 |  | Deliver MAG FM 2 (to UCB for IDPU/BOOM Suite FM 2 I&T) | 2d | 2004-03-16 | 2004-03-17 | 252 |  | 69d |  |
| 247 | 1.5.2.2 | **FM 1** | 25d | 2004-01-09 | 2004-02-13 |  |  | 63d |  |
| 248 |  | FM 1 MAG Testing | 10d | 2004-01-09 | 2004-01-23 |  |  | 63d | start no earlier than 2004-01-09 |
| 249 |  | MAG FM 1 Calibration | 15d | 2004-01-26 | 2004-02-13 | 248 |  | 63d |  |
| 250 | 1.5.2.3 | **FM 2** | 25d | 2004-02-09 | 2004-03-15 |  |  | 69d |  |
| 251 |  | FM 2 MAG Testing | 10d | 2004-02-09 | 2004-02-23 |  |  | 69d | start no earlier than 2004-02-09 |
| 252 |  | MAG FM 2 Calibration | 15d | 2004-02-24 | 2004-03-15 | 251 |  | 69d |  |
| 253 | 1.5.3 | **SWEA - CESR** | 79d | 2003-12-08 A | 2004-03-31 |  | 6% | 76d |  |
| 254 | 1.5.3.1 | **Deliveries** | 79d | 2003-12-08 A | 2004-03-31 |  | 50% | 76d |  |
| 255 |  | SWEA FM 1 Delivery to UCB | 3d | 2003-12-08 A | 2003-12-10 A |  | 100% |  | start no earlier than 2003-12-08 |
| 256 |  | SWEA FM 2 Delivery to UCB | 3d | 2004-03-29 | 2004-03-31 | 259 |  | 76d |  |
| 257 | 1.5.3.2 | **FM 2** | 47d | 2004-01-21 | 2004-03-26 |  |  | 76d |  |
| 258 |  | SWEA FM 2 Final Assembly (Block 2) | 3d | 2004-01-21 | 2004-01-23 |  |  | 76d | start no earlier than 2004-01-21 |
| 259 |  | SWEA FM 2 Calibration | 44d | 2004-01-26 | 2004-03-26 | 258 |  | 76d |  |
| 260 | 1.5.4 | **STE - UCB** | 153d | 2003-08-29 A | 2004-04-09 |  | 55% | 87d |  |
| 261 | 1.5.4.1 | **Deliveries** | 8d | 2004-03-30 | 2004-04-09 |  |  | 31d |  |
| 262 |  | Deliver STE-D FM 1 (stays at UCB for SWEA/STE-D FM 1 I&T) | 0d | 2004-03-30 | 2004-03-30 | 277 |  | 31d |  |
| 263 |  | Deliver STE-D FM 2 (stays at UCB for SWEA/STE-D FM 2 I&T) | 0d | 2004-04-09 | 2004-04-09 | 285 |  | 69d |  |
| 264 |  | Deliver STE-U FM 1 (stays at UCB for BOOM Suite FM 1 I&T) | 0d | 2004-04-05 | 2004-04-05 | 278 |  | 30d |  |
| 265 |  | Deliver STE-U FM 2 (stays at UCB for BOOM Suite FM 2 I&T) | 0d | 2004-04-09 | 2004-04-09 | 286 |  | 87d |  |
| 266 | 1.5.4.2 | **STE-U/D Housing** | 38d | 2003-11-21 A | 2004-01-16 |  | 71% | 99d |  |
| 267 |  | Fabricate STE FM 1 Box | 38d | 2003-11-21 A | 2004-01-16 |  | 71% | 40d | start no earlier than 2003-11-21 |
| 268 |  | Fabricate STE FM 2 Box | 38d | 2003-11-21 A | 2004-01-16 |  | 71% | 99d | start no earlier than 2003-11-21 |
| 269 | 1.5.4.3 | **STE-U/D Detector Boards** | 153d | 2003-08-29 A | 2004-04-09 |  | 51% | 87d |  |
| 270 |  | Coupon Test STE FM 1 & FM 2 Detector Printed Wiring Board | 17d | 2003-10-10 A | 2003-11-04 A | 272, 280 | 100% |  | start no earlier than 2003-10-10 |
| 271 | 1.5.4.3.2 | **FM 1** | 149d | 2003-08-29 A | 2004-04-05 |  | 47% | 30d |  |
| 272 |  | Fabrication STE FM 1 Detector Printed Wiring Board | 29d | 2003-08-29 A | 2003-10-09 A |  | 100% |  | start no earlier than 2003-08-29 |
| 273 |  | Load STE FM 1 Detector Printed Wiring Board | 49d | 2003-11-05 A | 2004-01-16 | 270 | 78% | 30d |  |
| 274 |  | Test STE FM 1 Detector Printed Wiring Board | 10d | 2004-01-20 | 2004-02-02 | 273 |  | 30d |  |
| 275 | 1.5.4.3.2.4 | **Integration & Test** | 44d | 2004-02-03 | 2004-04-05 |  |  | 30d |  |
| 276 |  | Integrate & Test STE-U/D FM 1 Detectors W/ FM 1 Housings | 20d | 2004-02-03 | 2004-03-02 | 267, 274 |  | 30d |  |
| 277 |  | Calibrate STE-U/D FM 1 | 20d | 2004-03-03 | 2004-03-30 | 276 |  | 30d |  |
| 278 |  | STE-U FM 1 Thermal Vacuum/Balance | 14d | 2004-03-17 | 2004-04-05 | 277FS-10d |  | 30d |  |
| 279 | 1.5.4.3.3 | **FM 2** | 153d | 2003-08-29 A | 2004-04-09 |  | 48% | 87d |  |
| 280 |  | Fabricate STE FM 2 Detector Printed Wiring Board | 29d | 2003-08-29 A | 2003-10-09 A |  | 100% |  | start no earlier than 2003-08-29 |

| ID | WBS | Task | Duration | Start | Finish | Predecessors | Complete | Total float | Constraint |
| --- | --- | --- | --- | --- | --- | --- | --- | --- | --- |
| 281 |  | Load STE FM 2 Detector Printed Wiring Board | 63d | 2003-11-05 A | 2004-02-06 | 270 | 60% | 75d |  |
| 282 |  | Test STE FM 2 Detector Printed Wiring Board | 10d | 2004-02-09 | 2004-02-23 | 281 |  | 75d |  |
| 283 | 1.5.4.3.3.4 | **Integration & Test** | 28d | 2004-03-03 | 2004-04-09 |  |  | 69d |  |
| 284 |  | Integrate & Test STE-U/D FM 2 Detectors W/ FM 2 Housings | 10d | 2004-03-03 | 2004-03-16 | 268, 282, 276 |  | 69d |  |
| 285 |  | Calibrate STE-U/D FM 2 | 18d | 2004-03-17 | 2004-04-09 | 284 |  | 69d |  |
| 286 |  | STE-U FM 2 Thermal Vacuum | 10d | 2004-03-29 | 2004-04-09 | 285FS-10d |  | 87d |  |
| 287 | 1.5.5 | **STE and SWEA - UCB** | 276d | 2003-07-01 A | 2004-08-03 |  | 67% | 309d |  |
| 288 | 1.5.5.1 | **Deliveries** | 125d | 2004-02-06 | 2004-08-03 |  |  | 33d |  |
| 289 |  | Deliver STE-U FM 1 Interface (stays at UCB for IDPU FM 1 I&T) | 0d | 2004-02-06 | 2004-02-06 | 338 |  | 79d |  |
| 290 |  | Deliver STE-U FM 2 Interface (stays at UCB for IDPU FM 2 I&T) | 0d | 2004-02-20 | 2004-02-20 | 347 |  | 87d |  |
| 291 |  | Deliver SWEA/STE-D FM 1 (stays at UCB for Boom Suite FM 1 I&T) | 0d | 2004-05-17 | 2004-05-17 | 344 |  | 27d |  |
| 292 |  | Deliver SWEA/STE-D FM 2 (stays at UCB for Boom Suite FM 2 I&T) | 0d | 2004-08-03 | 2004-08-03 | 353 |  | 33d |  |
| 293 | 1.5.5.2 | **SWEA Pedestal** | 137d | 2003-07-01 A | 2004-01-16 |  | 92% | 97d |  |
| 294 |  | Fabricate SWEA FM 1 Baseplate | 137d | 2003-07-01 A | 2004-01-16 |  | 92% | 51d | start no earlier than 2003-07-01 |
| 295 |  | Fabricate SWEA FM 2 Baseplate | 137d | 2003-07-01 A | 2004-01-16 |  | 92% | 97d | start no earlier than 2003-07-01 |
| 296 | 1.5.5.3 | **STE-D Pre-Amp Board** | 98d | 2003-09-22 A | 2004-02-12 |  | 89% | 79d |  |
| 297 | 1.5.5.3.1 | **FM 1** | 98d | 2003-09-22 A | 2004-02-12 |  | 87% | 33d |  |
| 298 |  | Fabricate STE-D FM 1 Preamp Printed Wiring Board | 34d | 2003-09-22 A | 2003-11-07 A |  | 100% |  | start no earlier than 2003-09-22 |
| 299 |  | Load STE-D FM 1 Preamp Printed Wiring Board | 5d | 2004-02-06 | 2004-02-12 | 303 |  | 33d | start no earlier than 2004-02-06 |
| 300 | 1.5.5.3.2 | **FM 2** | 98d | 2003-09-22 A | 2004-02-12 |  | 87% | 79d |  |
| 301 |  | Fabricate STE-D FM 2 Preamp Printed Wiring Board | 34d | 2003-09-22 A | 2003-11-07 A |  | 100% |  | start no earlier than 2003-09-22 |
| 302 |  | Load STE-D FM 2 Preamp Printed Wiring Board | 5d | 2004-02-06 | 2004-02-12 | 299SS |  | 79d |  |
| 303 |  | Coupon Test STE-D FM 1 & FM 2 Pre-Amp Printed Wiring Boards | 15d | 2003-11-10 A | 2003-12-02 A | 298, 301 | 100% |  |  |
| 304 | 1.5.5.4 | **STE-D Shaper Board** | 94d | 2003-12-04 A | 2004-04-19 |  | 64% | 33d |  |
| 305 | 1.5.5.4.1 | **FM 1** | 44d | 2003-12-04 A | 2004-02-06 |  | 67% | 37d |  |
| 306 |  | Fabricate STE-D FM 1 Shaper Printed Wiring Board | 10d | 2003-12-04 A | 2003-12-17 A |  | 100% |  | start no earlier than 2003-12-04 |
| 307 |  | Load STE-D FM 1 Shaper Printed Wiring Board | 5d | 2004-02-02 | 2004-02-06 | 311 |  | 37d | start no earlier than 2004-02-02 |
| 308 | 1.5.5.4.2 | **FM 2** | 94d | 2003-12-04 A | 2004-04-19 |  | 67% | 33d |  |
| 309 |  | Fabricate STE-D FM 2 Shaper Printed Wiring Board | 10d | 2003-12-04 A | 2003-12-17 A |  | 100% |  | start no earlier than 2003-12-04 |
| 310 |  | Load STE-D FM 2 Shaper Printed Wiring Board | 5d | 2004-04-13 | 2004-04-19 | 311, 342 |  | 33d |  |
| 311 |  | Coupon Test STE-D FM 1 & FM 2 Shaper Printed Wiring Boards | 15d | 2003-12-18 A | 2004-01-09 | 306, 309 | 60% | 51d |  |
| 312 | 1.5.5.5 | **STE-D Interface Board** | 94d | 2003-12-04 A | 2004-04-19 |  | 64% | 384d |  |
| 313 | 1.5.5.5.1 | **FM 1** | 44d | 2003-12-04 A | 2004-02-06 |  | 67% | 37d |  |
| 314 |  | Fabricate SWEA / STE-D FM 1 Digital to Analog Converter Printed Wiring Board | 10d | 2003-12-04 A | 2003-12-17 A |  | 100% |  | start no earlier than 2003-12-04 |
| 315 |  | Load SWEA / STE-D FM 1 Digital to Analog Converter Printed Wiring Board | 5d | 2004-02-02 | 2004-02-06 | 307SS |  | 37d |  |
| 316 | 1.5.5.5.2 | **FM 2** | 94d | 2003-12-04 A | 2004-04-19 |  | 67% | 33d |  |
| 317 |  | Fabricate SWEA / STE-D FM 2 Digital to Analog Converter Printed Wiring Board | 10d | 2003-12-04 A | 2003-12-17 A |  | 100% |  | start no earlier than 2003-12-04 |
| 318 |  | Load SWEA / STE-D FM 2 Digital to Analog Converter Printed Wiring Board | 5d | 2004-04-13 | 2004-04-19 | 310SS |  | 33d |  |
| 319 |  | Coupon Test STE-D FM 1 & FM 2 D/A Converter Printed Wiring Boards | 15d | 2003-12-18 A | 2004-01-09 | 314, 317 | 60% | 453d |  |
| 320 | 1.5.5.6 | **STE-U Pre-Amp Board** | 98d | 2003-09-22 A | 2004-02-12 |  | 95% | 87d |  |
| 321 | 1.5.5.6.1 | **FM 1** | 79d | 2003-09-22 A | 2004-01-15 A |  | 100% |  |  |
| 322 |  | Fabricate STE-U FM 1 Preamp Printed Wiring Board | 34d | 2003-09-22 A | 2003-11-07 A |  | 100% |  | start no earlier than 2003-09-22 |
| 323 |  | Load STE-U FM 1 Preamp Printed Wiring Board | 4d | 2004-01-12 A | 2004-01-15 A | 327 | 100% |  | start no earlier than 2004-01-12 |
| 324 | 1.5.5.6.2 | **FM 2** | 98d | 2003-09-22 A | 2004-02-12 |  | 87% | 87d |  |
| 325 |  | Fabricate STE-U FM 2 Preamp Printed Wiring Board | 34d | 2003-09-22 A | 2003-11-07 A |  | 100% |  | start no earlier than 2003-09-22 |
| 326 |  | Load STE-U FM 2 Preamp Printed Wiring Board | 5d | 2004-02-06 | 2004-02-12 | 327 |  | 87d | start no earlier than 2004-02-06 |
| 327 |  | Coupon Test STE-U FM 1 & FM 2 Pre-Amp Printed Wiring Boards | 15d | 2003-11-10 A | 2003-12-02 A | 322, 325 | 100% |  |  |
| 328 | 1.5.5.7 | **STE-U Shaper & Interface Board** | 39d | 2003-12-04 A | 2004-01-30 |  | 64% | 96d |  |
| 329 | 1.5.5.7.1 | **FM 1** | 39d | 2003-12-04 A | 2004-01-30 |  | 67% | 79d |  |
| 330 |  | Fabricate STE-U FM 1Shaper & Interface Printed Wiring Board | 10d | 2003-12-04 A | 2003-12-17 A |  | 100% |  | start no earlier than 2003-12-04 |
| 331 |  | Load STE-U FM 1 Shaper & Interface Printed Wiring Board | 5d | 2004-01-26 | 2004-01-30 | 335 |  | 79d | start no earlier than 2004-01-26 |
| 332 | 1.5.5.7.2 | **FM 2** | 39d | 2003-12-04 A | 2004-01-30 |  | 67% | 96d |  |
| 333 |  | Fabricate STE-U FM 2 Shaper & Interface Printed Wiring Board | 10d | 2003-12-04 A | 2003-12-17 A |  | 100% |  | start no earlier than 2003-12-04 |
| 334 |  | Load STE-U FM 2 Shaper & Interface Printed Wiring Board | 5d | 2004-01-26 | 2004-01-30 | 331SS |  | 96d |  |
| 335 |  | Coupon Test STE-U FM 1 & FM 2 Shaper & Interface Printed Wiring Boards | 15d | 2003-12-18 A | 2004-01-09 | 330, 333 | 60% | 88d |  |
| 336 | 1.5.5.8 | **Integration & Test** | 130d | 2004-02-02 | 2004-08-03 |  |  | 33d |  |
| 337 | 1.5.5.8.1 | **FM 1** | 123d | 2004-02-02 | 2004-07-23 |  |  | 37d |  |
| 338 |  | Integrate & Test STE-U FM 1 Interface Boards | 5d | 2004-02-02 | 2004-02-06 | 323, 331 |  | 79d |  |
| 339 |  | Integrate & Test SWEA/STE-D FM 1 Interface Boards | 20d | 2004-02-13 | 2004-03-12 | 294, 299, 307, 315 |  | 33d |  |
| 340 |  | Integrate & Test SWEA/STE-D FM 1 Interface with SWEA/STE-D FM 1 LVPS | 10d | 2004-03-23 | 2004-04-05 | 339, 72 |  | 27d |  |
| 341 |  | Clean/Coat/Stake SWEA/STE-D Interface | 10d | 2004-03-15 | 2004-03-26 | 339 |  | 33d |  |
| 342 |  | Integrate & Test SWEA/STE-D FM 1 Combined | 5d | 2004-04-06 | 2004-04-12 | 340, 341, 255, 262 |  | 27d |  |
| 343 |  | Calibrate SWEA/STE FM 1 | 20d | 2004-04-13 | 2004-05-10 | 342 |  | 27d |  |
| 344 |  | SWEA/STE FM 1 Vibration | 5d | 2004-05-11 | 2004-05-17 | 343 |  | 27d |  |
| 345 |  | SWEA/STE-D FM 1 Thermal Vac/Thermal Balance | 14d | 2004-07-06 | 2004-07-23 | 18 |  | 37d |  |
| 346 | 1.5.5.8.2 | **FM 2** | 121d | 2004-02-13 | 2004-08-03 |  |  | 33d |  |
| 347 |  | Integrate & Test STE-U FM 2 Interface Boards | 5d | 2004-02-13 | 2004-02-20 | 326, 334 |  | 87d |  |
| 348 |  | Integrate & Test SWEA/STE-D FM 2 Interface Boards | 20d | 2004-04-20 | 2004-05-17 | 295, 302, 310, 318 |  | 33d |  |
| 349 |  | Integrate & Test SWEA/STE-D FM 2 Interface with SWEA/STE-D FM 2 LVPS | 10d | 2004-05-18 | 2004-06-01 | 348, 78 |  | 33d |  |
| 350 |  | Integrate & Test SWEA/STE-D FM 2 Combined | 10d | 2004-06-02 | 2004-06-15 | 349, 256, 263 |  | 33d |  |

| ID | WBS | Task | Duration | Start | Finish | Predecessors | Complete | Total float | Constraint |
| --- | --- | --- | --- | --- | --- | --- | --- | --- | --- |
| 351 |  | Calibrate SWEA/STE FM 2 | 20d | 2004-06-16 | 2004-07-13 | 350 |  | 33d |  |
| 352 |  | SWEA/STE FM 2 Vibration | 5d | 2004-07-14 | 2004-07-20 | 351 |  | 33d |  |
| 353 |  | SWEA/STE-D FM 2 Thermal Vac | 10d | 2004-07-21 | 2004-08-03 | 352 |  | 33d |  |
| 354 | 1.5.6 | **Boom Suite I&T - UCB** | 108d | 2004-04-09 | 2004-09-09 |  |  | 27d |  |
| 355 | 1.5.6.1 | **FM 1** | 90d | 2004-04-09 | 2004-08-13 |  |  | 27d |  |
| 356 |  | FM 1 Boom/MAG/STE-U I&T | 4d | 2004-04-09 | 2004-04-14 | 217, 245, 264 |  | 27d |  |
| 357 |  | FM 1 Boom/SWEA/STE/MAG I&T | 2d | 2004-05-18 | 2004-05-19 | 291, 191 |  | 27d |  |
| 358 |  | FM 1 Integrated Boom/IDPU I&T | 4d | 2004-05-20 | 2004-05-25 | 357, 191, 164 |  | 27d |  |
| 359 |  | BOOM Suite FM 1 Bakeout | 5d | 2004-07-26 | 2004-07-30 | 358, 345 |  | 37d |  |
| 360 |  | Final BOOM Suite FM 1 I & T | 10d | 2004-08-02 | 2004-08-13 | 359, 181 |  | 37d |  |
| 361 | 1.5.6.2 | **FM 2** | 107d | 2004-04-12 | 2004-09-09 |  |  | 33d |  |
| 362 |  | FM 2 Boom/MAG/STE-U I&T | 4d | 2004-04-12 | 2004-04-15 | 239, 246, 265 |  | 87d |  |
| 363 |  | FM 2 Boom/SWEA/STE/MAG I&T | 2d | 2004-08-04 | 2004-08-05 | 292, 192 |  | 33d |  |
| 364 |  | FM 2 Integrated Boom/IDPU I&T | 4d | 2004-08-06 | 2004-08-11 | 363, 192, 775 |  | 33d |  |
| 365 |  | Boom Suite FM 2 EMC | 5d | 2004-08-12 | 2004-08-18 | 364 |  | 33d |  |
| 366 |  | BOOM Suite FM 2 Bakeout | 5d | 2004-08-19 | 2004-08-25 | 365 |  | 33d |  |
| 367 |  | Final BOOM Suite FM 2 I & T | 10d | 2004-08-26 | 2004-09-09 | 366, 186 |  | 33d |  |
| 368 | 1.6 | **SEP Suite - CIT** | 351d | 2003-06-02 A | 2004-10-20 |  | 29% | 255d |  |
| 369 | 1.6.1 | **SEP Mechanical - Sandy Shuman (GSFC)** | 93d | 2004-01-22 | 2004-06-02 |  |  | 19d |  |
| 370 | 1.6.1.1 | **SIT Electronics Enclosure (Priority 1)** | 21d | 2004-01-22 | 2004-02-20 |  |  | 22d |  |
| 371 |  | Complete Design/Drawings for SIT Enclosure | 5d | 2004-01-22 | 2004-01-28 |  |  | 22d | start no earlier than 2004-01-22 |
| 372 |  | Fabrication of SIT Enclosure | 10d | 2004-01-29 | 2004-02-11 | 371 |  | 33d |  |
| 373 |  | Inspection and Final Assembly of SIT Enclosure | 5d | 2004-02-12 | 2004-02-19 | 372 |  | 33d |  |
| 374 |  | Deliver SIT Enclosure to UMD | 1d | 2004-02-20 | 2004-02-20 | 373 |  | 33d |  |
| 375 | 1.6.1.2 | **SEP FM 1 & FM 2 LVPS Boxes (Priority 2)** | 23d | 2004-01-29 | 2004-03-02 |  |  | 22d |  |
| 376 |  | Complete Design/Drawings for SEP LVPS Boxes | 5d | 2004-01-29 | 2004-02-04 | 371 |  | 22d |  |
| 377 |  | Fabrication of SEP LVPS Boxes | 10d | 2004-02-05 | 2004-02-19 | 376 |  | 50d |  |
| 378 |  | Inspection and Final Assembly of SEP LVPS Boxes | 5d | 2004-02-20 | 2004-02-26 | 377 |  | 50d |  |
| 379 |  | Deliver SEP LVPS Boxes to UCB | 3d | 2004-02-27 | 2004-03-02 | 378 |  | 50d |  |
| 380 | 1.6.1.3 | **SEP Electronics Enclosure (Priority 3)** | 31d | 2004-02-05 | 2004-03-19 |  |  | 22d |  |
| 381 |  | Complete Design/Drawings for SEP Enclosure | 13d | 2004-02-05 | 2004-02-24 | 376 |  | 22d |  |
| 382 |  | Fabrication of SEP Enclosure | 10d | 2004-02-25 | 2004-03-09 | 381 |  | 65d |  |
| 383 |  | Inspection and Final Assembly of SEP Enclosure | 5d | 2004-03-10 | 2004-03-16 | 382 |  | 65d |  |
| 384 |  | Deliver SEP Enclosure to CIT | 3d | 2004-03-17 | 2004-03-19 | 383 |  | 65d |  |
| 385 | 1.6.1.4 | **SEP Central Bias Supply Shields (Priority 4)** | 20d | 2004-02-25 | 2004-03-23 |  |  | 22d |  |
| 386 |  | Complete Design/Drawings for Bias Supply Shields | 5d | 2004-02-25 | 2004-03-02 | 381 |  | 22d |  |
| 387 |  | Fabrication of Bias Supply Shields | 10d | 2004-03-03 | 2004-03-16 | 386 |  | 22d |  |
| 388 |  | Inspection and Delivery (to CIT) of Bias Supply Shields | 5d | 2004-03-17 | 2004-03-23 | 387 |  | 22d |  |
| 389 | 1.6.1.5 | **LET Telescope (Priority 5)** | 26d | 2004-03-03 | 2004-04-07 |  |  | 25d |  |
| 390 |  | Complete Design/Drawings for LET Telescope | 8d | 2004-03-03 | 2004-03-12 | 386 |  | 25d |  |
| 391 |  | Fabrication of LET Telescope | 10d | 2004-03-15 | 2004-03-26 | 390 |  | 38d |  |
| 392 |  | Inspection and Final Assembly of LET Telescope | 5d | 2004-03-29 | 2004-04-02 | 391 |  | 38d |  |
| 393 |  | Deliver LET Telescope to CIT | 3d | 2004-04-05 | 2004-04-07 | 392 |  | 38d |  |
| 394 | 1.6.1.6 | **HET Electronics Enclosure (Priority 6)** | 23d | 2004-03-15 | 2004-04-14 |  |  | 25d |  |
| 395 |  | Complete Design/Drawings for HET Enclosure | 8d | 2004-03-15 | 2004-03-24 | 390 |  | 25d |  |
| 396 |  | Fabrication of HET Enclosure | 10d | 2004-03-25 | 2004-04-07 | 395 |  | 25d |  |
| 397 |  | Inspection and Final Assembly of HET Enclosure | 5d | 2004-04-08 | 2004-04-14 | 396 |  | 25d |  |
| 398 |  | Deliver HET Enclosure (stays at GSFC) | 0d | 2004-04-14 | 2004-04-14 | 397 |  | 25d |  |
| 399 | 1.6.1.7 | **HET Telescope (Priority 7)** | 61d | 2004-01-27 | 2004-04-21 |  |  | 16d |  |
| 400 |  | On Going work for HET Telescope (Complete Design/Drawings & Prep for Fab) | 46d | 2004-01-27 | 2004-03-31 |  |  | 16d | start no earlier than 2004-01-27 |
| 401 |  | Fabrication of HET Telescope | 10d | 2004-04-01 | 2004-04-14 | 400 |  | 25d |  |
| 402 |  | Inspection and Final Assembly of HET Telescope | 5d | 2004-04-15 | 2004-04-21 | 401, 398 |  | 25d |  |
| 403 |  | Deliver HET Telescope (stays at GSFC) | 0d | 2004-04-21 | 2004-04-21 | 402 |  | 25d |  |
| 404 | 1.6.1.8 | **SIT Telescope (Priority 8)** | 34d | 2004-04-01 | 2004-05-18 |  |  | 16d |  |
| 405 |  | Complete Design/Drawings for SIT Telescope | 18d | 2004-04-01 | 2004-04-26 | 400 |  | 16d |  |
| 406 |  | Fabrication of SIT Telescope | 10d | 2004-04-27 | 2004-05-10 | 405 |  | 16d |  |
| 407 |  | Inspection and Final Assembly of SIT Telescope | 5d | 2004-05-11 | 2004-05-17 | 406 |  | 16d |  |
| 408 |  | Deliver SIT Telescope to UMD | 1d | 2004-05-18 | 2004-05-18 | 407 |  | 16d |  |
| 409 | 1.6.1.9 | **Shipping Containers for HET, SIT & SEP Central (Priority 9)** | 23d | 2004-04-27 | 2004-05-27 |  |  | 23d |  |
| 410 |  | Design | 5d | 2004-04-27 | 2004-05-03 | 405 |  | 23d |  |
| 411 |  | Fabrication/Machining | 10d | 2004-05-04 | 2004-05-17 | 410 |  | 23d |  |
| 412 |  | Inspection and Assembly | 5d | 2004-05-18 | 2004-05-24 | 411 |  | 23d |  |
| 413 |  | HET Container stays at GSFC | 0d | 2004-05-24 | 2004-05-24 | 412 |  | 23d |  |
| 414 |  | SIT Container to UMD | 1d | 2004-05-25 | 2004-05-25 | 412 |  | 25d |  |
| 415 |  | SEP Central Container to CIT | 3d | 2004-05-25 | 2004-05-27 | 412 |  | 40d |  |
| 416 | 1.6.1.10 | **LET Radiation Test Fixture (Priority 10)** | 21d | 2004-05-04 | 2004-06-02 |  |  | 24d |  |
| 417 |  | Design | 5d | 2004-05-04 | 2004-05-10 | 410 |  | 24d |  |
| 418 |  | Fabrication | 10d | 2004-05-11 | 2004-05-24 | 417 |  | 24d |  |
| 419 |  | Inspection and Assembly | 5d | 2004-05-25 | 2004-06-01 | 418 |  | 24d |  |
| 420 |  | Deliver to CIT for SEP I&T | 1d | 2004-06-02 | 2004-06-02 | 419 |  | 24d |  |

| ID | WBS | Task | Duration | Start | Finish | Predecessors | Complete | Total float | Constraint |
| --- | --- | --- | --- | --- | --- | --- | --- | --- | --- |
| 421 | 1.6.2 | **SEP Central - CIT** | 211d | 2003-08-01 A | 2004-06-03 |  | 27% | 26d |  |
| 422 | 1.6.2.1 | **Deliveries** | 35d | 2004-04-14 | 2004-06-03 |  |  | 26d |  |
| 423 |  | Deliver all SEP Cen FM 1 Boards to SEP I&T (stays at CIT) | 0d | 2004-04-29 | 2004-04-29 | 447 |  | 36d |  |
| 424 |  | Deliver all SEP Cen FM 2 Boards & FM 2 LVPS to SEP I&T (stays at CIT) | 0d | 2004-04-29 | 2004-04-29 | 447 |  | 50d |  |
| 425 |  | SEP Central Build 3 Software Complete | 0d | 2004-04-14 | 2004-04-14 | 449 |  | 47d |  |
| 426 |  | Final SEP Central Flight Software Complete | 0d | 2004-06-03 | 2004-06-03 | 450 |  | 26d |  |
| 427 | 1.6.2.2 | **Logic Board** | 30d | 2004-02-13 | 2004-03-26 |  |  | 29d |  |
| 428 | 1.6.2.2.1 | **Assembly** | 10d | 2004-02-13 | 2004-02-27 |  |  | 29d |  |
| 429 |  | Assemble FM 1 SEP Central Logic board | 10d | 2004-02-13 | 2004-02-27 |  |  | 29d | start no earlier than 2004-02-13 |
| 430 |  | Assemble FM 2 SEP Central Logic board | 10d | 2004-02-13 | 2004-02-27 | 429SS |  | 29d |  |
| 431 | 1.6.2.2.2 | **Test** | 20d | 2004-03-01 | 2004-03-26 |  |  | 29d |  |
| 432 |  | Test FM 1 SEP Central Logic board (initial) | 20d | 2004-03-01 | 2004-03-26 | 429 |  | 29d |  |
| 433 |  | Test FM 2 SEP Central Logic board (initial) | 20d | 2004-03-01 | 2004-03-26 | 430 |  | 29d |  |
| 434 | 1.6.2.3 | **Analog/Post-Reg Board** | 0d | 2004-01-27 A | 2004-01-27 A |  | 100% |  |  |
| 435 |  | FM 1 Analog/Post-Reg Board Complete Test and awaiting Conformal Coat with other SEP Central Boards | 0d | 2004-01-27 A | 2004-01-27 A |  | 100% |  | start no earlier than 2004-01-27 |
| 436 |  | FM 2 Analog/Post-Reg Board Complete Test and awaiting Conformal Coat with other SEP Central Boards | 0d | 2004-01-27 A | 2004-01-27 A |  | 100% |  | start no earlier than 2004-01-27 |
| 437 | 1.6.2.4 | **SEP Solid State Detector Bias Supply Board** | 55d | 2004-01-20 | 2004-04-06 |  |  | 22d |  |
| 438 | 1.6.2.4.1 | **Assembly & Initial Test** | 40d | 2004-01-20 | 2004-03-16 |  |  | 27d |  |
| 439 |  | Assemble and Initial Test FM 1 SSD Bias Supply Board | 40d | 2004-01-20 | 2004-03-16 |  |  | 27d | start no earlier than 2004-01-20 |
| 440 |  | Assemble and Initial Test FM 2 SSD Bias Supply Board | 40d | 2004-01-20 | 2004-03-16 | 439SS |  | 27d |  |
| 441 | 1.6.2.4.2 | **Final Test** | 10d | 2004-03-24 | 2004-04-06 |  |  | 22d |  |
| 442 |  | Final Test FM 1 SSD Bias Supply Board | 10d | 2004-03-24 | 2004-04-06 | 439, 388 |  | 22d |  |
| 443 |  | Final Test FM 2 SSD Bias Supply Board | 10d | 2004-03-24 | 2004-04-06 | 440, 388 |  | 22d |  |
| 444 | 1.6.2.5 | **Conformal Coat, Mass Properties and Bake Out (SEP Central, LET, SEP LVPS)** | 17d | 2004-04-07 | 2004-04-29 |  |  | 22d |  |
| 445 |  | Stake/Conformal Coat All SEP Central and LET Boards | 10d | 2004-04-07 | 2004-04-20 | 432, 433, 435, 436, 442, 443, 512, 513 |  | 22d |  |
| 446 |  | Mass Properties/Photo All SEP Central and LET Boards | 4d | 2004-04-21 | 2004-04-26 | 445 |  | 22d |  |
| 447 |  | Bake Out All SEP Central/LET Boards and SEP LVPS (FM 1 & 2) | 3d | 2004-04-27 | 2004-04-29 | 446, 77, 71 |  | 22d |  |
| 448 | 1.6.2.6 | **Flight Software** | 211d | 2003-08-01 A | 2004-06-03 |  | 49% | 26d |  |
| 449 |  | SEP Central Build 3 | 176d | 2003-08-01 A | 2004-04-14 |  | 59% | 26d | start no earlier than 2003-08-01 |
| 450 |  | Final Flight S/W Build | 35d | 2004-04-15 | 2004-06-03 | 449 |  | 26d |  |
| 451 | 1.6.3 | **HET - GSFC** | 118d | 2004-01-06 | 2004-06-22 |  |  | 19d |  |
| 452 | 1.6.3.1 | **Deliveries** | 37d | 2004-04-30 | 2004-06-22 |  |  | 19d |  |
| 453 |  | Deliver HET FM 1 (to CIT for SEP Suite I&T) | 2d | 2004-05-28 | 2004-06-01 | 494, 413 |  | 20d |  |
| 454 |  | Deliver HET FM 2 (to CIT for SEP Suite I&T) | 2d | 2004-06-21 | 2004-06-22 | 497, 413 |  | 19d |  |
| 455 |  | Deliver Final HET Flight Software to SEP I&T | 2d | 2004-04-30 | 2004-05-03 | 490 |  | 40d |  |
| 456 | 1.6.3.2 | **Detectors** | 60d | 2004-01-06 | 2004-03-31 |  |  | 40d |  |
| 457 |  | Receive & Inspect HET Flight Detectors | 40d | 2004-01-06 | 2004-03-03 |  |  | 40d | start no earlier than 2004-01-06 |
| 458 | 1.6.3.2.2 | **Detector Testing** | 60d | 2004-01-06 | 2004-03-31 |  |  | 40d |  |
| 459 |  | Capacitance, Current, Depletion, Alpha Resolution Testing | 60d | 2004-01-06 | 2004-03-31 | 457SS |  | 40d |  |
| 460 |  | Life Test HET Detectors | 60d | 2004-01-06 | 2004-03-31 | 459SS |  | 40d |  |
| 461 | 1.6.3.3 | **Electronics Board** | 80d | 2004-01-22 | 2004-05-13 |  |  | 24d |  |
| 462 | 1.6.3.3.1 | **Assembly** | 36d | 2004-01-22 | 2004-03-12 |  |  | 24d |  |
| 463 |  | Install Socket on HET Electronics FM 1 Board for ETU ACTEL | 1d | 2004-01-22 | 2004-01-22 |  |  | 24d | start no earlier than 2004-01-22 |
| 464 |  | Complete Population of HET Electronics FM 1 Board (ETU ACTEL) | 1d | 2004-01-23 | 2004-01-23 | 463 |  | 24d |  |
| 465 |  | Complete Population of HET Electronics FM 2 Board (Flight ACTEL) | 2d | 2004-03-11 | 2004-03-12 | 464, 471, 506 |  | 30d |  |
| 466 | 1.6.3.3.2 | **Test** | 78d | 2004-01-26 | 2004-05-13 |  |  | 24d |  |
| 467 | 1.6.3.3.2.1 | **FM 1** | 40d | 2004-01-26 | 2004-03-22 |  |  | 24d |  |
| 468 |  | Test HET FM 1 Electronics Board w/ETU ACTEL | 20d | 2004-01-26 | 2004-02-23 | 464 |  | 24d |  |
| 469 |  | Remove ETU ACTEL and socket from HET FM 1 Electronics Board | 1d | 2004-02-24 | 2004-02-24 | 468 |  | 24d |  |
| 470 |  | Install Flight ACTEL on HET FM 1 Electronics Board | 1d | 2004-02-25 | 2004-02-25 | 469 |  | 24d |  |
| 471 |  | Retest HET FM 1 Electronics Board w/Flight ACTEL | 10d | 2004-02-26 | 2004-03-10 | 470 |  | 24d |  |
| 472 |  | Conformal Coat HET FM 1 Electronics Board | 2d | 2004-03-11 | 2004-03-12 | 471 |  | 24d |  |
| 473 |  | Retest Conformal Coated HET FM 1 Electronics Board | 2d | 2004-03-15 | 2004-03-16 | 472 |  | 24d |  |
| 474 |  | Bakeout HET FM 1 Electronics Board | 2d | 2004-03-17 | 2004-03-18 | 473 |  | 24d |  |
| 475 |  | Retest Bakedout HET FM 1 Electronics Board | 2d | 2004-03-19 | 2004-03-22 | 474 |  | 24d |  |
| 476 | 1.6.3.3.2.2 | **FM 2** | 38d | 2004-03-23 | 2004-05-13 |  |  | 24d |  |
| 477 |  | Test HET FM 2 Electronics Board | 30d | 2004-03-23 | 2004-05-03 | 465, 468, 475 |  | 24d |  |
| 478 |  | Conformal Coat HET FM 2 Electronics Board | 2d | 2004-05-04 | 2004-05-05 | 477 |  | 24d |  |
| 479 |  | Retest Conformal Coated HET FM 2 Electronics Board | 2d | 2004-05-06 | 2004-05-07 | 478, 473 |  | 24d |  |
| 480 |  | Bakeout HET FM 2 Electronics Board | 2d | 2004-05-10 | 2004-05-11 | 479 |  | 24d |  |
| 481 |  | Retest Bakedout HET FM 2 Electronics Board | 2d | 2004-05-12 | 2004-05-13 | 480, 475 |  | 24d |  |
| 482 | 1.6.3.4 | **Flight Software** | 70d | 2004-01-22 | 2004-04-29 |  |  | 19d |  |
| 483 | 1.6.3.4.1 | **Design** | 10d | 2004-01-22 | 2004-02-04 |  |  | 19d |  |
| 484 |  | Complete Definition of HET PH Event Processing | 10d | 2004-01-22 | 2004-02-04 |  |  | 19d | start no earlier than 2004-01-22 |
| 485 | 1.6.3.4.2 | **Coding** | 20d | 2004-02-05 | 2004-03-04 |  |  | 19d |  |
| 486 |  | Code HET PH Event Processing Update for Flight | 10d | 2004-02-05 | 2004-02-19 | 484 |  | 19d |  |
| 487 |  | Code HET Telemetry Formatting Update for Flight | 10d | 2004-02-20 | 2004-03-04 | 486 |  | 19d |  |
| 488 | 1.6.3.4.3 | **Test** | 40d | 2004-03-05 | 2004-04-29 |  |  | 19d |  |
| 489 |  | Test Integrated HET S/W with Simulated Data | 15d | 2004-03-05 | 2004-03-25 | 487 |  | 19d |  |
| 490 |  | Verify HET On-Board Software | 25d | 2004-03-26 | 2004-04-29 | 489 |  | 19d |  |

| ID | WBS | Task | Duration | Start | Finish | Predecessors | Complete | Total float | Constraint |
| --- | --- | --- | --- | --- | --- | --- | --- | --- | --- |
| 491 | 1.6.3.5 | **Integration & Test** | 35d | 2004-04-30 | 2004-06-18 |  |  | 19d |  |
| 492 | 1.6.3.5.1 | **FM 1** | 20d | 2004-04-30 | 2004-05-27 |  |  | 19d |  |
| 493 |  | Integrate HET FM 1 Electronics Telescope (Ahead) | 5d | 2004-04-30 | 2004-05-06 | 475, 460, 490, 403 |  | 19d |  |
| 494 |  | Test HET FM 1 Telescope (Ahead) | 15d | 2004-05-07 | 2004-05-27 | 493 |  | 19d |  |
| 495 | 1.6.3.5.2 | **FM 2** | 25d | 2004-05-14 | 2004-06-18 |  |  | 19d |  |
| 496 |  | Integrate HET FM 2 Electronics Telescope (Behind) | 5d | 2004-05-14 | 2004-05-20 | 481, 493, 460, 490, 403 |  | 24d |  |
| 497 |  | Test HET FM 2 Telescope (Behind) | 15d | 2004-05-28 | 2004-06-18 | 494, 496 |  | 19d |  |
| 498 | 1.6.4 | **LET - CIT** | 221d | 2003-07-14 A | 2004-05-27 |  | 56% | 36d |  |
| 499 | 1.6.4.1 | **Deliveries** | 17d | 2004-05-04 | 2004-05-27 |  |  | 36d |  |
| 500 |  | Deliver LET FM 1 (stays at CIT for SEP I&T) | 0d | 2004-05-27 | 2004-05-27 | 518 |  | 22d |  |
| 501 |  | Deliver LET FM 2 (stays at CIT for SEP I&T) | 0d | 2004-05-27 | 2004-05-27 | 520 |  | 36d |  |
| 502 |  | Deliver LET Flight Software Build 3 | 0d | 2004-05-04 | 2004-05-04 | 515 |  | 39d |  |
| 503 | 1.6.4.2 | **Detectors** | 167d | 2003-07-14 A | 2004-03-12 |  | 71% | 56d |  |
| 504 |  | Complete LET Flight Detector Testing | 167d | 2003-07-14 A | 2004-03-12 |  | 71% | 56d | start no earlier than 2003-07-14 |
| 505 | 1.6.4.3 | **Hybrids** | 144d | 2003-08-01 A | 2004-03-01 |  | 72% | 27d |  |
| 506 |  | Complete Test of Flight Hybrids (LET and to GSFC for HET FM 2) | 144d | 2003-08-01 A | 2004-03-01 |  | 72% | 27d | start no earlier than 2003-08-01 |
| 507 | 1.6.4.4 | **Detector/Misc Board** | 21d | 2004-03-02 | 2004-03-30 |  |  | 27d |  |
| 508 | 1.6.4.4.1 | **Assembly** | 10d | 2004-03-02 | 2004-03-15 |  |  | 27d |  |
| 509 |  | Assemble LET FM 1 Detector Board | 10d | 2004-03-02 | 2004-03-15 | 506 |  | 27d |  |
| 510 |  | Assemble LET FM 2 Detector Board | 10d | 2004-03-02 | 2004-03-15 | 506 |  | 27d |  |
| 511 | 1.6.4.4.2 | **Test** | 11d | 2004-03-16 | 2004-03-30 |  |  | 27d |  |
| 512 |  | Test LET FM 1 Detector Board | 11d | 2004-03-16 | 2004-03-30 | 509 |  | 27d |  |
| 513 |  | Test LET FM 2 Detector Board | 11d | 2004-03-16 | 2004-03-30 | 510 |  | 27d |  |
| 514 | 1.6.4.5 | **Flight Software** | 190d | 2003-08-01 A | 2004-05-04 |  | 55% | 39d |  |
| 515 |  | Let Flight Software Build 3 | 190d | 2003-08-01 A | 2004-05-04 |  | 55% | 39d | start no earlier than 2003-08-01 |
| 516 | 1.6.4.6 | **Integration & Test** | 20d | 2004-04-30 | 2004-05-27 |  |  | 22d |  |
| 517 | 1.6.4.6.1 | **FM 1** | 20d | 2004-04-30 | 2004-05-27 |  |  | 22d |  |
| 518 |  | Integrate LET FM 1 Housing With Detectors | 20d | 2004-04-30 | 2004-05-27 | 504, 447, 393 |  | 22d |  |
| 519 | 1.6.4.6.2 | **FM 2** | 20d | 2004-04-30 | 2004-05-27 |  |  | 36d |  |
| 520 |  | Integrate LET FM 2 Housing With Detectors | 20d | 2004-04-30 | 2004-05-27 | 504, 447, 393 |  | 36d |  |
| 521 | 1.6.5 | **SEPT - Kiel/ESTEC** | 240d | 2003-08-08 A | 2004-07-21 |  | 35% | 318d |  |
| 522 | 1.6.5.1 | **Deliveries** | 102d | 2004-03-01 | 2004-07-21 |  |  | 68d |  |
| 523 |  | Deliver SEPT-NS FM 1 to CIT for SEP I&T and Suite EMC | 5d | 2004-03-12 | 2004-03-18 | 567, 568 |  | 70d |  |
| 524 |  | Deliver SEPT-E FM 1 to CIT for SEP I&T and Suite EMC | 5d | 2004-03-01 | 2004-03-05 | 574, 575 |  | 79d |  |
| 525 |  | Final Delivery of SEPT FM 1 to APL | 2d | 2004-07-20 | 2004-07-21 | 569, 576 |  | 54d |  |
| 526 |  | Deliver SEPT-NS FM 2 to CIT for SEP I&T and Suite EMC | 5d | 2004-03-08 | 2004-03-12 | 582, 583 |  | 88d |  |
| 527 |  | Deliver SEPT-E FM 2 to CIT for SEP I&T and Suite EMC | 5d | 2004-03-08 | 2004-03-12 | 589, 590 |  | 88d |  |
| 528 |  | Final Delivery of SEPT FM 2 to APL | 2d | 2004-07-20 | 2004-07-21 | 584, 591 |  | 68d |  |
| 529 | 1.6.5.2 | **Mechanical Assembly** | 46d | 2003-12-22 A | 2004-02-27 |  | 66% | 420d |  |
| 530 | 1.6.5.2.1 | **FM 1** | 13d | 2003-12-22 A | 2004-01-09 A |  | 100% |  |  |
| 531 |  | Assemble SEPT-NS FM 1 Sensor and E-Box Housing | 13d | 2003-12-22 A | 2004-01-09 A |  | 100% |  | start no earlier than 2003-12-22 |
| 532 |  | Assemble SEPT-E FM 1 Sensor and E-Box Housing | 13d | 2003-12-22 A | 2004-01-09 A |  | 100% |  | start no earlier than 2003-12-22 |
| 533 | 1.6.5.2.2 | **FM 2** | 14d | 2003-12-29 A | 2004-01-16 A |  | 100% |  |  |
| 534 |  | Assemble SEPT-NS FM 2 Sensor and E-Box Housing | 14d | 2003-12-29 A | 2004-01-16 A | 531SS+4d | 100% |  |  |
| 535 |  | Assemble SEPT-E FM 2 Sensor and E-Box Housing | 14d | 2003-12-29 A | 2004-01-16 A | 532SS+4d | 100% |  |  |
| 536 | 1.6.5.2.3 | **Spare** | 28d | 2004-01-20 | 2004-02-27 |  |  | 420d |  |
| 537 |  | Assemble SEPT Spare Sensor and E-Box Housing | 28d | 2004-01-20 | 2004-02-27 | 534, 535 |  | 420d |  |
| 538 | 1.6.5.3 | **Electronics** | 144d | 2003-08-08 A | 2004-03-08 |  | 43% | 414d |  |
| 539 | 1.6.5.3.1 | **Assembly** | 124d | 2003-08-08 A | 2004-02-06 |  | 44% | 414d |  |
| 540 | 1.6.5.3.1.1 | **FM 2** | 106d | 2003-08-08 A | 2004-01-12 A |  | 100% |  |  |
| 541 |  | Assemble SEPT-NS FM 2 Electronics | 106d | 2003-08-08 A | 2004-01-12 A |  | 100% |  | start no earlier than 2003-08-08 |
| 542 |  | Assemble SEPT-E FM 2 Electronics | 92d | 2003-08-08 A | 2003-12-19 A |  | 100% |  | start no earlier than 2003-08-08 |
| 543 | 1.6.5.3.1.2 | **Spare** | 124d | 2003-08-08 | 2004-02-06 |  |  | 414d |  |
| 544 |  | Assemble SEPT-NS FS Electronics | 124d | 2003-08-08 | 2004-02-06 | 541SS |  | 414d |  |
| 545 |  | Assemble SEPT-E FS Electronics | 124d | 2003-08-08 | 2004-02-06 | 542SS |  | 414d |  |
| 546 | 1.6.5.3.2 | **Test** | 59d | 2003-12-11 A | 2004-03-08 |  | 35% | 414d |  |
| 547 | 1.6.5.3.2.1 | **FM 2** | 34d | 2003-12-11 A | 2004-01-30 |  | 74% | 439d |  |
| 548 |  | SEPT-NS FM 2 Electronics Test | 4d | 2004-01-13 A | 2004-01-16 A | 541 | 100% |  |  |
| 549 |  | SEPT-E FM 2 Electronics Test | 4d | 2003-12-11 A | 2003-12-16 A | 542FS-7d | 100% |  |  |
| 550 |  | Coat SEPT-NS FM 2 Electronics Board | 4d | 2004-01-20 | 2004-01-23 | 548 |  | 439d |  |
| 551 |  | Coat SEPT-E FM 2 Electronics Board | 5d | 2003-12-17 A | 2003-12-23 A | 549 | 100% |  |  |
| 552 |  | SEPT-NS FM 2 Mechanical Integration | 5d | 2004-01-26 | 2004-01-30 | 550 |  | 439d |  |
| 553 |  | SEPT-E FM 2 Mechanical Integration | 13d | 2003-12-24 A | 2004-01-13 A | 551 | 100% |  |  |
| 554 | 1.6.5.3.2.2 | **Spare** | 20d | 2004-02-09 | 2004-03-08 |  |  | 414d |  |
| 555 |  | SEPT-NS Flight Spare Electronics Test | 5d | 2004-02-09 | 2004-02-13 | 544 |  | 414d |  |
| 556 |  | SEPT-E Flight Spare Electronics Test | 5d | 2004-02-09 | 2004-02-13 | 545 |  | 414d |  |
| 557 |  | Coat SEPT-NS FS Electronics Board | 5d | 2004-02-17 | 2004-02-23 | 555 |  | 414d |  |
| 558 |  | Coat SEPT-E FS Electronics Board | 5d | 2004-02-17 | 2004-02-23 | 556 |  | 414d |  |
| 559 |  | SEPT-NS FS Mechanical Integration | 10d | 2004-02-24 | 2004-03-08 | 557 |  | 414d |  |
| 560 |  | SEPT-E FS Mechanical Integration | 10d | 2004-02-24 | 2004-03-08 | 558 |  | 414d |  |

| ID | WBS | Task | Duration | Start | Finish | Predecessors | Complete | Total float | Constraint |
| --- | --- | --- | --- | --- | --- | --- | --- | --- | --- |
| 561 | 1.6.5.4 | **Integration & Test** | 133d | 2004-01-12 A | 2004-07-19 |  | 3% | 68d |  |
| 562 | 1.6.5.4.1 | **FM 1** | 133d | 2004-01-12 A | 2004-07-19 |  | 6% | 54d |  |
| 563 | 1.6.5.4.1.1 | **SEPT-NS** | 124d | 2004-01-26 | 2004-07-19 |  |  | 54d |  |
| 564 |  | SEPT-NS FM 1 Integration & Test | 5d | 2004-01-26 | 2004-01-30 | 531 |  | 70d | start no earlier than 2004-01-26 |
| 565 |  | Muon and Radioactive Source Test | 5d | 2004-02-02 | 2004-02-06 | 564 |  | 70d |  |
| 566 |  | SEPT-NS FM 1 Vibration and Acoustics | 10d | 2004-02-09 | 2004-02-23 | 565 |  | 70d |  |
| 567 |  | SEPT-NS FM 1 Thermal Vac | 10d | 2004-02-24 | 2004-03-08 | 566 |  | 70d |  |
| 568 |  | SEPT-NS FM 1 Bake Out | 3d | 2004-03-09 | 2004-03-11 | 567 |  | 70d |  |
| 569 |  | SEPT-NS FM 1 Thermal Balance | 10d | 2004-07-06 | 2004-07-19 | 18 |  | 54d |  |
| 570 | 1.6.5.4.1.2 | **SEPT-E** | 133d | 2004-01-12 A | 2004-07-19 |  | 12% | 54d |  |
| 571 |  | SEPT-E FM 1 Integration & Test | 5d | 2004-01-12 A | 2004-01-16 A | 532 | 100% |  |  |
| 572 |  | Muon and Radioactive Source Test | 5d | 2004-01-20 | 2004-01-26 | 571 |  | 79d |  |
| 573 |  | SEPT-E FM 1 Vibration and Acoustics | 10d | 2004-01-27 | 2004-02-09 | 572 |  | 79d |  |
| 574 |  | SEPT-E FM 1 Thermal Vac | 10d | 2004-02-10 | 2004-02-24 | 573 |  | 79d |  |
| 575 |  | SEPT-E FM 1 Bake Out | 3d | 2004-02-25 | 2004-02-27 | 574 |  | 79d |  |
| 576 |  | SEPT-E FM 1 Thermal Balance | 10d | 2004-07-06 | 2004-07-19 | 18 |  | 54d |  |
| 577 | 1.6.5.4.2 | **FM 2** | 128d | 2004-01-20 | 2004-07-19 |  |  | 68d |  |
| 578 | 1.6.5.4.2.1 | **SEPT-NS** | 128d | 2004-01-20 | 2004-07-19 |  |  | 68d |  |
| 579 |  | SEPT-NS FM 2 Integration & Test | 5d | 2004-01-20 | 2004-01-26 | 534 |  | 88d |  |
| 580 |  | Muon and Radioactive Source Test | 5d | 2004-01-27 | 2004-02-02 | 579 |  | 88d |  |
| 581 |  | SEPT-NS FM 2 Vibration and Acoustics | 10d | 2004-02-03 | 2004-02-17 | 580 |  | 88d |  |
| 582 |  | SEPT-NS FM 2 Thermal Vac | 10d | 2004-02-18 | 2004-03-02 | 581 |  | 88d |  |
| 583 |  | SEPT-NS FM 2 Bake Out | 3d | 2004-03-03 | 2004-03-05 | 582 |  | 88d |  |
| 584 |  | SEPT-NS FM 2 Thermal Balance | 10d | 2004-07-06 | 2004-07-19 | 18 |  | 68d |  |
| 585 | 1.6.5.4.2.2 | **SEPT-E** | 128d | 2004-01-20 | 2004-07-19 |  |  | 68d |  |
| 586 |  | SEPT-E FM 2 Integration & Test | 5d | 2004-01-20 | 2004-01-26 | 535 |  | 88d |  |
| 587 |  | Muon and Radioactive Source Test | 5d | 2004-01-27 | 2004-02-02 | 586 |  | 88d |  |
| 588 |  | SEPT-E FM 2 Vibration and Acoustics | 10d | 2004-02-03 | 2004-02-17 | 587 |  | 88d |  |
| 589 |  | SEPT-E FM 2 Thermal Vac | 10d | 2004-02-18 | 2004-03-02 | 588 |  | 88d |  |
| 590 |  | SEPT-E FM 2 Bake Out | 3d | 2004-03-03 | 2004-03-05 | 589 |  | 88d |  |
| 591 |  | SEPT-E FM 2 Thermal Balance | 10d | 2004-07-06 | 2004-07-19 | 18 |  | 68d |  |
| 592 | 1.6.6 | **SIT - UMD** | 351d | 2003-06-02 A | 2004-10-20 |  | 26% | 255d |  |
| 593 | 1.6.6.1 | **Deliveries** | 81d | 2004-06-11 | 2004-10-04 |  |  | 14d |  |
| 594 |  | Deliver SIT FM 1 to CIT for SEP I&T and Suite EMC | 2d | 2004-06-11 | 2004-06-14 | 414, 693 |  | 14d |  |
| 595 |  | Deliver SIT FM 1 back to GSFC for Environmental Testing (after EMC Test) | 2d | 2004-07-06 | 2004-07-07 | 18 |  | 29d |  |
| 596 |  | Final Delivery of SIT FM 1 to APL | 1d | 2004-08-25 | 2004-08-25 | 725 |  | 29d |  |
| 597 |  | Deliver SIT FM 2 to CIT for SEP I&T | 2d | 2004-07-23 | 2004-07-26 | 698, 414 |  | 16d |  |
| 598 |  | Deliver SIT FM 2 back to GSFC for Environmental Testing | 2d | 2004-08-12 | 2004-08-13 | 790 |  | 16d |  |
| 599 |  | Final Delivery of SIT FM 2 to APL | 1d | 2004-10-04 | 2004-10-04 | 734 |  | 16d |  |
| 600 | 1.6.6.2 | **Detectors** | 43d | 2004-01-05 | 2004-03-05 |  |  | 42d |  |
| 601 | 1.6.6.2.1 | **Detector Testing** | 43d | 2004-01-05 | 2004-03-05 |  |  | 42d |  |
| 602 | 1.6.6.2.1.1 | **FM 1** | 43d | 2004-01-05 | 2004-03-05 |  |  | 33d |  |
| 603 |  | Test FM 1 Solid States Detectors | 24d | 2004-01-05 | 2004-02-06 |  |  | 42d | start no earlier than 2004-01-05 |
| 604 |  | Test FM 1 Foils | 24d | 2004-01-05 | 2004-02-06 | 603SS |  | 42d |  |
| 605 |  | Alpha Tests FM 1 w/Proto Elect | 10d | 2004-02-23 | 2004-03-05 | 603, 604, 374 |  | 33d |  |
| 606 | 1.6.6.2.1.2 | **FM 2** | 43d | 2004-01-05 | 2004-03-05 |  |  | 68d |  |
| 607 |  | Test FM 2 Solid States Detectors | 24d | 2004-01-05 | 2004-02-06 | 603SS |  | 77d |  |
| 608 |  | Test FM 2 Foils | 24d | 2004-01-05 | 2004-02-06 | 604SS |  | 77d |  |
| 609 |  | Alpha Tests FM 2 w/Proto Elect | 10d | 2004-02-23 | 2004-03-05 | 607, 608, 374 |  | 68d |  |
| 610 | 1.6.6.3 | **ACTEL - for SIT Logic Board** | 11d | 2004-02-27 | 2004-03-12 |  |  | 60d |  |
| 611 |  | Burn Final SIT ACTEL Chip (at GSFC) | 1d | 2004-02-27 | 2004-02-27 |  |  | 60d | start no earlier than 2004-02-27 |
| 612 |  | Evaluate (Test) SIT Final ACTEL Chip | 10d | 2004-03-01 | 2004-03-12 | 611 |  | 60d |  |
| 613 | 1.6.6.4 | **TOF Boards** | 20d | 2004-02-17 | 2004-03-15 |  |  | 40d |  |
| 614 |  | Receive Analog and Digital TOF Boards (FM 1 & FM 2) | 0d | 2004-02-17 | 2004-02-17 |  |  | 40d | start no earlier than 2004-02-17 |
| 615 | 1.6.6.4.2 | **Test** | 20d | 2004-02-17 | 2004-03-15 |  |  | 40d |  |
| 616 | 1.6.6.4.2.1 | **FM 1** | 10d | 2004-02-17 | 2004-03-01 |  |  | 40d |  |
| 617 |  | FM 1 TOF Boards Functional Test | 10d | 2004-02-17 | 2004-03-01 | 614 |  | 40d |  |
| 618 | 1.6.6.4.2.2 | **FM 2** | 10d | 2004-03-02 | 2004-03-15 |  |  | 65d |  |
| 619 |  | FM 2 TOF Boards Functional Test | 10d | 2004-03-02 | 2004-03-15 | 614, 617 |  | 65d |  |
| 620 | 1.6.6.5 | **Energy Board** | 76d | 2003-11-10 A | 2004-03-02 |  | 57% | 74d |  |
| 621 | 1.6.6.5.1 | **Assembly** | 46d | 2003-11-10 A | 2004-01-16 |  | 76% | 89d |  |
| 622 | 1.6.6.5.1.1 | **FM 1** | 46d | 2003-11-10 A | 2004-01-16 |  | 76% | 54d |  |
| 623 |  | Assemble FM 1 Energy Board | 46d | 2003-11-10 A | 2004-01-16 |  | 76% | 54d | start no earlier than 2003-11-10 |
| 624 | 1.6.6.5.1.2 | **FM 2** | 46d | 2003-11-10 A | 2004-01-16 |  | 76% | 89d |  |
| 625 |  | Assemble FM 2 Energy Board | 46d | 2003-11-10 A | 2004-01-16 | 623SS | 76% | 89d |  |
| 626 | 1.6.6.5.2 | **Test** | 30d | 2004-01-20 | 2004-03-02 |  |  | 54d |  |
| 627 | 1.6.6.5.2.1 | **FM 1** | 15d | 2004-01-20 | 2004-02-09 |  |  | 54d |  |
| 628 |  | Bench Test/Calibration | 10d | 2004-01-20 | 2004-02-02 | 623 |  | 54d |  |
| 629 |  | Thermal | 3d | 2004-02-03 | 2004-02-05 | 628 |  | 54d |  |
| 630 |  | Voltage Margin | 2d | 2004-02-06 | 2004-02-09 | 629 |  | 54d |  |

| ID | WBS | Task | Duration | Start | Finish | Predecessors | Complete | Total float | Constraint |
| --- | --- | --- | --- | --- | --- | --- | --- | --- | --- |
| 631 | 1.6.6.5.2.2 | **FM 2** | 15d | 2004-02-10 | 2004-03-02 |  |  | 74d |  |
| 632 |  | FM 2 Energy Board Functional Test | 15d | 2004-02-10 | 2004-03-02 | 625, 630 |  | 74d |  |
| 633 | 1.6.6.6 | **Logic Board** | 168d | 2003-11-10 A | 2004-07-09 |  | 31% | 16d |  |
| 634 | 1.6.6.6.1 | **Design** | 3d | 2003-11-17 A | 2003-11-19 A |  | 100% |  |  |
| 635 |  | Layout new Logic Board Design | 3d | 2003-11-17 A | 2003-11-19 A |  | 100% |  | start no earlier than 2003-11-17 |
| 636 | 1.6.6.6.2 | **Fabrication** | 10d | 2004-02-02 | 2004-02-13 |  |  | 14d |  |
| 637 |  | FM 1 & FM 2 Logic Board Fabrication | 10d | 2004-02-02 | 2004-02-13 | 635, 651 |  | 14d | start no earlier than 2004-02-02 |
| 638 | 1.6.6.6.3 | **Assembly** | 91d | 2004-03-02 | 2004-07-07 |  |  | 14d |  |
| 639 | 1.6.6.6.3.1 | **FM 1** | 58d | 2004-03-02 | 2004-05-20 |  |  | 14d |  |
| 640 |  | Assemble FM 1 Logic Board with ETU ACTELs | 11d | 2004-03-02 | 2004-03-16 | 653 |  | 14d |  |
| 641 |  | Disassembel FM 1 Logic Board with ETU ACTELs | 1d | 2004-05-17 | 2004-05-17 | 707 |  | 14d |  |
| 642 |  | Retrofit/Inspect FM 1 Flight ACTELs | 2d | 2004-05-18 | 2004-05-19 | 641, 612 |  | 14d |  |
| 643 |  | Reassemble FM 1 Logic Board with Flight ACTELs | 1d | 2004-05-20 | 2004-05-20 | 642 |  | 14d |  |
| 644 | 1.6.6.6.3.2 | **FM 2** | 91d | 2004-03-02 | 2004-07-07 |  |  | 16d |  |
| 645 |  | Assemble FM 2 Logic Board with ETU ACTELS | 11d | 2004-03-02 | 2004-03-16 | 653 |  | 49d |  |
| 646 |  | Disassemble FM 2 Logic Boards | 1d | 2004-07-02 | 2004-07-02 | 716, 641SS |  | 16d |  |
| 647 |  | Retrofit/Inspect Flight ACTELS | 2d | 2004-07-05 | 2004-07-06 | 646, 612 |  | 16d |  |
| 648 |  | Reassemble FM 2 Logic Boards | 1d | 2004-07-07 | 2004-07-07 | 647 |  | 16d |  |
| 649 | 1.6.6.6.4 | **Test** | 168d | 2003-11-10 A | 2004-07-09 |  | 42% | 16d |  |
| 650 | 1.6.6.6.4.1 | **ETU** | 55d | 2003-11-10 A | 2004-01-30 |  | 75% | 14d |  |
| 651 |  | Test New ETU Logic Board | 55d | 2003-11-10 A | 2004-01-30 |  | 75% | 14d | start no earlier than 2003-11-10 |
| 652 | 1.6.6.6.4.2 | **FM1 & FM 2** | 10d | 2004-02-17 | 2004-03-01 |  |  | 14d |  |
| 653 |  | Coupon Testing | 10d | 2004-02-17 | 2004-03-01 | 637 |  | 14d |  |
| 654 | 1.6.6.6.4.3 | **FM 1** | 49d | 2004-03-17 | 2004-05-24 |  |  | 14d |  |
| 655 |  | Functional Test of FM 1 Logic Board w/ETU ACTELS | 15d | 2004-03-17 | 2004-04-06 | 640 |  | 14d |  |
| 656 |  | Funtional Test of FM 1 Logic Board w/Flight ACTELS | 2d | 2004-05-21 | 2004-05-24 | 643 |  | 14d |  |
| 657 | 1.6.6.6.4.4 | **FM 2** | 67d | 2004-04-07 | 2004-07-09 |  |  | 16d |  |
| 658 |  | Functional Test of FM 2 Logic Board w/ETU ACTELS | 15d | 2004-04-07 | 2004-04-27 | 645, 655 |  | 34d |  |
| 659 |  | Functional Test of FM 2 Logic Board w/Flight ACTELS | 2d | 2004-07-08 | 2004-07-09 | 648 |  | 16d |  |
| 660 | 1.6.6.7 | **Mother Board** | 50d | 2003-12-22 | 2004-03-04 |  |  | 42d |  |
| 661 | 1.6.6.7.1 | **Design** | 15d | 2003-12-22 | 2004-01-13 |  |  | 42d |  |
| 662 | 1.6.6.7.1.1 | **FM 1 & FM 2** | 15d | 2003-12-22 | 2004-01-13 |  |  | 42d |  |
| 663 |  | Finalize Mother Board Layout | 15d | 2003-12-22 | 2004-01-13 |  |  | 42d | start no earlier than 2003-12-22 |
| 664 | 1.6.6.7.2 | **Fabrication** | 15d | 2004-01-14 | 2004-02-04 |  |  | 42d |  |
| 665 | 1.6.6.7.2.1 | **FM 1 & FM 2** | 15d | 2004-01-14 | 2004-02-04 |  |  | 42d |  |
| 666 |  | Fabricate FM 1 & FM 2 Mother Boards | 15d | 2004-01-14 | 2004-02-04 | 663 |  | 42d |  |
| 667 | 1.6.6.7.3 | **Assembly** | 10d | 2004-02-05 | 2004-02-19 |  |  | 42d |  |
| 668 |  | Assemble FM 1 Mother Board | 10d | 2004-02-05 | 2004-02-19 | 666 |  | 42d |  |
| 669 |  | Assemble FM 2 Mother Board | 10d | 2004-02-05 | 2004-02-19 | 668SS |  | 64d |  |
| 670 | 1.6.6.7.4 | **Test** | 20d | 2004-02-05 | 2004-03-04 |  |  | 52d |  |
| 671 | 1.6.6.7.4.1 | **FM 1 & FM 2** | 15d | 2004-02-05 | 2004-02-26 |  |  | 421d |  |
| 672 |  | Coupon Testing of Mother Boards | 15d | 2004-02-05 | 2004-02-26 | 666 |  | 421d |  |
| 673 | 1.6.6.7.4.2 | **FM 1** | 5d | 2004-02-20 | 2004-02-26 |  |  | 42d |  |
| 674 |  | Functional Test FM 1 Mother Board | 5d | 2004-02-20 | 2004-02-26 | 668 |  | 42d |  |
| 675 | 1.6.6.7.4.3 | **FM 2** | 5d | 2004-02-27 | 2004-03-04 |  |  | 59d |  |
| 676 |  | Functional Test FM 2 Mother Board | 5d | 2004-02-27 | 2004-03-04 | 669, 674 |  | 59d |  |
| 677 | 1.6.6.8 | **HVPS** | 62d | 2004-01-12 | 2004-04-08 |  |  | 44d |  |
| 678 | 1.6.6.8.1 | **Test** | 62d | 2004-01-12 | 2004-04-08 |  |  | 44d |  |
| 679 | 1.6.6.8.1.1 | **FM 1** | 10d | 2004-01-12 | 2004-01-26 |  |  | 61d |  |
| 680 |  | Functional Test SIT FM 1 HVPS | 10d | 2004-01-12 | 2004-01-26 | 74 |  | 61d | start no earlier than 2004-01-12 |
| 681 | 1.6.6.8.1.2 | **FM 2** | 10d | 2004-03-26 | 2004-04-08 |  |  | 44d |  |
| 682 |  | Functional Test SIT FM 2 HVPS | 10d | 2004-03-26 | 2004-04-08 | 80, 676 |  | 44d |  |
| 683 | 1.6.6.9 | **Flight Software** | 210d | 2003-06-02 A | 2004-04-01 |  | 70% | 44d |  |
| 684 | 1.6.6.9.1 | **Test** | 210d | 2003-06-02 A | 2004-04-01 |  | 70% | 44d |  |
| 685 | 1.6.6.9.1.1 | **FM 1 & FM 2** | 210d | 2003-06-02 A | 2004-04-01 |  | 70% | 44d |  |
| 686 |  | Validate SIT On-Board Code | 210d | 2003-06-02 A | 2004-04-01 |  | 70% | 44d | start no earlier than 2003-06-02 |
| 687 | 1.6.6.10 | **Integration & Test (using ETU Telescope for FM 1)** | 98d | 2004-03-08 | 2004-07-22 |  |  | 16d |  |
| 688 | 1.6.6.10.1 | **FM 1 (Flight Telescope)** | 12d | 2004-05-25 | 2004-06-10 |  |  | 14d |  |
| 689 |  | Disassemble SIT FM 1 | 1d | 2004-05-25 | 2004-05-25 | 656 |  | 14d |  |
| 690 |  | Conformal Coat SIT FM 1 Boards | 2d | 2004-05-26 | 2004-05-27 | 689 |  | 14d |  |
| 691 |  | Reassemble SIT FM 1 with Flight Telescope | 1d | 2004-05-28 | 2004-05-28 | 690, 408 |  | 14d |  |
| 692 |  | Bench Calibration SIT FM 1 w/Flight Telescope | 3d | 2004-06-01 | 2004-06-03 | 691 |  | 14d |  |
| 693 |  | Vacuum Test SIT FM 1 w/Flight Telescope | 5d | 2004-06-04 | 2004-06-10 | 692 |  | 14d |  |
| 694 | 1.6.6.10.2 | **FM 2** | 9d | 2004-07-12 | 2004-07-22 |  |  | 16d |  |
| 695 |  | Disassemble SIT FM 2 | 1d | 2004-07-12 | 2004-07-12 | 659 |  | 16d |  |
| 696 |  | Conformal Coat SIT FM 2 Boards | 2d | 2004-07-13 | 2004-07-14 | 695 |  | 16d |  |
| 697 |  | Reassemble SIT FM 2 | 1d | 2004-07-15 | 2004-07-15 | 696 |  | 16d |  |
| 698 |  | Post-Coat Retest SIT FM 2 | 5d | 2004-07-16 | 2004-07-22 | 697 |  | 16d |  |
| 699 | 1.6.6.10.3 | **FM 1 (ETU Telescope)** | 50d | 2004-03-08 | 2004-05-14 |  |  | 14d |  |
| 700 |  | Integrate SIT FM 1 HVPS and SIT ETU Telescope Without Electronics | 3d | 2004-03-08 | 2004-03-10 | 680, 605 |  | 33d |  |

| ID | WBS | Task | Duration | Start | Finish | Predecessors | Complete | Total float | Constraint |
| --- | --- | --- | --- | --- | --- | --- | --- | --- | --- |
| 701 |  | Integrate Electronics to SIT ETU Telescope | 2d | 2004-04-07 | 2004-04-08 | 655, 617, 674, 630, 700 |  | 14d |  |
| 702 |  | SIT FM 1 Debug | 5d | 2004-04-09 | 2004-04-15 | 701 |  | 14d |  |
| 703 |  | SIT FM 1 Bench Test | 5d | 2004-04-16 | 2004-04-22 | 702 |  | 14d |  |
| 704 |  | SIT FM 1 Alpha TEST | 5d | 2004-04-23 | 2004-04-29 | 703 |  | 14d |  |
| 705 |  | SIT FM 1 Noise Removal | 5d | 2004-04-30 | 2004-05-06 | 704 |  | 14d |  |
| 706 |  | SIT FM 1 Thermal Test | 5d | 2004-05-07 | 2004-05-13 | 705 |  | 14d |  |
| 707 |  | SIT FM 1 Functional Test | 1d | 2004-05-14 | 2004-05-14 | 706, 686 |  | 14d |  |
| 708 | 1.6.6.10.4 | **FM 2** | 31d | 2004-05-19 | 2004-07-01 |  |  | 16d |  |
| 709 |  | Integrate SIT FM 2 HVPS and SIT FM 2 Telescope Without Electronics | 3d | 2004-05-19 | 2004-05-21 | 682, 609, 408 |  | 16d |  |
| 710 |  | Integrate Electronics to SIT FM 2 Telescope | 2d | 2004-05-24 | 2004-05-25 | 658, 619, 676, 632, 709 |  | 16d |  |
| 711 |  | SIT FM 2 Debug | 5d | 2004-05-26 | 2004-06-02 | 710 |  | 16d |  |
| 712 |  | SIT FM 2 Bench Test | 5d | 2004-06-03 | 2004-06-09 | 711 |  | 16d |  |
| 713 |  | SIT FM 2 Alpha Test | 5d | 2004-06-10 | 2004-06-16 | 712 |  | 16d |  |
| 714 |  | SIT FM 2 Noise Removal | 5d | 2004-06-17 | 2004-06-23 | 713, 705 |  | 16d |  |
| 715 |  | SIT FM 2 Thermal Test | 5d | 2004-06-24 | 2004-06-30 | 714 |  | 16d |  |
| 716 |  | SIT FM 2 Functional Test | 1d | 2004-07-01 | 2004-07-01 | 715 |  | 16d |  |
| 717 | 1.6.6.11 | **Environmental Testing at GSFC (FM 1)** | 34d | 2004-07-08 | 2004-08-24 |  |  | 29d |  |
| 718 |  | SIT FM 1 Vibration and Acoustics | 10d | 2004-07-08 | 2004-07-21 | 595 |  | 29d |  |
| 719 |  | Functional Test | 1d | 2004-07-22 | 2004-07-22 | 718 |  | 29d |  |
| 720 |  | SIT FM 1 Thermal Balance | 5d | 2004-07-23 | 2004-07-29 | 719 |  | 29d |  |
| 721 |  | SIT FM 1 Thermal Vac | 10d | 2004-07-30 | 2004-08-12 | 720 |  | 29d |  |
| 722 |  | Disassemble SIT Instruments | 2d | 2004-08-13 | 2004-08-16 | 721 |  | 29d |  |
| 723 |  | Bake Out | 3d | 2004-08-17 | 2004-08-19 | 722 |  | 29d |  |
| 724 |  | Reassemble Instruments | 2d | 2004-08-20 | 2004-08-23 | 723 |  | 29d |  |
| 725 |  | Functional Test | 1d | 2004-08-24 | 2004-08-24 | 724 |  | 29d |  |
| 726 | 1.6.6.12 | **Environmental Testing at GSFC (FM 2)** | 34d | 2004-08-16 | 2004-10-01 |  |  | 16d |  |
| 727 |  | SIT FM 2 Vibration and Acoustics | 10d | 2004-08-16 | 2004-08-27 | 598 |  | 16d |  |
| 728 |  | Functional Test | 1d | 2004-08-30 | 2004-08-30 | 727 |  | 16d |  |
| 729 |  | SIT FM 2 Thermal Balance | 5d | 2004-08-31 | 2004-09-07 | 728 |  | 16d |  |
| 730 |  | SIT FM 2 Thermal Vac | 10d | 2004-09-08 | 2004-09-21 | 729 |  | 16d |  |
| 731 |  | Disassemble SIT Instruments | 2d | 2004-09-22 | 2004-09-23 | 730 |  | 16d |  |
| 732 |  | Bake Out | 3d | 2004-09-24 | 2004-09-28 | 731 |  | 16d |  |
| 733 |  | Reassemble Instruments | 2d | 2004-09-29 | 2004-09-30 | 732 |  | 16d |  |
| 734 |  | Functional Test | 1d | 2004-10-01 | 2004-10-01 | 733 |  | 16d |  |
| 735 | 1.6.6.13 | **Emulators/Simulators/GSE** | 214d | 2003-12-17 A | 2004-10-20 |  | 9% | 255d |  |
| 736 | 1.6.6.13.1 | **Simulators** | 80d | 2003-12-17 A | 2004-04-12 |  | 13% | 389d |  |
| 737 |  | Labview CPU Ready | 80d | 2003-12-17 A | 2004-04-12 |  | 13% | 389d | start no earlier than 2003-12-17 |
| 738 |  | Test Simulator | 80d | 2003-12-17 A | 2004-04-12 | 737SS | 13% | 389d |  |
| 739 | 1.6.6.13.2 | **GSE** | 60d | 2004-07-27 | 2004-10-20 |  |  | 255d |  |
| 740 |  | Pulse Generator | 60d | 2004-07-27 | 2004-10-20 | 594, 597 |  | 255d |  |
| 741 | 1.6.7 | **SEP Suite I&T - CIT** | 305d | 2003-08-01 A | 2004-10-15 |  | 31% | 258d |  |
| 742 | 1.6.7.1 | **ETU** | 5d | 2004-02-23 | 2004-02-27 |  |  | 420d |  |
| 743 |  | Complete Integration/Test of SEP Central EM with Sensors | 5d | 2004-02-23 | 2004-02-27 |  |  | 420d | start no earlier than 2004-02-23 |
| 744 | 1.6.7.2 | **FM 1 & FM 2** | 154d | 2004-03-08 | 2004-10-12 |  |  | 74d |  |
| 745 |  | Software Support For SEP Integration | 115d | 2004-04-30 | 2004-10-12 | 756SS |  | 261d |  |
| 746 |  | Generate SEPT integration & test procedure | 5d | 2004-03-08 | 2004-03-12 | 757FS-10d |  | 75d |  |
| 747 |  | Generate LET integration & test procedure | 5d | 2004-04-26 | 2004-04-30 | 758FS-10d |  | 41d |  |
| 748 |  | Generate HET integration & test procedure | 5d | 2004-05-19 | 2004-05-25 | 760FS-10d |  | 25d |  |
| 749 |  | Generate SIT integration & test procedure | 5d | 2004-06-02 | 2004-06-08 | 764FS-10d |  | 19d |  |
| 750 |  | Generate SEP system test procedure | 5d | 2004-06-03 | 2004-06-09 | 765FS-10d |  | 19d |  |
| 751 |  | Software Support For Acceptance Testing of SEP Instruments | 27d | 2004-06-17 | 2004-07-23 | 766SS |  | 316d |  |
| 752 |  | Generate SEP-IDPU integration procedure | 5d | 2004-05-20 | 2004-05-26 | 761FS-10d |  | 21d |  |
| 753 |  | Generate SEP-IDPU test procedure | 5d | 2004-05-27 | 2004-06-03 | 752 |  | 21d |  |
| 754 |  | Software Support of SEP Accelerator Tests | 20d | 2004-06-22 | 2004-07-19 | 797SS-10d |  | 320d |  |
| 755 | 1.6.7.3 | **FM 1** | 66d | 2004-03-19 | 2004-06-21 |  |  | 14d |  |
| 756 |  | Integrate/test SEP Central FM 1 | 5d | 2004-04-30 | 2004-05-06 | 423, 425, 384 |  | 36d |  |
| 757 |  | Receive & inspect SEPT FM 1 | 1d | 2004-03-19 | 2004-03-19 | 523, 524 |  | 70d |  |
| 758 |  | Integrate & test SEPT FM 1 | 1d | 2004-05-07 | 2004-05-07 | 746, 756, 757 |  | 36d |  |
| 759 |  | Integrate & test LET FM 1 | 1d | 2004-05-28 | 2004-05-28 | 747, 758, 500, 502 |  | 22d |  |
| 760 |  | Receive & inspect HET FM 1 | 1d | 2004-06-02 | 2004-06-02 | 453, 455 |  | 20d |  |
| 761 |  | Integrate & test HET FM 1 | 1d | 2004-06-03 | 2004-06-03 | 748, 759, 760 |  | 20d |  |
| 762 |  | Integrate SEP FM 1 - IDPU FM 1 | 1d | 2004-06-04 | 2004-06-04 | 752, 761 |  | 20d |  |
| 763 |  | Test SEP FM 1 - IDPU FM 1 | 1d | 2004-06-07 | 2004-06-07 | 753, 762, 358 |  | 20d |  |
| 764 |  | Receive & inspect SIT FM 1 | 1d | 2004-06-15 | 2004-06-15 | 594 |  | 14d |  |
| 765 |  | Integrate & test SIT FM 1 | 1d | 2004-06-16 | 2004-06-16 | 749, 761, 764, 763 |  | 14d |  |
| 766 |  | SEP system test FM 1 | 3d | 2004-06-17 | 2004-06-21 | 750, 765, 420 |  | 14d |  |
| 767 | 1.6.7.4 | **FM 2** | 102d | 2004-03-15 | 2004-08-04 |  |  | 14d |  |
| 768 |  | Integrate/testSEP Central FM 2 | 5d | 2004-04-30 | 2004-05-06 | 424, 425, 384 |  | 50d |  |
| 769 |  | Receive & inspect SEPT FM 2 | 1d | 2004-03-15 | 2004-03-15 | 526, 527 |  | 88d |  |
| 770 |  | Integrate & test SEPT FM 2 | 1d | 2004-05-07 | 2004-05-07 | 746, 768, 769 |  | 50d |  |

| ID | WBS | Task | Duration | Start | Finish | Predecessors | Complete | Total float | Constraint |
| --- | --- | --- | --- | --- | --- | --- | --- | --- | --- |
| 771 |  | Integrate & test LET FM 2 | 1d | 2004-05-28 | 2004-05-28 | 747, 770, 501, 502 |  | 36d |  |
| 772 |  | Receive & inspect HET FM 2 | 1d | 2004-06-23 | 2004-06-23 | 454 |  | 19d |  |
| 773 |  | Integrate & test HET FM 2 | 1d | 2004-06-24 | 2004-06-24 | 748, 771, 772 |  | 19d |  |
| 774 |  | Integrate SEP FM 2 - IDPU FM 2 | 1d | 2004-06-25 | 2004-06-25 | 752, 773, 165 |  | 19d |  |
| 775 |  | Test SEP FM 2 - IDPU FM 2 | 1d | 2004-06-28 | 2004-06-28 | 753, 774 |  | 19d |  |
| 776 |  | Receive & inspect SIT FM 2 | 1d | 2004-07-27 | 2004-07-27 | 597 |  | 16d |  |
| 777 |  | Integrate & test SIT FM 2 | 1d | 2004-07-30 | 2004-07-30 | 749, 776, 791 |  | 14d |  |
| 778 |  | SEP FM 2 system test | 3d | 2004-08-02 | 2004-08-04 | 750, 777 |  | 14d |  |
| 779 | 1.6.7.5 | **Environmental Test (at JPL)** | 88d | 2004-05-17 | 2004-09-17 |  |  | 28d |  |
| 780 |  | Generate Environmental Test Procedures | 15d | 2004-05-17 | 2004-06-07 |  |  | 46d | start no earlier than 2004-05-17 |
| 781 |  | Manufacture test cables (JPL) | 20d | 2004-06-01 | 2004-06-28 |  |  | 31d | start no earlier than 2004-06-01 |
| 782 | 1.6.7.5.3 | **FM 1** | 45d | 2004-07-16 | 2004-09-17 |  |  | 14d |  |
| 783 |  | FM 1 LET/HET/SEP Central Vibration/Acoustics Test | 10d | 2004-07-16 | 2004-07-29 | 18FS+3d, 780, 781, 797FS+3d |  | 18d |  |
| 784 |  | FM 1 LET/HET/SEP Central Thermal Balance Test | 5d | 2004-07-30 | 2004-08-05 | 783 |  | 18d |  |
| 785 |  | FM 1 LET/HET/SEP Central T/V Test | 15d | 2004-08-12 | 2004-09-01 | 784, 790 |  | 14d |  |
| 786 |  | Evaluate SEP performance | 10d | 2004-09-02 | 2004-09-16 | 785 |  | 14d |  |
| 787 |  | Generate test reports | 11d | 2004-09-02 | 2004-09-17 | 786SS |  | 14d | finish no later than 2004-10-07 |
| 788 |  | Bakeout Clean SEP exterior & prepare for delivery | 3d | 2004-09-02 | 2004-09-07 | 785 |  | 21d |  |
| 789 | 1.6.7.5.4 | **FM 2** | 45d | 2004-07-16 | 2004-09-17 |  |  | 14d |  |
| 790 |  | FM 2 EMI/EMC Test at CalTech | 5d | 2004-08-05 | 2004-08-11 | 778 |  | 14d |  |
| 791 |  | FM 2 LET/HET/SEP Central Vibration/Acoustics Test | 10d | 2004-07-16 | 2004-07-29 | 798FS+3d |  | 14d |  |
| 792 |  | FM 2 LET/HET/SEP Central T/V Test | 15d | 2004-08-12 | 2004-09-01 | 790 |  | 28d |  |
| 793 |  | Evaluate SEP performance | 10d | 2004-09-02 | 2004-09-16 | 792 |  | 28d |  |
| 794 |  | Generate test reports | 11d | 2004-09-02 | 2004-09-17 | 793SS |  | 28d | finish no later than 2004-10-28 |
| 795 |  | Bakeout Clean SEP exterior & prepare for delivery | 3d | 2004-09-02 | 2004-09-07 | 792 |  | 35d |  |
| 796 | 1.6.7.6 | **Accelerator Test (at MSU)** | 5d | 2004-07-06 | 2004-07-12 |  |  | 14d |  |
| 797 |  | FM 1 LET/SEP Cen end-to-end test at Accelerator | 5d | 2004-07-06 | 2004-07-12 | 803, 18, 415 |  | 14d |  |
| 798 |  | FM 2 LET/SEP Cen end-to-end test at Accelerator | 5d | 2004-07-06 | 2004-07-12 | 797SS, 775 |  | 14d |  |
| 799 | 1.6.7.7 | **GSE** | 305d | 2003-08-01 A | 2004-10-15 |  | 55% | 258d |  |
| 800 | 1.6.7.7.1 | **End-to-End Test Equipment** | 218d | 2003-08-11 A | 2004-06-22 |  | 84% | 23d |  |
| 801 |  | Design | 192d | 2003-08-11 A | 2004-05-14 |  | 95% | 23d | start no earlier than 2003-08-11 |
| 802 |  | Assemble | 21d | 2004-05-17 | 2004-06-15 | 801 |  | 23d |  |
| 803 |  | Test | 5d | 2004-06-16 | 2004-06-22 | 802 |  | 23d |  |
| 804 | 1.6.7.7.2 | **GSE software** | 305d | 2003-08-01 A | 2004-10-15 |  | 34% | 258d |  |
| 805 |  | Build GSE software release 2 | 157d | 2003-08-01 A | 2004-03-18 |  | 66% | 281d | start no earlier than 2003-08-01 |
| 806 |  | Write user's guide | 8d | 2004-03-22 | 2004-03-31 | 805 |  | 280d | start no earlier than 2004-03-22 |
| 807 |  | Build GSE software release 3 | 117d | 2004-05-03 | 2004-10-15 | 806 |  | 258d | start no earlier than 2004-05-03 |
| 808 |  | Write user's guide supplement | 22d | 2004-09-15 | 2004-10-15 | 807FS-22d |  | 258d |  |
| 809 | 1.7 | **SWEA and SIT Refurbishment (after S/C Environmental Testing)** | 14d | 2005-09-27 | 2005-10-14 |  |  | 0d |  |
| 810 |  | Ship SWEA FM 1 to UCB | 3d | 2005-09-27 | 2005-09-29 |  |  | 0d | start no earlier than 2005-09-27 |
| 811 |  | Ship (Hand Carry) SIT FM 1 to UMD | 1d | 2005-09-27 | 2005-09-27 |  |  | 2d | start no earlier than 2005-09-27 |
| 812 |  | Ship SWEA FM 2 to UCB | 3d | 2005-10-04 | 2005-10-06 |  |  | 1d | start no earlier than 2005-10-04 |
| 813 |  | Ship (Hand Carry) SIT FM 2 to UMD | 1d | 2005-10-04 | 2005-10-04 |  |  | 3d | start no earlier than 2005-10-04 |
| 814 |  | Vacuum Testing of SWEA FM 1 @ UCB | 5d | 2005-09-30 | 2005-10-06 | 810 |  | 0d |  |
| 815 |  | Vacuum Testing of SIT FM 1 @ UMD | 5d | 2005-09-28 | 2005-10-04 | 811 |  | 2d |  |
| 816 |  | Vacuum Testing of SWEA FM 2 @ UCB | 5d | 2005-10-07 | 2005-10-13 | 812 |  | 1d |  |
| 817 |  | Vacuum Testing of SIT FM 2 @ UMD | 5d | 2005-10-05 | 2005-10-11 | 813 |  | 3d |  |
| 818 |  | Ship SWEA FM 1 & 2 to Launch Site for Re-integration to S/C | 3d | 2005-10-07 | 2005-10-11 | 814 |  | 0d |  |
| 819 |  | Ship SIT FM 1 & 2 to Launch Site for Re-integration to S/C | 3d | 2005-10-05 | 2005-10-07 | 815 |  | 2d |  |
| 820 |  | Reintegration of SWEA and SIT to S/C (at Launch Site) | 3d | 2005-10-12 | 2005-10-14 | 818, 819 |  | 0d | finish no later than 2005-11-18 |

## Version 2 (data date 2004-02-29, saved 2004-04-14, file IMPACT Master Schedule_April 12 2004v2.mpp)

Last finish 2005-10-14 → 2005-11-21 (+38d). Complete tasks 64 → 147.

Added:

| ID | Task | Duration | Start | Finish | Predecessors | Constraint |
| --- | --- | --- | --- | --- | --- | --- |
| 15 | TRR 4 - Prior to FM 1 IDPU Vibration | 1d | 2004-05-18 | 2004-05-18 | 23SS-5d |  |
| 18 | TRR 7 - Prior to FM 1 SIT Vibration | 1d | 2004-08-16 | 2004-08-16 | 43SS-5d |  |
| 25 | IDPU Thermal Vac & Bake Out | 10d | 2004-06-02 | 2004-06-15 | 174SS |  |
| 29 | STE-U Thermal Vac/Bake Out | 10d | 2004-05-27 | 2004-06-10 | 278SS |  |
| 41 | SEPT (NS & E) Thermal Balance (at GSFC) | 10d | 2004-08-18 | 2004-08-31 | 565SS, 572SS |  |
| 406 | **SIT Door (Priority 10)** | 27d | 2004-05-18 | 2004-06-24 |  |  |
| 407 | Complete Design/Drawings for SIT Door | 10d | 2004-05-18 | 2004-06-01 | 400 |  |
| 408 | Fabrication | 10d | 2004-06-02 | 2004-06-15 | 407 |  |
| 409 | Inspection | 5d | 2004-06-16 | 2004-06-22 | 408 |  |
| 410 | Final Assembly | 1d | 2004-06-23 | 2004-06-23 | 409 |  |
| 411 | Deliver SIT Door (stay at GSFC for Environmental Testing) | 1d | 2004-06-24 | 2004-06-24 | 410 |  |
| 457 | **Replacement HET Detectors (Batch 2)** | 66d | 2004-03-12 A | 2004-06-14 |  |  |
| 458 | Receive H1 Detector Mounts | 0d | 2004-03-12 A | 2004-03-12 A |  | start no earlier than 2004-03-12 |
| 459 | Receive H3 Detector Mounts | 0d | 2004-03-26 A | 2004-03-26 A |  | start no earlier than 2004-03-26 |
| 460 | Detector Mounting at Micron | 20d | 2004-04-15 | 2004-05-12 | 458, 459 | start no earlier than 2004-04-15 |
| 461 | Detector Delivery to GSFC | 2d | 2004-05-13 | 2004-05-14 | 460 |  |
| 462 | Detector Testing at GSFC | 20d | 2004-05-17 | 2004-06-14 | 461 |  |
| 493 | Install new HET Flight Detectors in FM 1 | 1d | 2004-07-05 | 2004-07-05 | 462, 492 |  |
| 494 | Performance Test FM 1 with New Flight Detectors | 1d | 2004-07-06 | 2004-07-06 | 493 |  |
| 497 | Install new HET Flight Detectors in FM 2 | 1d | 2004-07-06 | 2004-07-06 | 496, 462, 493 |  |
| 569 | SEPT-E FM 1 Vibration | 4d | 2004-02-19 A | 2004-02-24 A | 568, 562SS |  |
| 599 | Receive Analog and Digital TOF Boards (FM 2) | 20d | 2004-03-25 | 2004-04-21 | 602 |  |
| 649 | Redesign Mother Board Layout | 17d | 2004-03-05 A | 2004-03-29 A | 648, 659 |  |
| 653 | Refabricate FM1 & FM2 Mother Boards | 15d | 2004-03-30 | 2004-04-19 | 659, 649 |  |
| 660 | Coupon Testing of 2nd Mother Boards | 5d | 2004-04-20 | 2004-04-26 | 653 |  |
| 705 | Integrate SIT Door FM 1 | 1d | 2004-08-20 | 2004-08-20 | 589, 411 |  |
| 706 | Integrate SIT Door FM 2 | 1d | 2004-09-02 | 2004-09-02 | 592, 705 |  |
| 808 | Target Date for Reintegration to S/C | 1d | 2005-11-19 | 2005-11-21 | 807 | must start on 2005-11-19 |

Removed: 13 TRR 2 - Prior to FM 1 IDPU Vibration; 21 IDPU Thermal Vac; 27 IDPU Bake Out; 28 Boom Suite Bake Out; 37 IDPU Bake Out; 38 Boom Suite Bake Out; 44 SEPT Thermal Balance (at GSFC); 59 SEPT Thermal Balance (at GSFC); 139 Coat & Stake SIT FM 1 HVPS Boards (at UMD); 140 Retest SIT FM 1 HVPS Boards (at UMD); 166 Deliver IDPU S/W Build 3 (to UNH); 181 IDPU FM 1 Bakeout; 186 IDPU FM 2 Bakeout; 359 BOOM Suite FM 1 Bakeout; 366 BOOM Suite FM 2 Bakeout; 474 Bakeout HET FM 1 Electronics Board; 475 Retest Bakedout HET FM 1 Electronics Board; 480 Bakeout HET FM 2 Electronics Board; 481 Retest Bakedout HET FM 2 Electronics Board; 528 Final Delivery of SEPT FM 2 to APL; 545 Assemble SEPT-E FS Electronics; 556 SEPT-E Flight Spare Electronics Test; 558 Coat SEPT-E FS Electronics Board; 560 SEPT-E FS Mechanical Integration; 573 SEPT-E FM 1 Vibration and Acoustics; 584 SEPT-NS FM 2 Thermal Balance; 591 SEPT-E FM 2 Thermal Balance; 600 Detectors; 601 Detector Testing; 602 FM 1; 603 Test FM 1 Solid States Detectors; 604 Test FM 1 Foils; 605 Alpha Tests FM 1 w/Proto Elect; 606 FM 2; 607 Test FM 2 Solid States Detectors; 608 Test FM 2 Foils; 609 Alpha Tests FM 2 w/Proto Elect; 745 Software Support For SEP Integration; 751 Software Support For Acceptance Testing of SEP Instruments; 754 Software Support of SEP Accelerator Tests

Changed:

| ID | Task | Start | Finish | Duration | Complete | Total float | Predecessors | Other |
| --- | --- | --- | --- | --- | --- | --- | --- | --- |
| 1 | **IMPACT - Dave Curtis (UCB) & Lil Reichenthal (GSFC)** |  | 2005-10-14 → 2005-11-21 (+38d) | 673d → 699d | 38% → 60% |  |  | baseline start none → 2003-02-26; baseline finish none → 2005-11-18 |
| 2 | **Suite Deliveries to APL** | 2004-08-13 → 2004-09-21 (+39d) |  | 51d → 25d |  |  |  | baseline start none → 2004-08-13; baseline finish none → 2004-10-28 |
| 3 | FM 1 Target Delivery Date |  |  |  |  | 0d → -6d |  | baseline start none → 2004-10-07; baseline finish none → 2004-10-07 |
| 4 | FM 1 Target Delivery Date |  |  |  |  |  |  | baseline start none → 2004-10-28; baseline finish none → 2004-10-28 |
| 5 | Boom Suite FM 1 Ready for Delivery to APL | 2004-08-13 → 2004-09-21 (+39d) | 2004-08-13 → 2004-09-21 (+39d) |  |  | 37d → 11d |  | baseline start none → 2004-08-13; baseline finish none → 2004-08-13 |
| 6 | Boom Suite FM 2 Ready for Delivery to APL | 2004-09-09 → 2004-10-06 (+27d) | 2004-09-09 → 2004-10-06 (+27d) |  |  | 33d → 14d |  | baseline start none → 2004-09-28; baseline finish none → 2004-09-28 |
| 7 | SEP Suite FM 1 Ready for Delivery to APL | 2004-09-07 → 2004-10-15 (+38d) | 2004-09-07 → 2004-10-15 (+38d) |  |  | 21d → -6d |  | baseline start none → 2004-09-14; baseline finish none → 2004-09-14 |
| 8 | SEP Suite FM 2 Ready for Delivery to APL | 2004-10-04 → 2004-10-22 (+18d) | 2004-10-04 → 2004-10-22 (+18d) |  |  | 16d → 3d | 782, 593, Final Delivery of SEPT FM 2 to APL → 782, 593 | baseline start none → 2004-10-12; baseline finish none → 2004-10-12 |
| 9 | **Environmental Testing - PER, Impact Suite EMC, Snapshots of Boom & SEP Suite Test Flows** |  | 2004-09-28 → 2004-10-18 (+20d) | 181d → 194d | 0% → 3% | 270d → 283d |  | baseline start none → 2004-01-14; baseline finish none → 2004-10-05 |
| 10 | **Reviews (PER and TRR's) - TRR Dates are Tentative** |  | 2004-06-15 → 2004-08-16 (+62d) | 107d → 151d | 14% → 25% | 344d → 326d |  | baseline start none → 2004-01-14; baseline finish none → 2004-07-08 |
| 11 | Instrument PER at UCB |  |  |  |  |  |  | baseline start none → 2004-01-14; baseline finish none → 2004-01-14 |
| 12 | TRR 1 - Prior to FM 1 SEPT Thermal Vac | 2004-02-13 A | 2004-02-13 A |  | 0% → 100% | 179d → none |  | baseline start none → 2004-02-13; baseline finish none → 2004-02-13 |
| 13 | TRR 2 - Prior to FM 1 STE-U Thermal Vac/Thermal Balance | 2004-03-10 → 2004-04-19 (+40d) | 2004-03-10 → 2004-04-19 (+40d) |  |  | 162d → 410d | 21SS-5d → 21SS | was named TRR 3 - Prior to FM 1 STE-U Thermal Vac/Thermal Balance; constraint none → start no earlier than 2004-04-19; baseline start none → 2004-03-25; baseline finish none → 2004-03-25 |
| 14 | TRR 3 - Prior to FM 1 Boom Structure Vibration | 2004-04-08 → 2004-04-19 (+11d) | 2004-04-08 → 2004-04-19 (+11d) |  |  | 141d → 410d | 22SS-5d → 22SS-9d | was named TRR 4 - Prior to FM 1 Boom Structure Vibration; baseline start none → 2004-04-20; baseline finish none → 2004-04-20 |
| 16 | TRR 5 - Prior to FM 1 SWEA Vibration | 2004-05-04 → 2004-06-08 (+35d) | 2004-05-04 → 2004-06-08 (+35d) |  |  | 123d → 375d |  | baseline start none → 2004-05-28; baseline finish none → 2004-05-28 |
| 17 | TRR 6 - Prior to FM 1 Impact Suite EMC (for Boom and SEP) | 2004-06-15 → 2004-07-28 (+43d) | 2004-06-15 → 2004-07-28 (+43d) |  |  | 344d → 339d |  | baseline start none → 2004-06-22; baseline finish none → 2004-06-22 |
| 19 | IMPACT Suite FM 1 EMC Testing at UCB | 2004-06-22 → 2004-08-04 (+43d) | 2004-07-05 → 2004-08-17 (+43d) |  |  | 14d → -13d |  | baseline start none → 2004-06-29; baseline finish none → 2004-07-12 |
| 20 | **Boom Suite FM 1 Environmental Test Flow Snapshot - UCB** | 2004-03-17 → 2004-04-05 (+19d) | 2004-07-30 → 2004-09-07 (+39d) | 97d → 110d |  |  |  | baseline start none → 2004-04-01; baseline finish none → 2004-07-30 |
| 21 | STE-U Thermal Vac/Thermal Balance/Bake Out | 2004-03-17 → 2004-04-05 (+19d) | 2004-04-05 → 2004-04-22 (+17d) |  |  | 144d → 407d |  | was named STE-U Thermal Vac and Thermal Balance; baseline start none → 2004-04-01; baseline finish none → 2004-04-20 |
| 22 | Boom Structure Vibration | 2004-04-15 → 2004-04-30 (+15d) | 2004-04-20 → 2004-05-05 (+15d) |  |  | 133d → 398d |  | baseline start none → 2004-04-27; baseline finish none → 2004-04-30 |
| 23 | IDPU Vibration | 2004-04-21 → 2004-05-25 (+34d) | 2004-04-27 → 2004-06-01 (+35d) |  |  | 128d → 380d |  | baseline start none → 2004-05-03; baseline finish none → 2004-05-07 |
| 24 | Boom Structure Thermal Vac & Bake Out | 2004-04-21 → 2004-05-06 (+15d) | 2004-05-11 → 2004-05-26 (+15d) |  |  | 118d → 383d |  | was named Boom Structure Thermal Vac; baseline start none → 2004-05-03; baseline finish none → 2004-05-21 |
| 26 | SWEA/STE Vibration | 2004-05-11 → 2004-06-15 (+35d) | 2004-05-17 → 2004-06-21 (+35d) |  |  | 114d → 366d |  | baseline start none → 2004-06-07; baseline finish none → 2004-06-11 |
| 27 | SWEA/STE Thermal Vac/Thermal Balance/Bake Out | 2004-07-06 → 2004-08-18 (+43d) | 2004-07-23 → 2004-09-07 (+46d) |  |  | 316d → 311d |  | was named SWEA/STE Thermal Vac and Thermal Balance; baseline start none → 2004-07-13; baseline finish none → 2004-07-30 |
| 28 | **Boom Suite FM 2 Environmental Test Flow Snapshot - UCB** | 2004-04-16 → 2004-05-27 (+41d) | 2004-08-25 → 2004-09-22 (+28d) | 93d → 83d |  | 293d → 300d |  | baseline start none → 2004-04-27; baseline finish none → 2004-09-14 |
| 30 | IDPU Vibration | 2004-05-10 → 2004-07-07 (+58d) | 2004-05-14 → 2004-07-13 (+60d) |  |  | 115d → 350d |  | baseline start none → 2004-05-10; baseline finish none → 2004-05-14 |
| 31 | Boom Structure Vibration | 2004-04-16 → 2004-06-17 (+62d) | 2004-04-21 → 2004-06-22 (+62d) |  |  | 132d → 365d |  | baseline start none → 2004-05-17; baseline finish none → 2004-05-20 |
| 32 | IDPU Thermal Vac & Bake Out | 2004-05-17 → 2004-07-14 (+58d) | 2004-05-28 → 2004-07-27 (+60d) |  |  | 105d → 340d |  | was named IDPU Thermal Vac; baseline start none → 2004-05-17; baseline finish none → 2004-05-28 |
| 33 | Boom Structure Thermal Vac & Bake Out | 2004-05-12 → 2004-06-23 (+42d) | 2004-06-02 → 2004-07-13 (+41d) |  |  | 103d → 350d |  | was named Boom Structure Thermal Vac; baseline start none → 2004-05-24; baseline finish none → 2004-06-14 |
| 34 | SWEA/STE Vibration | 2004-07-14 → 2004-08-17 (+34d) | 2004-07-20 → 2004-08-23 (+34d) |  |  | 69d → 321d |  | baseline start none → 2004-08-09; baseline finish none → 2004-08-13 |
| 35 | SWEA/STE Thermal Vac & Bake Out | 2004-07-21 → 2004-08-24 (+34d) | 2004-08-03 → 2004-09-07 (+35d) |  |  | 59d → 311d |  | was named SWEA/STE Thermal Vac; baseline start none → 2004-08-16; baseline finish none → 2004-08-27 |
| 36 | Boom Suite FM 2 EMC | 2004-08-12 → 2004-09-16 (+35d) | 2004-08-18 → 2004-09-22 (+35d) |  |  | 48d → 300d |  | baseline start none → 2004-09-08; baseline finish none → 2004-09-14 |
| 37 | **SEP Suite FM 1 Environmental Test Flow Snapshot** | 2004-02-09 → 2004-02-19 A (+10d) | 2004-09-07 → 2004-10-15 (+38d) | 149d → 169d | 0% → 4% | 285d → 284d |  | baseline start none → 2004-02-17; baseline finish none → 2004-09-14 |
| 38 | SEPT (NS & E) Vibration (in Europe) | 2004-02-09 → 2004-02-19 A (+10d) | 2004-02-23 → 2004-02-24 A (+1d) | 10d → 4d | 0% → 100% | 424d → none | 562SS, SEPT-E FM 1 Vibration and AcousticsSS → 562SS | was named SEPT Vibe and Acoustics (in Europe); baseline start none → 2004-02-17; baseline finish none → 2004-02-24 |
| 39 | SEPT (NS & E) Thermal Vac (in Europe) | 2004-02-24 → 2004-02-27 (+3d) | 2004-03-08 → 2004-03-11 (+3d) |  |  | 414d → 437d |  | was named SEPT Thermal Vac (in Europe); baseline start none → 2004-02-25; baseline finish none → 2004-03-08 |
| 40 | SEPT (NS & E) Bake Out (in Europe) | 2004-03-09 → 2004-03-05 (-4d) | 2004-03-11 → 2004-03-08 (-3d) | 3d → 2d |  | 411d → 440d |  | was named SEPT Bake Out (in Europe); baseline start none → 2004-03-09; baseline finish none → 2004-03-10 |
| 42 | LET/HET/SEP Cen Accelerator Test (at MSU) | 2004-07-06 → 2004-08-18 (+43d) | 2004-07-20 → 2004-09-01 (+43d) |  |  | 319d → 314d |  | baseline start none → 2004-07-13; baseline finish none → 2004-07-27 |
| 43 | SIT Vibe and Acoustics (at GSFC) | 2004-07-08 → 2004-08-23 (+46d) | 2004-07-21 → 2004-09-03 (+44d) |  |  | 318d → 312d |  | baseline start none → 2004-07-15; baseline finish none → 2004-07-28 |
| 44 | LET/HET/SEP Cen Vibe and Acoustics (at JPL) | 2004-07-16 → 2004-08-30 (+45d) | 2004-07-29 → 2004-09-13 (+46d) |  |  | 312d → 307d |  | baseline start none → 2004-07-23; baseline finish none → 2004-08-05 |
| 45 | SIT Thermal Balance (at GSFC) | 2004-07-23 → 2004-09-08 (+47d) | 2004-07-29 → 2004-09-14 (+47d) |  |  | 312d → 306d |  | baseline start none → 2004-07-30; baseline finish none → 2004-08-05 |
| 46 | LET/HET/SEP Cen Thermal Balance (at JPL) | 2004-07-30 → 2004-09-14 (+46d) | 2004-08-05 → 2004-09-20 (+46d) |  |  | 307d → 302d |  | baseline start none → 2004-08-06; baseline finish none → 2004-08-12 |
| 47 | SIT Thermal Vac (at GSFC) | 2004-07-30 → 2004-09-15 (+47d) | 2004-08-12 → 2004-09-28 (+47d) |  |  | 302d → 296d |  | baseline start none → 2004-08-06; baseline finish none → 2004-08-19 |
| 48 | LET/HET/SEP Cen Thermal Vac (at JPL) | 2004-08-12 → 2004-09-21 (+40d) | 2004-09-01 → 2004-10-12 (+41d) |  |  | 288d → 287d |  | baseline start none → 2004-08-19; baseline finish none → 2004-09-09 |
| 49 | SIT Bake Out (at GSFC) | 2004-08-17 → 2004-10-01 (+45d) | 2004-08-19 → 2004-10-05 (+47d) |  |  | 297d → 291d |  | baseline start none → 2004-08-24; baseline finish none → 2004-08-26 |
| 50 | LET/HET/SEP Cen Bake Out (at JPL) | 2004-09-02 → 2004-10-13 (+41d) | 2004-09-07 → 2004-10-15 (+38d) |  |  | 285d → 284d |  | baseline start none → 2004-09-10; baseline finish none → 2004-09-14 |
| 51 | **SEP Suite FM 2 Environmental Test Flow Snapshot** | 2004-02-03 → 2004-02-19 A (+16d) | 2004-09-28 → 2004-10-18 (+20d) | 168d → 170d | 0% → 5% | 270d → 283d |  | baseline start none → 2004-02-17; baseline finish none → 2004-10-05 |
| 52 | SEPT (NS & E) Vibe and Acoustics (in Europe) | 2004-02-03 → 2004-02-19 A (+16d) | 2004-02-17 → 2004-02-24 A (+7d) | 10d → 4d | 0% → 100% | 428d → none | 577SS, 583SS → 577SS | was named SEPT Vibe and Acoustics (in Europe); baseline start none → 2004-02-17; baseline finish none → 2004-02-24 |
| 53 | SEPT (NS & E) Thermal Vac (in Europe) | 2004-02-18 → 2004-03-05 (+16d) | 2004-03-02 → 2004-03-18 (+16d) |  |  | 418d → 432d |  | was named SEPT Thermal Vac (in Europe); baseline start none → 2004-03-09; baseline finish none → 2004-03-17 |
| 54 | SEPT (NS & E) Bake Out (in Europe) | 2004-03-03 → 2004-03-12 (+9d) | 2004-03-05 → 2004-03-15 (+10d) | 3d → 2d |  | 415d → 435d |  | was named SEPT Bake Out (in Europe); baseline start none → 2004-03-18; baseline finish none → 2004-03-19 |
| 55 | LET/HET/SEP Cen Accelerator Test (at MSU) | 2004-07-06 → 2004-08-18 (+43d) | 2004-07-20 → 2004-09-01 (+43d) |  |  | 319d → 314d |  | baseline start none → 2004-07-13; baseline finish none → 2004-07-27 |
| 56 | LET/HET/SEP Cen Vibe and Acoustics (at JPL) | 2004-07-16 → 2004-08-31 (+46d) | 2004-07-29 → 2004-09-14 (+47d) |  |  | 312d → 306d |  | baseline start none → 2004-07-23; baseline finish none → 2004-08-05 |
| 57 | SEP Suite FM 2 EMC (at Caltech) | 2004-08-05 → 2004-08-24 (+19d) | 2004-08-11 → 2004-08-30 (+19d) |  |  | 303d → 316d |  | baseline start none → 2004-08-12; baseline finish none → 2004-08-18 |
| 58 | LET/HET/SEP Cen Thermal Vac (at JPL) | 2004-08-12 → 2004-09-15 (+34d) | 2004-09-01 → 2004-10-05 (+34d) |  |  | 288d → 291d |  | baseline start none → 2004-08-19; baseline finish none → 2004-09-09 |
| 59 | SIT Vibe and Acoustics (at GSFC) | 2004-08-16 → 2004-09-02 (+17d) | 2004-08-27 → 2004-09-16 (+20d) |  |  | 291d → 304d |  | baseline start none → 2004-08-23; baseline finish none → 2004-09-03 |
| 60 | SIT Thermal Balance (at GSFC) | 2004-08-31 → 2004-09-20 (+20d) | 2004-09-07 → 2004-09-24 (+17d) |  |  | 285d → 298d |  | baseline start none → 2004-09-08; baseline finish none → 2004-09-14 |
| 61 | LET/HET/SEP Cen Bake Out (at JPL) | 2004-09-02 → 2004-10-06 (+34d) | 2004-09-07 → 2004-10-08 (+31d) |  |  | 285d → 288d |  | baseline start none → 2004-09-10; baseline finish none → 2004-09-14 |
| 62 | SIT Thermal Vac (at GSFC) | 2004-09-08 → 2004-09-27 (+19d) | 2004-09-21 → 2004-10-08 (+17d) |  |  | 275d → 288d |  | baseline start none → 2004-09-15; baseline finish none → 2004-09-28 |
| 63 | SIT Bake Out (at GSFC) | 2004-09-24 → 2004-10-14 (+20d) | 2004-09-28 → 2004-10-18 (+20d) |  |  | 270d → 283d |  | baseline start none → 2004-10-01; baseline finish none → 2004-10-05 |
| 64 | **Power Converters - UCB** |  | 2004-06-16 → 2004-06-29 (+13d) | 330d → 339d | 45% → 63% | 343d → 19d |  | baseline start none → 2003-02-26; baseline finish none → 2004-06-23 |
| 65 | **Deliveries** |  | 2004-04-30 → 2004-06-29 (+60d) | 100d → 141d |  | 44d → 19d |  | baseline start none → 2003-12-09; baseline finish none → 2004-04-30 |
| 66 | **FM 1** |  | 2004-04-13 → 2004-05-17 (+34d) | 87d → 111d |  | 33d → 13d |  | baseline start none → 2003-12-09; baseline finish none → 2004-04-23 |
| 67 | Deliver IDPU FM 1 LVPS (stays at UCB) | 2004-04-13 → 2004-05-17 (+34d) | 2004-04-13 → 2004-05-17 (+34d) |  |  | 33d → 13d |  | baseline start none → 2004-04-23; baseline finish none → 2004-04-23 |
| 68 | Deliver SEP FM 1 LVPS (to Caltech) | 2004-03-17 → 2004-05-13 (+57d) | 2004-03-17 → 2004-05-13 (+57d) |  |  | 50d → 13d |  | baseline start none → 2004-04-06; baseline finish none → 2004-04-06 |
| 69 | Deliver SWEA/STE FM 1 LVPS (stays at UCB) | 2004-03-22 → 2004-04-23 (+32d) | 2004-03-22 → 2004-04-23 (+32d) |  |  | 27d → 7d |  | baseline start none → 2004-04-15; baseline finish none → 2004-04-15 |
| 70 | Deliver PLASTIC FM 1 LVPS (to UNH) | 2004-03-04 → 2004-04-12 (+39d) | 2004-03-05 → 2004-04-13 (+39d) |  |  | 42d → 15d |  | baseline start none → 2004-03-24; baseline finish none → 2004-03-25 |
| 71 | Deliver SIT FM 1 HVPS (to UMD) |  |  |  |  |  |  | baseline start none → 2003-12-09; baseline finish none → 2003-12-10 |
| 72 | **FM 2** | 2004-03-24 → 2004-05-14 (+51d) | 2004-04-30 → 2004-06-29 (+60d) | 28d → 32d |  | 44d → 7d |  | baseline start none → 2004-04-12; baseline finish none → 2004-04-30 |
| 73 | Deliver IDPU FM 2 LVPS (stays at UCB) | 2004-04-30 → 2004-06-29 (+60d) | 2004-04-30 → 2004-06-29 (+60d) |  |  | 37d → 19d |  | baseline start none → 2004-04-30; baseline finish none → 2004-04-30 |
| 74 | Deliver SEP FM 2 LVPS (to Caltech) | 2004-04-19 → 2004-05-18 (+29d) | 2004-04-19 → 2004-05-18 (+29d) |  |  | 27d → 10d |  | baseline start none → 2004-04-19; baseline finish none → 2004-04-19 |
| 75 | Deliver SWEA/STE FM 2 LVPS (stays at UCB) | 2004-04-26 → 2004-06-07 (+42d) | 2004-04-26 → 2004-06-07 (+42d) |  |  | 48d → 24d |  | baseline start none → 2004-04-26; baseline finish none → 2004-04-26 |

| ID | Task | Start | Finish | Duration | Complete | Total float | Predecessors | Other |
| --- | --- | --- | --- | --- | --- | --- | --- | --- |
| 76 | Deliver PLASTIC FM 2 LVPS (to UNH) | 2004-04-12 → 2004-05-21 (+39d) | 2004-04-13 → 2004-05-24 (+41d) |  |  | 41d → 12d |  | baseline start none → 2004-04-12; baseline finish none → 2004-04-13 |
| 77 | Deliver SIT FM 2 HVPS (to UMD) | 2004-03-24 → 2004-05-14 (+51d) | 2004-03-25 → 2004-05-17 (+53d) |  |  | 44d → 7d |  | baseline start none → 2004-04-12; baseline finish none → 2004-04-13 |
| 78 | **Remaining Flight Procurements** |  | 2004-02-06 → 2004-03-12 (+35d) | 71d → 95d |  | 33d → 13d |  | baseline start none → 2003-10-24; baseline finish none → 2004-02-19 |
| 79 | Procure IDPU Flight Printed Wiring Board | 2004-01-26 → 2004-03-01 (+35d) | 2004-02-06 → 2004-03-12 (+35d) |  |  | 33d → 13d |  | constraint start no earlier than 2004-01-26 → start no earlier than 2004-03-01; baseline start none → 2004-02-05; baseline finish none → 2004-02-19 |
| 80 | Procure SEP Flight Printed Wiring Board |  |  |  |  |  |  | baseline start none → 2003-11-24; baseline finish none → 2003-12-08 |
| 81 | Procure SWEA Flight Printed Wiring Board |  |  |  |  |  |  | baseline start none → 2003-12-04; baseline finish none → 2003-12-17 |
| 82 | Procure PLASTIC Flight Printed Wiring Board |  |  |  |  |  |  | baseline start none → 2003-10-24; baseline finish none → 2003-11-06 |
| 83 | **Fabrication** |  | 2004-01-20 → 2004-02-06 A (+17d) | 226d → 239d | 86% → 100% | 71d → none |  | baseline start none → 2003-02-26; baseline finish none → 2004-02-06 |
| 84 | **FM 1 & FM 2** |  |  |  |  |  |  | baseline start none → 2003-02-26; baseline finish none → 2003-12-03 |
| 85 | Re-layout IDPU LVPS Flight Printed Wiring Board |  |  |  |  |  |  | baseline start none → 2003-02-26; baseline finish none → 2003-11-19 |
| 86 | Re-layout SEP LVPS Flight Printed Wiring Board |  |  |  |  |  |  | baseline start none → 2003-09-24; baseline finish none → 2003-11-07 |
| 87 | Re-layout SWEA LVPS Flight Printed Wiring Board |  |  |  |  |  |  | baseline start none → 2003-11-26; baseline finish none → 2003-12-03 |
| 88 | **FM 1** |  |  |  |  |  |  | baseline start none → 2003-09-29; baseline finish none → 2003-12-03 |
| 89 | Wind IDPU LVPS FM 1 Magnets |  |  |  |  |  |  | baseline start none → 2003-10-17; baseline finish none → 2003-10-30 |
| 90 | Wind SEP LVPS FM 1 Magnets |  |  |  |  |  |  | baseline start none → 2003-09-29; baseline finish none → 2003-10-20 |
| 91 | Wind SWEA LVPS FM 1 Magnets |  |  |  |  |  |  | baseline start none → 2003-11-26; baseline finish none → 2003-12-03 |
| 92 | Wind PLASTIC LVPS FM 1 Magnets |  |  |  |  |  |  | baseline start none → 2003-09-29; baseline finish none → 2003-12-03 |
| 93 | **FM 2** |  | 2004-01-20 → 2004-02-06 A (+17d) | 15d → 28d | 30% → 100% | 71d → none |  | baseline start none → 2003-12-29; baseline finish none → 2004-02-06 |
| 94 | Wind HVPS FM 2 Magnets |  | 2004-01-20 → 2004-02-06 A (+17d) | 15d → 28d | 30% → 100% | 44d → none |  | baseline start none → 2003-12-29; baseline finish none → 2004-02-06 |
| 95 | Wind IDPU LVPS FM 2 Magnets |  | 2004-01-20 → 2004-02-06 A (+17d) | 15d → 28d | 30% → 100% | 64d → none |  | baseline start none → 2003-12-29; baseline finish none → 2004-02-06 |
| 96 | Wind SEP LVPS FM 2 Magnets |  | 2004-01-20 → 2004-02-06 A (+17d) | 15d → 28d | 30% → 100% | 44d → none |  | baseline start none → 2003-12-29; baseline finish none → 2004-02-06 |
| 97 | Wind SWEA LVPS FM 2 Magnets |  | 2004-01-20 → 2004-02-06 A (+17d) | 15d → 28d | 30% → 100% | 71d → none |  | baseline start none → 2003-12-29; baseline finish none → 2004-02-06 |
| 98 | Wind PLASTIC LVPS FM 2 Magnets |  | 2004-01-20 → 2004-02-06 A (+17d) | 15d → 28d | 30% → 100% | 54d → none |  | baseline start none → 2003-12-29; baseline finish none → 2004-02-06 |
| 99 | **Assembly** |  | 2004-03-19 → 2004-05-17 (+59d) | 57d → 98d | 2% → 45% | 44d → 19d |  | baseline start none → 2003-12-29; baseline finish none → 2004-03-19 |
| 100 | **FM 1** |  | 2004-03-02 → 2004-04-05 (+34d) | 44d → 68d | 5% → 78% | 33d → 13d |  | baseline start none → 2003-12-29; baseline finish none → 2004-03-12 |
| 101 | Assemble IDPU FM 1 LVPS | 2004-02-13 → 2004-03-19 (+35d) | 2004-03-02 → 2004-04-05 (+34d) |  |  | 33d → 13d |  | baseline start none → 2004-02-26; baseline finish none → 2004-03-12 |
| 102 | Assemble SEP FM 1 LVPS | 2004-01-12 A | 2004-02-02 → 2004-03-09 A (+36d) | 15d → 40d | 0% → 100% | 50d → none |  | baseline start none → 2004-01-12; baseline finish none → 2004-02-23 |
| 103 | Assemble SWEA FM 1 LVPS | 2004-01-20 → 2004-02-13 A (+24d) | 2004-02-06 → 2004-03-12 (+35d) | 14d → 20d | 0% → 50% | 27d → 7d |  | constraint start no earlier than 2004-01-12 → start no earlier than 2004-02-13; baseline start none → 2004-02-13; baseline finish none → 2004-03-04 |
| 104 | Assemble PLASTIC FM 1 LVPS |  | 2004-01-20 → 2004-02-09 A (+20d) | 15d → 29d | 20% → 100% | 42d → none |  | baseline start none → 2003-12-29; baseline finish none → 2004-02-09 |
| 105 | **FM 2** | 2004-01-21 → 2004-03-15 (+54d) | 2004-03-19 → 2004-05-17 (+59d) | 42d → 46d |  | 44d → 7d |  | baseline start none → 2004-02-09; baseline finish none → 2004-03-19 |
| 106 | Assemble IDPU FM 2 LVPS | 2004-03-01 → 2004-04-27 (+57d) | 2004-03-19 → 2004-05-17 (+59d) |  |  | 37d → 19d | 95 → 95, 119 | baseline start none → 2004-03-01; baseline finish none → 2004-03-19 |
| 107 | Assemble SEP FM 2 LVPS | 2004-02-13 → 2004-03-16 (+32d) | 2004-03-05 → 2004-04-05 (+31d) |  |  | 27d → 10d | 96 → 96, 123 | baseline start none → 2004-02-13; baseline finish none → 2004-03-05 |
| 108 | Assemble SWEA FM 2 LVPS | 2004-02-24 → 2004-04-05 (+41d) | 2004-03-15 → 2004-04-23 (+39d) |  |  | 48d → 24d | 97 → 97, 127 | baseline start none → 2004-02-24; baseline finish none → 2004-03-15 |
| 109 | Assemble PLASTIC FM 2 LVPS | 2004-02-09 → 2004-03-22 (+42d) | 2004-02-27 → 2004-04-08 (+41d) |  |  | 41d → 12d | 98 → 98, 131 | baseline start none → 2004-02-09; baseline finish none → 2004-02-27 |
| 110 | Assemble SIT FM 2 HVPS | 2004-01-21 → 2004-03-15 (+54d) | 2004-02-09 → 2004-04-01 (+52d) |  |  | 44d → 7d | 94 → 94, 103 | baseline start none → 2004-02-09; baseline finish none → 2004-02-27 |
| 111 | **Testing** |  | 2004-06-16 → 2004-06-29 (+13d) | 157d → 166d | 12% → 21% | 343d → 19d |  | baseline start none → 2003-10-31; baseline finish none → 2004-06-23 |
| 112 | **FM 1 & FM 2** |  | 2004-02-12 → 2004-03-18 (+35d) | 55d → 79d |  | 33d → 13d |  | baseline start none → 2003-11-24; baseline finish none → 2004-02-25 |
| 113 | Coupon Test IDPU Flight Printed Wiring Board | 2004-02-09 → 2004-03-15 (+35d) | 2004-02-12 → 2004-03-18 (+35d) |  |  | 33d → 13d |  | baseline start none → 2004-02-20; baseline finish none → 2004-02-25 |
| 114 | Coupon Test SEP Flight Printed Wiring Board |  |  |  |  |  |  | baseline start none → 2003-12-09; baseline finish none → 2003-12-15 |
| 115 | Coupon Test SWEA Flight Printed Wiring Board |  |  |  |  |  |  | baseline start none → 2004-01-09; baseline finish none → 2004-01-16 |
| 116 | Coupon Test PLASTIC Flight Printed Wiring Board |  |  |  |  |  |  | baseline start none → 2003-11-24; baseline finish none → 2003-12-01 |
| 117 | **FM 1** |  | 2004-06-16 → 2004-05-17 (-30d) | 157d → 136d | 16% → 35% | 343d → 13d |  | baseline start none → 2003-10-31; baseline finish none → 2004-06-23 |
| 118 | **IDPU** | 2004-03-03 → 2004-04-06 (+34d) | 2004-04-13 → 2004-05-17 (+34d) |  |  | 33d → 13d |  | baseline start none → 2004-03-15; baseline finish none → 2004-04-23 |
| 119 | Test IDPU FM 1 LVPS | 2004-03-03 → 2004-04-06 (+34d) | 2004-03-23 → 2004-04-26 (+34d) |  |  | 33d → 13d |  | baseline start none → 2004-03-15; baseline finish none → 2004-04-02 |
| 120 | Coat & Stake IDPU LVPS FM 1 Boards | 2004-03-24 → 2004-04-27 (+34d) | 2004-03-30 → 2004-05-03 (+34d) |  |  | 33d → 13d |  | baseline start none → 2004-04-05; baseline finish none → 2004-04-09 |
| 121 | Retest IDPU LVPS FM 1 Boards | 2004-03-31 → 2004-05-04 (+34d) | 2004-04-13 → 2004-05-17 (+34d) |  |  | 33d → 13d |  | baseline start none → 2004-04-12; baseline finish none → 2004-04-23 |
| 122 | **SEP** | 2004-02-03 → 2004-03-10 (+36d) | 2004-03-16 → 2004-05-12 (+57d) | 30d → 46d |  | 50d → 10d |  | baseline start none → 2004-02-24; baseline finish none → 2004-04-05 |
| 123 | Test SEP FM 1 LVPS | 2004-02-03 → 2004-03-10 (+36d) | 2004-02-24 → 2004-03-15 (+20d) | 15d → 4d |  | 50d → 10d |  | baseline start none → 2004-02-24; baseline finish none → 2004-03-15 |
| 124 | Coat & Stake SEP LVPS FM 1 Boards | 2004-02-25 → 2004-03-16 (+20d) | 2004-03-02 → 2004-03-22 (+20d) |  |  | 50d → 40d |  | baseline start none → 2004-03-16; baseline finish none → 2004-03-22 |
| 125 | Retest SEP LVPS FM 1 Boards | 2004-03-03 → 2004-04-29 (+57d) | 2004-03-16 → 2004-05-12 (+57d) |  |  | 50d → 13d |  | baseline start none → 2004-03-23; baseline finish none → 2004-04-05 |
| 126 | **SWEA** | 2004-02-09 → 2004-03-15 A (+35d) | 2004-03-22 → 2004-04-23 (+32d) |  | 0% → 43% | 27d → 7d |  | baseline start none → 2004-03-05; baseline finish none → 2004-04-15 |
| 127 | Test SWEA FM 1 LVPS | 2004-02-09 → 2004-03-15 A (+35d) | 2004-03-01 → 2004-04-02 (+32d) |  | 0% → 87% | 27d → 7d |  | baseline start none → 2004-03-05; baseline finish none → 2004-03-25 |
| 128 | Coat & Stake SWEA LVPS FM 1 Boards | 2004-03-02 → 2004-04-05 (+34d) | 2004-03-08 → 2004-04-09 (+32d) |  |  | 27d → 7d |  | baseline start none → 2004-03-26; baseline finish none → 2004-04-01 |
| 129 | Retest SWEA LVPS FM 1 Boards | 2004-03-09 → 2004-04-12 (+34d) | 2004-03-22 → 2004-04-23 (+32d) |  |  | 27d → 7d |  | baseline start none → 2004-04-02; baseline finish none → 2004-04-15 |
| 130 | **PLASTIC** | 2004-01-21 → 2004-02-10 A (+20d) | 2004-03-03 → 2004-04-09 (+37d) | 30d → 43d | 0% → 30% | 42d → 15d |  | baseline start none → 2004-02-10; baseline finish none → 2004-03-23 |
| 131 | Test PLASTIC FM 1 LVPS | 2004-01-21 → 2004-02-10 A (+20d) | 2004-02-10 → 2004-03-19 (+38d) | 15d → 28d | 0% → 46% | 42d → 12d |  | baseline start none → 2004-02-10; baseline finish none → 2004-03-02 |
| 132 | Coat & Stake PLASTIC LVPS FM 1 Boards | 2004-02-11 → 2004-03-22 (+40d) | 2004-02-18 → 2004-03-26 (+37d) |  |  | 42d → 15d |  | baseline start none → 2004-03-03; baseline finish none → 2004-03-09 |
| 133 | Retest PLASTIC LVPS FM 1 Boards | 2004-02-19 → 2004-03-29 (+39d) | 2004-03-03 → 2004-04-09 (+37d) |  |  | 42d → 15d |  | baseline start none → 2004-03-10; baseline finish none → 2004-03-23 |
| 134 | **SIT** |  | 2004-06-16 → 2003-12-08 A (-191d) | 157d → 25d | 63% → 100% | 343d → none |  | baseline start none → 2003-10-31; baseline finish none → 2004-06-23 |
| 135 | Test SIT FM 1 HVPS |  |  |  |  |  |  | baseline start none → 2003-10-31; baseline finish none → 2003-12-08 |
| 136 | **FM 2** | 2004-02-10 → 2004-04-02 (+52d) | 2004-04-30 → 2004-06-29 (+60d) | 58d → 62d |  | 44d → 7d |  | baseline start none → 2004-03-01; baseline finish none → 2004-04-30 |
| 137 | **IDPU** | 2004-03-22 → 2004-05-18 (+57d) | 2004-04-30 → 2004-06-29 (+60d) |  |  | 37d → 19d |  | baseline start none → 2004-03-22; baseline finish none → 2004-04-30 |
| 138 | Test IDPU FM 2 LVPS | 2004-03-22 → 2004-05-18 (+57d) | 2004-04-09 → 2004-06-08 (+60d) |  |  | 37d → 19d |  | baseline start none → 2004-03-22; baseline finish none → 2004-04-09 |
| 139 | Coat & Stake IDPU LVPS FM 2 Boards | 2004-04-12 → 2004-06-09 (+58d) | 2004-04-16 → 2004-06-15 (+60d) |  |  | 37d → 19d |  | baseline start none → 2004-04-12; baseline finish none → 2004-04-16 |
| 140 | Retest IDPU LVPS FM 2 Boards | 2004-04-19 → 2004-06-16 (+58d) | 2004-04-30 → 2004-06-29 (+60d) |  |  | 37d → 19d |  | baseline start none → 2004-04-19; baseline finish none → 2004-04-30 |
| 141 | **SEP** | 2004-03-08 → 2004-04-06 (+29d) | 2004-04-16 → 2004-05-17 (+31d) |  |  | 27d → 10d |  | baseline start none → 2004-03-08; baseline finish none → 2004-04-16 |
| 142 | Test SEP FM 2 LVPS | 2004-03-08 → 2004-04-06 (+29d) | 2004-03-26 → 2004-04-26 (+31d) |  |  | 27d → 10d |  | baseline start none → 2004-03-08; baseline finish none → 2004-03-26 |
| 143 | Coat & Stake SEP LVPS FM 2 Boards | 2004-03-29 → 2004-04-27 (+29d) | 2004-04-02 → 2004-05-03 (+31d) |  |  | 27d → 10d |  | baseline start none → 2004-03-29; baseline finish none → 2004-04-02 |
| 144 | Retest SEP LVPS FM 2 Boards | 2004-04-05 → 2004-05-04 (+29d) | 2004-04-16 → 2004-05-17 (+31d) |  |  | 27d → 10d |  | baseline start none → 2004-04-05; baseline finish none → 2004-04-16 |
| 145 | **SWEA** | 2004-03-16 → 2004-04-26 (+41d) | 2004-04-26 → 2004-06-07 (+42d) |  |  | 48d → 24d |  | baseline start none → 2004-03-16; baseline finish none → 2004-04-26 |

| ID | Task | Start | Finish | Duration | Complete | Total float | Predecessors | Other |
| --- | --- | --- | --- | --- | --- | --- | --- | --- |
| 146 | Test SWEA FM 2 LVPS | 2004-03-16 → 2004-04-26 (+41d) | 2004-04-05 → 2004-05-14 (+39d) |  |  | 48d → 24d |  | baseline start none → 2004-03-16; baseline finish none → 2004-04-05 |
| 147 | Coat & Stake SWEA LVPS FM 2 Boards | 2004-04-06 → 2004-05-17 (+41d) | 2004-04-12 → 2004-05-21 (+39d) |  |  | 48d → 24d |  | baseline start none → 2004-04-06; baseline finish none → 2004-04-12 |
| 148 | Retest SWEA LVPS FM 2 Boards | 2004-04-13 → 2004-05-24 (+41d) | 2004-04-26 → 2004-06-07 (+42d) |  |  | 48d → 24d |  | baseline start none → 2004-04-13; baseline finish none → 2004-04-26 |
| 149 | **PLASTIC** | 2004-03-01 → 2004-04-09 (+39d) | 2004-04-09 → 2004-05-20 (+41d) |  |  | 41d → 12d |  | baseline start none → 2004-03-01; baseline finish none → 2004-04-09 |
| 150 | Test PLASTIC FM 2 LVPS | 2004-03-01 → 2004-04-09 (+39d) | 2004-03-19 → 2004-04-29 (+41d) |  |  | 41d → 12d |  | baseline start none → 2004-03-01; baseline finish none → 2004-03-19 |
| 151 | Coat & Stake PLASTIC LVPS FM 2 Boards | 2004-03-22 → 2004-04-30 (+39d) | 2004-03-26 → 2004-05-06 (+41d) |  |  | 41d → 12d |  | baseline start none → 2004-03-22; baseline finish none → 2004-03-26 |
| 152 | Retest PLASTIC LVPS FM 2 Boards | 2004-03-29 → 2004-05-07 (+39d) | 2004-04-09 → 2004-05-20 (+41d) |  |  | 41d → 12d |  | baseline start none → 2004-03-29; baseline finish none → 2004-04-09 |
| 153 | **SIT** | 2004-02-10 → 2004-04-02 (+52d) | 2004-03-23 → 2004-05-13 (+51d) |  |  | 44d → 7d |  | baseline start none → 2004-03-01; baseline finish none → 2004-04-09 |
| 154 | Test SIT FM 2 HVPS | 2004-02-10 → 2004-04-02 (+52d) | 2004-03-02 → 2004-04-22 (+51d) |  |  | 44d → 7d |  | baseline start none → 2004-03-01; baseline finish none → 2004-03-19 |
| 155 | Coat & Stake SIT FM 2 HVPS Boards | 2004-03-03 → 2004-04-23 (+51d) | 2004-03-09 → 2004-04-29 (+51d) |  |  | 44d → 7d |  | baseline start none → 2004-03-22; baseline finish none → 2004-03-26 |
| 156 | Retest SIT FM 2 HVPS Boards | 2004-03-10 → 2004-04-30 (+51d) | 2004-03-23 → 2004-05-13 (+51d) |  |  | 44d → 7d |  | baseline start none → 2004-03-29; baseline finish none → 2004-04-09 |
| 157 | **IDPU - UCB** |  |  |  | 59% → 76% | 285d → 0d |  | baseline start none → 2003-05-05; baseline finish none → 2004-09-07 |
| 158 | **Deliveries** | 2004-02-09 → 2004-06-15 (+127d) | 2004-05-28 → 2004-07-27 (+60d) | 78d → 30d |  | 98d → 13d |  | baseline start none → 2004-04-13; baseline finish none → 2004-05-28 |
| 159 | IDPU FM 1 Complete (to UCB for Boom I&T, then to CIT for SEP I&T, Suite EMC, BO & Final Boom I&T) | 2004-05-11 → 2004-06-15 (+35d) | 2004-05-11 → 2004-06-15 (+35d) |  |  | 33d → 13d |  | baseline start none → 2004-05-21; baseline finish none → 2004-05-21 |
| 160 | IDPU FM 2 Complete (to CIT for SEP I&T, then to UCB for Boom I&T, Boom EMC, BO & Final Boom I&T) | 2004-05-28 → 2004-07-27 (+60d) | 2004-05-28 → 2004-07-27 (+60d) |  |  | 37d → 19d |  | baseline start none → 2004-05-28; baseline finish none → 2004-05-28 |
| 161 | **Flight Software** |  | 2004-02-09 → 2004-04-13 (+64d) | 192d → 237d | 81% → 89% | 105d → 83d |  | baseline start none → 2003-05-05; baseline finish none → 2004-04-13 |
| 162 | IDPU S/W Build #2.5 |  |  |  |  |  |  | baseline start none → 2003-05-05; baseline finish none → 2003-11-07 |
| 163 | IDPU S/W Build #3 (also goes to UNH) |  | 2004-02-09 → 2004-04-13 (+64d) | 120d → 165d | 60% → 81% | 105d → 83d |  | was named IDPU S/W Build #3; baseline start none → 2003-08-15; baseline finish none → 2004-04-13 |
| 164 | **GSE** |  |  |  | 50% → 72% | 285d → 0d |  | baseline start none → 2003-06-30; baseline finish none → 2004-09-07 |
| 165 | STE Science Display |  |  |  |  |  |  | baseline start none → 2003-10-23; baseline finish none → 2003-12-02 |
| 166 | SWEA Science Display |  | 2004-01-21 → 2004-03-01 A (+40d) | 140d → 167d | 62% → 100% | 446d → none |  | baseline start none → 2003-06-30; baseline finish none → 2004-02-23 |
| 167 | GSE Continued Development (LOE) |  |  |  | 40% → 54% | 285d → 0d |  | was named GSE Continued Development; constraint start no earlier than 2003-07-15 → must start on 2003-07-15; baseline start none → 2003-07-15; baseline finish none → 2004-09-07 |
| 168 | **Integration & Test** |  | 2004-08-25 → 2004-07-27 (-29d) | 224d → 203d | 33% → 38% | 33d → 19d |  | baseline start none → 2003-10-07; baseline finish none → 2004-05-28 |
| 169 | IDPU DCB FM 2 Board Level Testing |  |  |  |  |  |  | baseline start none → 2003-10-07; baseline finish none → 2003-10-28 |
| 170 | IDPU DCB Clean/Stake/Coat (FM 1 & FM 2) |  |  |  |  |  |  | baseline start none → 2003-12-26; baseline finish none → 2004-01-09 |
| 171 | **FM 1** | 2004-04-14 → 2004-05-18 (+34d) | 2004-07-12 → 2004-06-15 (-27d) | 63d → 20d |  | 33d → 13d |  | baseline start none → 2004-04-26; baseline finish none → 2004-05-21 |
| 172 | IDPU FM 1 I & T | 2004-04-14 → 2004-05-18 (+34d) | 2004-04-20 → 2004-05-24 (+34d) |  |  | 33d → 13d |  | baseline start none → 2004-04-26; baseline finish none → 2004-04-30 |
| 173 | IDPU FM 1 Vibration | 2004-04-21 → 2004-05-25 (+34d) | 2004-04-27 → 2004-06-01 (+35d) |  |  | 33d → 13d |  | baseline start none → 2004-05-03; baseline finish none → 2004-05-07 |
| 174 | IDPU FM 1 Thermal Vacuum & Bake Out | 2004-04-28 → 2004-06-02 (+35d) | 2004-05-11 → 2004-06-15 (+35d) |  |  | 33d → 13d |  | was named IDPU FM 1 Thermal Vacuum; baseline start none → 2004-05-10; baseline finish none → 2004-05-21 |
| 175 | **FM 2** | 2004-05-03 → 2004-06-30 (+58d) | 2004-08-25 → 2004-07-27 (-29d) | 82d → 20d |  | 33d → 19d |  | baseline start none → 2004-05-03; baseline finish none → 2004-05-28 |
| 176 | IDPU FM 2 I & T | 2004-05-03 → 2004-06-30 (+58d) | 2004-05-07 → 2004-07-06 (+60d) |  |  | 37d → 19d |  | baseline start none → 2004-05-03; baseline finish none → 2004-05-07 |
| 177 | IDPU FM 2 Vibration | 2004-05-10 → 2004-07-07 (+58d) | 2004-05-14 → 2004-07-13 (+60d) |  |  | 37d → 19d |  | baseline start none → 2004-05-10; baseline finish none → 2004-05-14 |
| 178 | IDPU FM 2 Thermal Vacuum & Bake Out | 2004-05-17 → 2004-07-14 (+58d) | 2004-05-28 → 2004-07-27 (+60d) |  |  | 37d → 19d |  | was named IDPU FM 2 Thermal Vacuum; baseline start none → 2004-05-17; baseline finish none → 2004-05-28 |
| 179 | **BOOM Suite - UCB** |  | 2004-09-09 → 2004-10-06 (+27d) | 302d → 321d | 56% → 72% | 283d → 14d |  | baseline start none → 2003-07-01; baseline finish none → 2004-09-28 |
| 180 | **BOOM Structure - UCB** |  | 2004-06-08 → 2004-07-19 (+41d) | 187d → 216d | 59% → 85% | 73d → 49d |  | baseline start none → 2003-09-10; baseline finish none → 2004-06-18 |
| 181 | **Deliveries** |  | 2004-06-08 → 2004-07-19 (+41d) | 104d → 133d |  | 73d → 49d |  | baseline start none → 2004-01-09; baseline finish none → 2004-06-18 |
| 182 | Protoflight Boom available for I&T (if needed) |  |  |  |  |  |  | baseline start none → 2004-01-09; baseline finish none → 2004-01-09 |
| 183 | Deliver Boom Structure FM 1 (stays at UCB for Boom Suite FM 1 I&T) | 2004-05-17 → 2004-06-02 (+16d) | 2004-05-17 → 2004-06-02 (+16d) |  |  | 27d → 20d |  | baseline start none → 2004-05-27; baseline finish none → 2004-05-27 |
| 184 | Deliver Boom Structure FM 2 (stays at UCB for Boom Suite FM 2 I&T) | 2004-06-08 → 2004-07-19 (+41d) | 2004-06-08 → 2004-07-19 (+41d) |  |  | 73d → 49d |  | baseline start none → 2004-06-18; baseline finish none → 2004-06-18 |
| 185 | **Protoflight** |  |  |  |  |  |  | baseline start none → 2003-09-16; baseline finish none → 2004-01-09 |
| 186 | Protoflight Boom Post Environmental Deployment Test |  |  |  |  |  |  | baseline start none → 2003-09-16; baseline finish none → 2003-11-04 |
| 187 | Document Protoflight Boom Test Results |  |  |  |  |  |  | baseline start none → 2003-11-05; baseline finish none → 2004-01-09 |
| 188 | **Flight Procurements** |  |  |  |  |  |  | baseline start none → 2003-09-10; baseline finish none → 2003-11-05 |
| 189 | Receive and Inspect Flight Boom Structure Tubes (FM 1) |  |  |  |  |  |  | baseline start none → 2003-09-10; baseline finish none → 2003-10-24 |
| 190 | Receive and Inspect Flight Boom Structure Tubes (FM 2) |  |  |  |  |  |  | baseline start none → 2003-09-10; baseline finish none → 2003-11-05 |
| 191 | **FM 1** |  | 2004-05-17 → 2004-06-02 (+16d) | 159d → 170d | 46% → 79% | 27d → 20d |  | baseline start none → 2003-09-29; baseline finish none → 2004-05-27 |
| 192 | **Telescoping** |  | 2004-02-24 → 2004-02-29 A (+5d) | 81d → 84d | 59% → 100% | 29d → none |  | baseline start none → 2003-10-27; baseline finish none → 2004-02-29 |
| 193 | **Fabrication, Assembly & Test** |  | 2004-02-24 → 2004-02-29 A (+5d) | 81d → 84d | 59% → 100% | 29d → none |  | baseline start none → 2003-10-27; baseline finish none → 2004-02-29 |
| 194 | Machine FM 1 Boom Structure Tubes as necessary |  |  |  |  |  |  | baseline start none → 2003-10-27; baseline finish none → 2003-10-31 |
| 195 | Machine FM 1 Boom Structure Parts (Rings) |  |  |  |  |  |  | baseline start none → 2003-11-07; baseline finish none → 2004-01-05 |
| 196 | Assemble FM 1 Boom Structure Telescoping Assembly | 2004-01-12 → 2004-02-23 A (+42d) | 2004-02-09 → 2004-02-27 A (+18d) | 20d → 5d | 0% → 100% | 29d → none |  | constraint start no earlier than 2004-01-12 → start no earlier than 2004-02-23; baseline start none → 2004-02-23; baseline finish none → 2004-02-27 |
| 197 | Test FM 1 Boom Structure Telescoping Assembly | 2004-02-10 → 2004-02-28 A (+18d) | 2004-02-24 → 2004-02-29 A (+5d) | 10d → 2d | 0% → 100% | 29d → none |  | baseline start none → 2004-02-28; baseline finish none → 2004-02-29 |
| 198 | **Harness** |  | 2004-02-26 → 2004-03-08 A (+11d) | 102d → 109d | 41% → 100% | 27d → none |  | baseline start none → 2003-09-29; baseline finish none → 2004-03-08 |
| 199 | **Fabrication** |  | 2004-01-13 → 2004-02-27 A (+45d) | 72d → 103d | 59% → 100% | 27d → none |  | baseline start none → 2003-09-29; baseline finish none → 2004-02-27 |
| 200 | Machine FM 1 Harness Parts |  | 2004-01-13 → 2004-02-27 A (+45d) | 72d → 103d | 59% → 100% | 27d → none |  | baseline start none → 2003-09-29; baseline finish none → 2004-02-27 |
| 201 | **Assembly & Test** | 2004-01-14 → 2004-03-01 A (+47d) | 2004-02-26 → 2004-03-08 A (+11d) | 30d → 6d | 0% → 100% | 27d → none |  | baseline start none → 2004-03-01; baseline finish none → 2004-03-08 |
| 202 | Assemble FM 1 Harness subassembly | 2004-01-14 → 2004-03-01 A (+47d) | 2004-02-11 → 2004-03-07 A (+25d) | 20d → 7d | 0% → 100% | 27d → none |  | constraint none → start no earlier than 2004-03-01; baseline start none → 2004-03-01; baseline finish none → 2004-03-07 |
| 203 | FM1 Harness Test | 2004-02-12 → 2004-03-08 A (+25d) | 2004-02-26 → 2004-03-08 A (+11d) | 10d → 1d | 0% → 100% | 27d → none |  | baseline start none → 2004-03-08; baseline finish none → 2004-03-08 |
| 204 | **Mounting** |  |  |  |  |  |  | baseline start none → 2003-09-29; baseline finish none → 2003-11-21 |
| 205 | FM 1Boom Structure Mounting Fabrication |  |  |  |  |  |  | baseline start none → 2003-09-29; baseline finish none → 2003-11-06 |
| 206 | FM 1Boom Structure Mounting Assembly |  |  |  |  |  |  | baseline start none → 2003-11-07; baseline finish none → 2003-11-21 |
| 207 | **Integration & Test** | 2004-02-27 → 2004-03-15 (+17d) | 2004-05-17 → 2004-06-02 (+16d) |  |  | 27d → 20d |  | baseline start none → 2004-03-09; baseline finish none → 2004-05-27 |
| 208 | Integrate FM 1 Boom Structure subassemblies & Harness Completion | 2004-02-27 → 2004-03-15 (+17d) | 2004-03-25 → 2004-04-09 (+15d) |  |  | 27d → 20d | 197, 203 → 197, 203, 230FS-5d | was named Integrate FM 1 Boom Structure subassemblies; baseline start none → 2004-03-09; baseline finish none → 2004-04-05 |
| 209 | FM 1 Boom Structure Deployment Test | 2004-03-26 → 2004-04-12 (+17d) | 2004-04-08 → 2004-04-23 (+15d) |  |  | 27d → 20d |  | baseline start none → 2004-04-06; baseline finish none → 2004-04-19 |
| 210 | FM 1 Boom Structure Vibration Test | 2004-04-15 → 2004-04-30 (+15d) | 2004-04-20 → 2004-05-05 (+15d) |  |  | 27d → 20d |  | was named FM 1 Boom Structure Vibration Testing Completed; baseline start none → 2004-04-27; baseline finish none → 2004-04-30 |
| 211 | FM 1 Boom Structure Themal Vac & Bake Out | 2004-04-21 → 2004-05-06 (+15d) | 2004-05-11 → 2004-05-26 (+15d) |  |  | 27d → 20d |  | was named FM 1 Boom Structure Themal Vac Testing Completed; baseline start none → 2004-05-03; baseline finish none → 2004-05-21 |
| 212 | FM 1 Boom Structure Post Environmental Deployment Test | 2004-05-12 → 2004-05-27 (+15d) | 2004-05-17 → 2004-06-02 (+16d) |  |  | 27d → 20d |  | was named FM 1 Boom Structure Post Environmental Deployment Test Completed; baseline start none → 2004-05-24; baseline finish none → 2004-05-27 |
| 213 | **FM 2** |  | 2004-06-08 → 2004-07-19 (+41d) | 174d → 203d | 47% → 83% | 73d → 49d |  | baseline start none → 2003-09-29; baseline finish none → 2004-06-18 |
| 214 | **Telescoping** |  | 2004-02-24 → 2004-03-02 A (+7d) | 73d → 78d | 62% → 100% | 90d → none |  | baseline start none → 2003-11-06; baseline finish none → 2004-03-16 |
| 215 | **Fabrication, Assembly & Test** |  | 2004-02-24 → 2004-03-02 A (+7d) | 73d → 78d | 62% → 100% | 90d → none |  | baseline start none → 2003-11-06; baseline finish none → 2004-03-16 |

| ID | Task | Start | Finish | Duration | Complete | Total float | Predecessors | Other |
| --- | --- | --- | --- | --- | --- | --- | --- | --- |
| 216 | Machine FM 2 Boom Structure Tubes as necessary |  |  |  |  |  |  | baseline start none → 2003-11-06; baseline finish none → 2003-11-21 |
| 217 | Machine FM 2 Boom Structure Parts (Rings) |  |  |  |  |  |  | baseline start none → 2003-11-07; baseline finish none → 2004-01-05 |
| 218 | Assemble FM 2 Boom Structure Telescoping Assembly | 2004-01-12 → 2004-02-23 A (+42d) | 2004-02-09 → 2004-02-27 A (+18d) | 20d → 5d | 0% → 100% | 90d → none | 216, 217 → 216, 217, 196SS | constraint start no earlier than 2004-01-12 → none; baseline start none → 2004-02-23; baseline finish none → 2004-02-27 |
| 219 | Test FM 2 Boom Structure Telescoping Assembly | 2004-02-10 → 2004-03-01 A (+20d) | 2004-02-24 → 2004-03-02 A (+7d) | 10d → 2d | 0% → 100% | 90d → none |  | baseline start none → 2004-03-15; baseline finish none → 2004-03-16 |
| 220 | **Harness** |  | 2004-02-26 → 2004-03-09 A (+12d) | 102d → 110d | 41% → 100% | 88d → none |  | baseline start none → 2003-09-29; baseline finish none → 2004-03-16 |
| 221 | **Fabrication** |  | 2004-01-13 → 2004-02-27 A (+45d) | 72d → 103d | 59% → 100% | 88d → none |  | baseline start none → 2003-09-29; baseline finish none → 2004-02-27 |
| 222 | Machine FM 2 Harness Parts |  | 2004-01-13 → 2004-02-27 A (+45d) | 72d → 103d | 59% → 100% | 88d → none |  | baseline start none → 2003-09-29; baseline finish none → 2004-02-27 |
| 223 | **Assembly & Test** | 2004-01-14 → 2004-03-01 A (+47d) | 2004-02-26 → 2004-03-09 A (+12d) | 30d → 7d | 0% → 100% | 88d → none |  | baseline start none → 2004-03-01; baseline finish none → 2004-03-16 |
| 224 | Assemble FM 2 Harness subassembly | 2004-01-14 → 2004-03-01 A (+47d) | 2004-02-11 → 2004-03-08 A (+26d) | 20d → 6d | 0% → 100% | 88d → none |  | baseline start none → 2004-03-01; baseline finish none → 2004-03-15 |
| 225 | FM 2 Harness Test | 2004-02-12 → 2004-03-09 A (+26d) | 2004-02-26 → 2004-03-09 A (+12d) | 10d → 1d | 0% → 100% | 88d → none |  | baseline start none → 2004-03-16; baseline finish none → 2004-03-16 |
| 226 | **Mounting** |  |  |  |  |  |  | baseline start none → 2003-09-29; baseline finish none → 2003-11-21 |
| 227 | FM 2 Boom Structure Mountings Fabrication |  |  |  |  |  |  | baseline start none → 2003-09-29; baseline finish none → 2003-11-06 |
| 228 | FM 2 Boom Structure Mountings Assembly |  |  |  |  |  |  | baseline start none → 2003-11-07; baseline finish none → 2003-11-21 |
| 229 | **Integration & Test** | 2004-02-27 → 2004-03-10 (+12d) | 2004-06-08 → 2004-07-19 (+41d) | 72d → 93d |  | 73d → 20d |  | baseline start none → 2004-03-17; baseline finish none → 2004-06-18 |
| 230 | Integrate FM 2 Boom Structure subassemblies & Harness Completion | 2004-02-27 → 2004-03-10 (+12d) | 2004-03-25 → 2004-03-19 (-6d) | 20d → 8d |  | 88d → 20d |  | was named Integrate FM 2 Boom Structure subassemblies; baseline start none → 2004-03-17; baseline finish none → 2004-04-13 |
| 231 | FM 2 Boom Structure Deployment Test | 2004-03-26 → 2004-03-22 (-4d) | 2004-04-08 → 2004-04-02 (-6d) |  |  | 88d → 97d |  | baseline start none → 2004-04-14; baseline finish none → 2004-04-27 |
| 232 | FM 2 Boom Structure Vibration Test | 2004-04-16 → 2004-06-17 (+62d) | 2004-04-21 → 2004-06-22 (+62d) |  |  | 87d → 49d |  | baseline start none → 2004-05-17; baseline finish none → 2004-05-20 |
| 233 | FM 2 Boom Structure Themal Vac & Bake Out | 2004-05-12 → 2004-06-23 (+42d) | 2004-06-02 → 2004-07-13 (+41d) |  |  | 73d → 49d |  | was named FM 2 Boom Structure Themal Vac Testing; baseline start none → 2004-05-24; baseline finish none → 2004-06-14 |
| 234 | FM 2 Boom Structure Post Environmental Deployment Test | 2004-06-03 → 2004-07-14 (+41d) | 2004-06-08 → 2004-07-19 (+41d) |  |  | 73d → 49d |  | baseline start none → 2004-06-15; baseline finish none → 2004-06-18 |
| 235 | **MAG - GSFC** | 2004-01-09 → 2004-02-20 A (+42d) | 2004-03-17 → 2004-03-29 (+12d) | 47d → 27d | 0% → 22% | 63d → 84d |  | baseline start none → 2004-02-20; baseline finish none → 2004-03-29 |
| 236 | **Deliveries** | 2004-02-17 → 2004-03-26 (+38d) | 2004-03-17 → 2004-03-29 (+12d) | 22d → 2d |  | 63d → 39d |  | baseline start none → 2004-03-26; baseline finish none → 2004-03-29 |
| 237 | Deliver MAG FM 1 (to UCB for IDPU/BOOM Suite FM 1 I&T) | 2004-02-17 → 2004-03-26 (+38d) | 2004-02-18 → 2004-03-29 (+40d) |  |  | 63d → 39d |  | baseline start none → 2004-03-26; baseline finish none → 2004-03-29 |
| 238 | Deliver MAG FM 2 (to UCB for IDPU/BOOM Suite FM 2 I&T) | 2004-03-16 → 2004-03-26 (+10d) | 2004-03-17 → 2004-03-29 (+12d) |  |  | 69d → 84d |  | baseline start none → 2004-03-26; baseline finish none → 2004-03-29 |
| 239 | **FM 1** | 2004-01-09 → 2004-02-20 A (+42d) | 2004-02-13 → 2004-03-25 (+41d) |  | 0% → 24% | 63d → 39d |  | baseline start none → 2004-02-20; baseline finish none → 2004-03-25 |
| 240 | FM 1 MAG Testing | 2004-01-09 → 2004-02-20 A (+42d) | 2004-01-23 → 2004-03-04 (+41d) |  | 0% → 60% | 63d → 39d |  | constraint start no earlier than 2004-01-09 → start no earlier than 2004-02-20; baseline start none → 2004-02-20; baseline finish none → 2004-03-04 |
| 241 | MAG FM 1 Calibration | 2004-01-26 → 2004-03-05 (+39d) | 2004-02-13 → 2004-03-25 (+41d) |  |  | 63d → 39d |  | baseline start none → 2004-03-05; baseline finish none → 2004-03-25 |
| 242 | **FM 2** | 2004-02-09 → 2004-02-20 A (+11d) | 2004-03-15 → 2004-03-25 (+10d) |  | 0% → 24% | 69d → 84d |  | baseline start none → 2004-02-20; baseline finish none → 2004-03-25 |
| 243 | FM 2 MAG Testing | 2004-02-09 → 2004-02-20 A (+11d) | 2004-02-23 → 2004-03-04 (+10d) |  | 0% → 60% | 69d → 84d |  | constraint start no earlier than 2004-02-09 → start no earlier than 2004-02-20; baseline start none → 2004-02-20; baseline finish none → 2004-03-04 |
| 244 | MAG FM 2 Calibration | 2004-02-24 → 2004-03-05 (+10d) | 2004-03-15 → 2004-03-25 (+10d) |  |  | 69d → 84d |  | baseline start none → 2004-03-05; baseline finish none → 2004-03-25 |
| 245 | **SWEA - CESR** |  | 2004-03-31 → 2004-05-05 (+35d) | 79d → 104d | 6% → 27% | 76d → 56d |  | baseline start none → 2003-12-08; baseline finish none → 2004-04-20 |
| 246 | **Deliveries** |  | 2004-03-31 → 2004-05-05 (+35d) | 79d → 104d |  | 76d → 56d |  | baseline start none → 2003-12-08; baseline finish none → 2004-04-20 |
| 247 | SWEA FM 1 Delivery to UCB |  |  |  |  |  |  | baseline start none → 2003-12-08; baseline finish none → 2003-12-10 |
| 248 | SWEA FM 2 Delivery to UCB | 2004-03-29 → 2004-05-03 (+35d) | 2004-03-31 → 2004-05-05 (+35d) |  |  | 76d → 56d |  | baseline start none → 2004-04-16; baseline finish none → 2004-04-20 |
| 249 | **FM 2** | 2004-01-21 → 2004-03-15 A (+54d) | 2004-03-26 → 2004-04-30 (+35d) | 47d → 35d | 0% → 21% | 76d → 56d |  | baseline start none → 2004-02-10; baseline finish none → 2004-04-15 |
| 250 | SWEA FM 2 Final Assembly (Block 2) | 2004-01-21 → 2004-03-15 A (+54d) | 2004-01-23 → 2004-03-19 A (+56d) | 3d → 5d | 0% → 100% | 76d → none |  | constraint start no earlier than 2004-01-21 → start no earlier than 2004-03-15; baseline start none → 2004-02-10; baseline finish none → 2004-02-12 |
| 251 | SWEA FM 2 Calibration | 2004-01-26 → 2004-04-06 (+71d) | 2004-03-26 → 2004-04-30 (+35d) | 44d → 19d |  | 76d → 56d | 250 → 250FS+11d | baseline start none → 2004-02-13; baseline finish none → 2004-04-15 |
| 252 | **STE - UCB** |  | 2004-04-09 → 2004-06-10 (+62d) | 153d → 196d | 55% → 70% | 87d → 49d |  | baseline start none → 2003-08-29; baseline finish none → 2004-05-10 |
| 253 | **Deliveries** | 2004-03-30 → 2004-04-16 (+17d) | 2004-04-09 → 2004-06-10 (+62d) | 8d → 38d |  | 31d → 22d |  | baseline start none → 2004-04-14; baseline finish none → 2004-05-10 |
| 254 | Deliver STE-D FM 1 (stays at UCB for SWEA/STE-D FM 1 I&T) | 2004-03-30 → 2004-04-16 (+17d) | 2004-03-30 → 2004-04-16 (+17d) |  |  | 31d → 22d |  | baseline start none → 2004-04-14; baseline finish none → 2004-04-14 |
| 255 | Deliver STE-D FM 2 (stays at UCB for SWEA/STE-D FM 2 I&T) | 2004-04-09 → 2004-06-10 (+62d) | 2004-04-09 → 2004-06-10 (+62d) |  |  | 69d → 31d |  | baseline start none → 2004-05-10; baseline finish none → 2004-05-10 |
| 256 | Deliver STE-U FM 1 (stays at UCB for BOOM Suite FM 1 I&T) | 2004-04-05 → 2004-04-22 (+17d) | 2004-04-05 → 2004-04-22 (+17d) |  |  | 30d → 21d |  | baseline start none → 2004-04-20; baseline finish none → 2004-04-20 |
| 257 | Deliver STE-U FM 2 (stays at UCB for BOOM Suite FM 2 I&T) | 2004-04-09 → 2004-06-10 (+62d) | 2004-04-09 → 2004-06-10 (+62d) |  |  | 87d → 49d |  | baseline start none → 2004-05-10; baseline finish none → 2004-05-10 |
| 258 | **STE-U/D Housing** |  | 2004-01-16 → 2004-02-09 A (+24d) | 38d → 53d | 71% → 100% | 99d → none |  | baseline start none → 2003-11-21; baseline finish none → 2004-02-09 |
| 259 | Fabricate STE FM 1 Box |  | 2004-01-16 → 2004-02-09 A (+24d) | 38d → 53d | 71% → 100% | 40d → none |  | baseline start none → 2003-11-21; baseline finish none → 2004-02-09 |
| 260 | Fabricate STE FM 2 Box |  | 2004-01-16 → 2004-02-09 A (+24d) | 38d → 53d | 71% → 100% | 99d → none |  | baseline start none → 2003-11-21; baseline finish none → 2004-02-09 |
| 261 | **STE-U/D Detector Boards** |  | 2004-04-09 → 2004-06-10 (+62d) | 153d → 196d | 51% → 61% | 87d → 49d |  | baseline start none → 2003-08-29; baseline finish none → 2004-05-10 |
| 262 | Coupon Test STE FM 1 & FM 2 Detector Printed Wiring Board |  |  |  |  |  |  | baseline start none → 2003-10-10; baseline finish none → 2003-11-04 |
| 263 | **FM 1** |  | 2004-04-05 → 2004-04-22 (+17d) | 149d → 162d | 47% → 64% | 30d → 21d |  | baseline start none → 2003-08-29; baseline finish none → 2004-04-20 |
| 264 | Fabrication STE FM 1 Detector Printed Wiring Board |  |  |  |  |  |  | baseline start none → 2003-08-29; baseline finish none → 2003-10-09 |
| 265 | Load STE FM 1 Detector Printed Wiring Board |  | 2004-01-16 → 2004-02-03 A (+18d) | 49d → 60d | 78% → 100% | 30d → none |  | baseline start none → 2003-11-05; baseline finish none → 2004-02-03 |
| 266 | Test STE FM 1 Detector Printed Wiring Board | 2004-01-20 → 2004-02-04 A (+15d) | 2004-02-02 → 2004-02-18 A (+16d) |  | 0% → 100% | 30d → none |  | baseline start none → 2004-02-04; baseline finish none → 2004-02-18 |
| 267 | **Integration & Test** | 2004-02-03 → 2004-02-19 A (+16d) | 2004-04-05 → 2004-04-22 (+17d) | 44d → 46d | 0% → 11% | 30d → 21d |  | baseline start none → 2004-02-19; baseline finish none → 2004-04-20 |
| 268 | Integrate & Test STE-U/D FM 1 Detectors W/ FM 1 Housings | 2004-02-03 → 2004-02-19 A (+16d) | 2004-03-02 → 2004-04-06 (+35d) | 20d → 34d | 0% → 21% | 30d → 21d |  | baseline start none → 2004-02-19; baseline finish none → 2004-03-17 |
| 269 | Calibrate STE-U/D FM 1 | 2004-03-03 → 2004-03-24 (+21d) | 2004-03-30 → 2004-04-16 (+17d) | 20d → 18d |  | 30d → 21d | 268 → 268FS-10d | baseline start none → 2004-03-18; baseline finish none → 2004-04-14 |
| 270 | STE-U FM 1 Thermal Vacuum/Balance/Bake Out | 2004-03-17 → 2004-04-05 (+19d) | 2004-04-05 → 2004-04-22 (+17d) |  |  | 30d → 21d |  | was named STE-U FM 1 Thermal Vacuum/Balance; baseline start none → 2004-04-01; baseline finish none → 2004-04-20 |
| 271 | **FM 2** |  | 2004-04-09 → 2004-06-10 (+62d) | 153d → 196d | 48% → 53% | 87d → 49d |  | baseline start none → 2003-08-29; baseline finish none → 2004-05-10 |
| 272 | Fabricate STE FM 2 Detector Printed Wiring Board |  |  |  |  |  |  | baseline start none → 2003-08-29; baseline finish none → 2003-10-09 |
| 273 | Load STE FM 2 Detector Printed Wiring Board |  | 2004-02-06 → 2004-03-12 (+35d) |  | 60% → 84% | 75d → 51d | 262 → 262, 266FF+17d | baseline start none → 2003-11-05; baseline finish none → 2004-03-17 |
| 274 | Test STE FM 2 Detector Printed Wiring Board | 2004-02-09 → 2004-03-15 (+35d) | 2004-02-23 → 2004-03-19 (+25d) | 10d → 5d |  | 75d → 51d |  | baseline start none → 2004-03-18; baseline finish none → 2004-03-31 |
| 275 | **Integration & Test** | 2004-03-03 → 2004-04-19 (+47d) | 2004-04-09 → 2004-06-10 (+62d) | 28d → 38d |  | 69d → 31d |  | baseline start none → 2004-04-01; baseline finish none → 2004-05-10 |
| 276 | Integrate & Test STE-U/D FM 2 Detectors W/ FM 2 Housings | 2004-03-03 → 2004-04-19 (+47d) | 2004-03-16 → 2004-05-14 (+59d) | 10d → 20d |  | 69d → 31d | 260, 274, 268 → 260, 274, 268FS-10d, 269 | baseline start none → 2004-04-01; baseline finish none → 2004-04-14 |
| 277 | Calibrate STE-U/D FM 2 | 2004-03-17 → 2004-05-03 (+47d) | 2004-04-09 → 2004-06-10 (+62d) | 18d → 28d |  | 69d → 31d | 276 → 276FS-10d | baseline start none → 2004-04-15; baseline finish none → 2004-05-10 |
| 278 | STE-U FM 2 Thermal Vacuum/Bake Out | 2004-03-29 → 2004-05-27 (+59d) | 2004-04-09 → 2004-06-10 (+62d) |  |  | 87d → 49d |  | was named STE-U FM 2 Thermal Vacuum; baseline start none → 2004-04-27; baseline finish none → 2004-05-10 |
| 279 | **STE and SWEA - UCB** |  | 2004-08-03 → 2004-09-07 (+35d) | 276d → 300d | 67% → 72% | 309d → 14d |  | baseline start none → 2003-07-01; baseline finish none → 2004-08-27 |
| 280 | **Deliveries** | 2004-02-06 → 2004-03-26 (+49d) | 2004-08-03 → 2004-09-07 (+35d) | 125d → 115d |  | 33d → 14d |  | baseline start none → 2004-02-27; baseline finish none → 2004-08-27 |
| 281 | Deliver STE-U FM 1 Interface (stays at UCB for IDPU FM 1 I&T) | 2004-02-06 → 2004-03-26 (+49d) | 2004-02-06 → 2004-03-26 (+49d) |  |  | 79d → 49d |  | baseline start none → 2004-02-27; baseline finish none → 2004-02-27 |
| 282 | Deliver STE-U FM 2 Interface (stays at UCB for IDPU FM 2 I&T) | 2004-02-20 → 2004-04-02 (+42d) | 2004-02-20 → 2004-04-02 (+42d) |  |  | 87d → 80d |  | baseline start none → 2004-03-01; baseline finish none → 2004-03-01 |
| 283 | Deliver SWEA/STE-D FM 1 (stays at UCB for Boom Suite FM 1 I&T) | 2004-05-17 → 2004-06-21 (+35d) | 2004-05-17 → 2004-06-21 (+35d) |  |  | 27d → 7d |  | baseline start none → 2004-06-11; baseline finish none → 2004-06-11 |
| 284 | Deliver SWEA/STE-D FM 2 (stays at UCB for Boom Suite FM 2 I&T) | 2004-08-03 → 2004-09-07 (+35d) | 2004-08-03 → 2004-09-07 (+35d) |  |  | 33d → 14d |  | baseline start none → 2004-08-27; baseline finish none → 2004-08-27 |
| 285 | **SWEA Pedestal** |  | 2004-01-16 → 2004-02-09 A (+24d) | 137d → 152d | 92% → 100% | 97d → none |  | baseline start none → 2003-07-01; baseline finish none → 2004-02-09 |

| ID | Task | Start | Finish | Duration | Complete | Total float | Predecessors | Other |
| --- | --- | --- | --- | --- | --- | --- | --- | --- |
| 286 | Fabricate SWEA FM 1 Baseplate |  | 2004-01-16 → 2004-02-09 A (+24d) | 137d → 152d | 92% → 100% | 51d → none |  | baseline start none → 2003-07-01; baseline finish none → 2004-02-09 |
| 287 | Fabricate SWEA FM 2 Baseplate |  | 2004-01-16 → 2004-02-09 A (+24d) | 137d → 152d | 92% → 100% | 97d → none |  | baseline start none → 2003-07-01; baseline finish none → 2004-02-09 |
| 288 | **STE-D Pre-Amp Board** |  | 2004-02-12 → 2004-03-15 (+32d) | 98d → 119d |  | 79d → 63d |  | baseline start none → 2003-09-22; baseline finish none → 2004-02-23 |
| 289 | **FM 1** |  | 2004-02-12 → 2004-03-15 (+32d) | 98d → 119d |  | 33d → 16d |  | baseline start none → 2003-09-22; baseline finish none → 2004-02-23 |
| 290 | Fabricate STE-D FM 1 Preamp Printed Wiring Board |  |  |  |  |  |  | baseline start none → 2003-09-22; baseline finish none → 2003-11-07 |
| 291 | Load STE-D FM 1 Preamp Printed Wiring Board | 2004-02-06 → 2004-03-09 (+32d) | 2004-02-12 → 2004-03-15 (+32d) |  |  | 33d → 16d |  | constraint start no earlier than 2004-02-06 → start no earlier than 2004-03-09; baseline start none → 2004-02-17; baseline finish none → 2004-02-23 |
| 292 | **FM 2** |  | 2004-02-12 → 2004-03-15 (+32d) | 98d → 119d |  | 79d → 63d |  | baseline start none → 2003-09-22; baseline finish none → 2004-02-23 |
| 293 | Fabricate STE-D FM 2 Preamp Printed Wiring Board |  |  |  |  |  |  | baseline start none → 2003-09-22; baseline finish none → 2003-11-07 |
| 294 | Load STE-D FM 2 Preamp Printed Wiring Board | 2004-02-06 → 2004-03-09 (+32d) | 2004-02-12 → 2004-03-15 (+32d) |  |  | 79d → 63d |  | baseline start none → 2004-02-17; baseline finish none → 2004-02-23 |
| 295 | Coupon Test STE-D FM 1 & FM 2 Pre-Amp Printed Wiring Boards |  |  |  |  |  |  | baseline start none → 2003-11-10; baseline finish none → 2003-12-02 |
| 296 | **STE-D Shaper Board** |  | 2004-04-19 → 2004-05-21 (+32d) | 94d → 118d | 64% → 78% | 33d → 14d |  | baseline start none → 2003-12-04; baseline finish none → 2004-05-13 |
| 297 | **FM 1** |  | 2004-02-06 → 2004-03-11 (+34d) | 44d → 67d |  | 37d → 18d |  | baseline start none → 2003-12-04; baseline finish none → 2004-02-20 |
| 298 | Fabricate STE-D FM 1 Shaper Printed Wiring Board |  |  |  |  |  |  | baseline start none → 2003-12-04; baseline finish none → 2003-12-17 |
| 299 | Load STE-D FM 1 Shaper Printed Wiring Board | 2004-02-02 → 2004-03-05 (+32d) | 2004-02-06 → 2004-03-11 (+34d) |  |  | 37d → 18d |  | constraint start no earlier than 2004-02-02 → start no earlier than 2004-03-05; baseline start none → 2004-02-13; baseline finish none → 2004-02-20 |
| 300 | **FM 2** |  | 2004-04-19 → 2004-05-21 (+32d) | 94d → 118d |  | 33d → 14d |  | baseline start none → 2003-12-04; baseline finish none → 2004-05-13 |
| 301 | Fabricate STE-D FM 2 Shaper Printed Wiring Board |  |  |  |  |  |  | baseline start none → 2003-12-04; baseline finish none → 2003-12-17 |
| 302 | Load STE-D FM 2 Shaper Printed Wiring Board | 2004-04-13 → 2004-05-17 (+34d) | 2004-04-19 → 2004-05-21 (+32d) |  |  | 33d → 14d |  | baseline start none → 2004-05-07; baseline finish none → 2004-05-13 |
| 303 | Coupon Test STE-D FM 1 & FM 2 Shaper Printed Wiring Boards |  | 2004-01-09 A |  | 60% → 100% | 51d → none |  | baseline start none → 2003-12-18; baseline finish none → 2004-01-09 |
| 304 | **STE-D Interface Board** |  | 2004-04-19 → 2004-05-21 (+32d) | 94d → 118d | 64% → 78% | 384d → 14d |  | baseline start none → 2003-12-04; baseline finish none → 2004-05-13 |
| 305 | **FM 1** |  | 2004-02-06 → 2004-03-11 (+34d) | 44d → 67d |  | 37d → 18d |  | baseline start none → 2003-12-04; baseline finish none → 2004-02-20 |
| 306 | Fabricate SWEA / STE-D FM 1 Digital to Analog Converter Printed Wiring Board |  |  |  |  |  |  | baseline start none → 2003-12-04; baseline finish none → 2003-12-17 |
| 307 | Load SWEA / STE-D FM 1 Digital to Analog Converter Printed Wiring Board | 2004-02-02 → 2004-03-05 (+32d) | 2004-02-06 → 2004-03-11 (+34d) |  |  | 37d → 18d |  | baseline start none → 2004-02-13; baseline finish none → 2004-02-20 |
| 308 | **FM 2** |  | 2004-04-19 → 2004-05-21 (+32d) | 94d → 118d |  | 33d → 14d |  | baseline start none → 2003-12-04; baseline finish none → 2004-05-13 |
| 309 | Fabricate SWEA / STE-D FM 2 Digital to Analog Converter Printed Wiring Board |  |  |  |  |  |  | baseline start none → 2003-12-04; baseline finish none → 2003-12-17 |
| 310 | Load SWEA / STE-D FM 2 Digital to Analog Converter Printed Wiring Board | 2004-04-13 → 2004-05-17 (+34d) | 2004-04-19 → 2004-05-21 (+32d) |  |  | 33d → 14d |  | baseline start none → 2004-05-07; baseline finish none → 2004-05-13 |
| 311 | Coupon Test STE-D FM 1 & FM 2 D/A Converter Printed Wiring Boards |  | 2004-01-09 A |  | 60% → 100% | 453d → none |  | baseline start none → 2003-12-18; baseline finish none → 2004-01-09 |
| 312 | **STE-U Pre-Amp Board** |  | 2004-02-12 → 2004-03-15 (+32d) | 98d → 119d |  | 87d → 89d |  | baseline start none → 2003-09-22; baseline finish none → 2004-02-23 |
| 313 | **FM 1** |  |  |  |  |  |  | baseline start none → 2003-09-22; baseline finish none → 2004-01-15 |
| 314 | Fabricate STE-U FM 1 Preamp Printed Wiring Board |  |  |  |  |  |  | baseline start none → 2003-09-22; baseline finish none → 2003-11-07 |
| 315 | Load STE-U FM 1 Preamp Printed Wiring Board |  |  |  |  |  |  | baseline start none → 2004-01-12; baseline finish none → 2004-01-15 |
| 316 | **FM 2** |  | 2004-02-12 → 2004-03-15 (+32d) | 98d → 119d |  | 87d → 89d |  | baseline start none → 2003-09-22; baseline finish none → 2004-02-23 |
| 317 | Fabricate STE-U FM 2 Preamp Printed Wiring Board |  |  |  |  |  |  | baseline start none → 2003-09-22; baseline finish none → 2003-11-07 |
| 318 | Load STE-U FM 2 Preamp Printed Wiring Board | 2004-02-06 → 2004-03-09 (+32d) | 2004-02-12 → 2004-03-15 (+32d) |  |  | 87d → 89d |  | constraint start no earlier than 2004-02-06 → start no earlier than 2004-03-09; baseline start none → 2004-02-17; baseline finish none → 2004-02-23 |
| 319 | Coupon Test STE-U FM 1 & FM 2 Pre-Amp Printed Wiring Boards |  |  |  |  |  |  | baseline start none → 2003-11-10; baseline finish none → 2003-12-02 |
| 320 | **STE-U Shaper & Interface Board** |  | 2004-01-30 → 2004-03-26 (+56d) | 39d → 78d | 64% → 66% | 96d → 80d |  | baseline start none → 2003-12-04; baseline finish none → 2004-02-20 |
| 321 | **FM 1** |  | 2004-01-30 → 2004-03-19 (+49d) | 39d → 73d | 67% → 43% | 79d → 49d |  | baseline start none → 2003-12-04; baseline finish none → 2004-02-20 |
| 322 | Fabricate STE-U FM 1Shaper & Interface Printed Wiring Board |  |  |  |  |  |  | baseline start none → 2003-12-04; baseline finish none → 2003-12-17 |
| 323 | Load STE-U FM 1 Shaper & Interface Printed Wiring Board | 2004-01-26 → 2004-03-03 (+37d) | 2004-01-30 → 2004-03-19 (+49d) | 5d → 13d |  | 79d → 49d |  | constraint start no earlier than 2004-01-26 → start no earlier than 2004-03-03; baseline start none → 2004-02-13; baseline finish none → 2004-02-20 |
| 324 | **FM 2** |  | 2004-01-30 → 2004-03-26 (+56d) | 39d → 78d |  | 96d → 80d |  | baseline start none → 2003-12-04; baseline finish none → 2004-02-20 |
| 325 | Fabricate STE-U FM 2 Shaper & Interface Printed Wiring Board |  |  |  |  |  |  | baseline start none → 2003-12-04; baseline finish none → 2003-12-17 |
| 326 | Load STE-U FM 2 Shaper & Interface Printed Wiring Board | 2004-01-26 → 2004-03-22 (+56d) | 2004-01-30 → 2004-03-26 (+56d) |  |  | 96d → 80d | 323SS → 323 | baseline start none → 2004-02-13; baseline finish none → 2004-02-20 |
| 327 | Coupon Test STE-U FM 1 & FM 2 Shaper & Interface Printed Wiring Boards |  | 2004-01-09 A |  | 60% → 100% | 88d → none |  | baseline start none → 2003-12-18; baseline finish none → 2004-01-09 |
| 328 | **Integration & Test** | 2004-02-02 → 2004-03-16 (+43d) | 2004-08-03 → 2004-09-07 (+35d) | 130d → 124d |  | 33d → 14d |  | baseline start none → 2004-02-23; baseline finish none → 2004-08-27 |
| 329 | **FM 1** | 2004-02-02 → 2004-03-16 (+43d) | 2004-07-23 → 2004-09-07 (+46d) | 123d → 124d |  | 37d → 11d |  | baseline start none → 2004-02-23; baseline finish none → 2004-07-30 |
| 330 | Integrate & Test STE-U FM 1 Interface Boards | 2004-02-02 → 2004-03-22 (+49d) | 2004-02-06 → 2004-03-26 (+49d) |  |  | 79d → 49d |  | baseline start none → 2004-02-23; baseline finish none → 2004-02-27 |
| 331 | Integrate & Test SWEA/STE-D FM 1 Interface Boards | 2004-02-13 → 2004-03-16 (+32d) | 2004-03-12 → 2004-04-12 (+31d) |  |  | 33d → 16d |  | baseline start none → 2004-02-24; baseline finish none → 2004-03-22 |
| 332 | Integrate & Test SWEA/STE-D FM 1 Interface with SWEA/STE-D FM 1 LVPS | 2004-03-23 → 2004-04-26 (+34d) | 2004-04-05 → 2004-05-07 (+32d) |  |  | 27d → 7d |  | baseline start none → 2004-04-16; baseline finish none → 2004-04-29 |
| 333 | Clean/Coat/Stake SWEA/STE-D Interface | 2004-03-15 → 2004-04-13 (+29d) | 2004-03-26 → 2004-04-26 (+31d) |  |  | 33d → 16d |  | baseline start none → 2004-03-23; baseline finish none → 2004-04-05 |
| 334 | Integrate & Test SWEA/STE-D FM 1 Combined | 2004-04-06 → 2004-05-10 (+34d) | 2004-04-12 → 2004-05-14 (+32d) |  |  | 27d → 7d |  | baseline start none → 2004-04-30; baseline finish none → 2004-05-06 |
| 335 | Calibrate SWEA/STE FM 1 | 2004-04-13 → 2004-05-17 (+34d) | 2004-05-10 → 2004-06-14 (+35d) |  |  | 27d → 7d |  | baseline start none → 2004-05-07; baseline finish none → 2004-06-04 |
| 336 | SWEA/STE FM 1 Vibration | 2004-05-11 → 2004-06-15 (+35d) | 2004-05-17 → 2004-06-21 (+35d) |  |  | 27d → 7d |  | baseline start none → 2004-06-07; baseline finish none → 2004-06-11 |
| 337 | SWEA/STE-D FM 1 Thermal Vac/Thermal Balance/Bake Out | 2004-07-06 → 2004-08-18 (+43d) | 2004-07-23 → 2004-09-07 (+46d) |  |  | 37d → 11d |  | was named SWEA/STE-D FM 1 Thermal Vac/Thermal Balance; baseline start none → 2004-07-13; baseline finish none → 2004-07-30 |
| 338 | **FM 2** | 2004-02-13 → 2004-03-29 (+45d) | 2004-08-03 → 2004-09-07 (+35d) | 121d → 115d |  | 33d → 14d |  | baseline start none → 2004-02-24; baseline finish none → 2004-08-27 |
| 339 | Integrate & Test STE-U FM 2 Interface Boards | 2004-02-13 → 2004-03-29 (+45d) | 2004-02-20 → 2004-04-02 (+42d) |  |  | 87d → 80d |  | baseline start none → 2004-02-24; baseline finish none → 2004-03-01 |
| 340 | Integrate & Test SWEA/STE-D FM 2 Interface Boards | 2004-04-20 → 2004-05-24 (+34d) | 2004-05-17 → 2004-06-21 (+35d) |  |  | 33d → 14d |  | baseline start none → 2004-05-14; baseline finish none → 2004-06-11 |
| 341 | Integrate & Test SWEA/STE-D FM 2 Interface with SWEA/STE-D FM 2 LVPS | 2004-05-18 → 2004-06-22 (+35d) | 2004-06-01 → 2004-07-05 (+34d) |  |  | 33d → 14d |  | baseline start none → 2004-06-14; baseline finish none → 2004-06-25 |
| 342 | Integrate & Test SWEA/STE-D FM 2 Combined | 2004-06-02 → 2004-07-06 (+34d) | 2004-06-15 → 2004-07-19 (+34d) |  |  | 33d → 14d |  | baseline start none → 2004-06-28; baseline finish none → 2004-07-09 |
| 343 | Calibrate SWEA/STE FM 2 | 2004-06-16 → 2004-07-20 (+34d) | 2004-07-13 → 2004-08-16 (+34d) |  |  | 33d → 14d |  | baseline start none → 2004-07-12; baseline finish none → 2004-08-06 |
| 344 | SWEA/STE FM 2 Vibration | 2004-07-14 → 2004-08-17 (+34d) | 2004-07-20 → 2004-08-23 (+34d) |  |  | 33d → 14d |  | baseline start none → 2004-08-09; baseline finish none → 2004-08-13 |
| 345 | SWEA/STE-D FM 2 Thermal Vac & bake Out | 2004-07-21 → 2004-08-24 (+34d) | 2004-08-03 → 2004-09-07 (+35d) |  |  | 33d → 14d |  | was named SWEA/STE-D FM 2 Thermal Vac; baseline start none → 2004-08-16; baseline finish none → 2004-08-27 |
| 346 | **Boom Suite I&T - UCB** | 2004-04-09 → 2004-04-26 (+17d) | 2004-09-09 → 2004-10-06 (+27d) | 108d → 116d |  | 27d → 14d |  | baseline start none → 2004-04-21; baseline finish none → 2004-09-28 |
| 347 | **FM 1** | 2004-04-09 → 2004-04-26 (+17d) | 2004-08-13 → 2004-09-21 (+39d) | 90d → 105d |  | 27d → 11d |  | baseline start none → 2004-04-21; baseline finish none → 2004-08-13 |
| 348 | FM 1 Boom/MAG/STE-U I&T | 2004-04-09 → 2004-04-26 (+17d) | 2004-04-14 → 2004-04-29 (+15d) |  |  | 27d → 20d |  | baseline start none → 2004-04-21; baseline finish none → 2004-04-26 |
| 349 | FM 1 Boom/SWEA/STE/MAG I&T | 2004-05-18 → 2004-06-22 (+35d) | 2004-05-19 → 2004-06-23 (+35d) |  |  | 27d → 7d |  | baseline start none → 2004-06-14; baseline finish none → 2004-06-15 |
| 350 | FM 1 Integrated Boom/IDPU I&T | 2004-05-20 → 2004-06-24 (+35d) | 2004-05-25 → 2004-06-29 (+35d) |  |  | 27d → 7d |  | baseline start none → 2004-06-16; baseline finish none → 2004-06-21 |
| 351 | Final BOOM Suite FM 1 I & T | 2004-08-02 → 2004-09-08 (+37d) | 2004-08-13 → 2004-09-21 (+39d) |  |  | 37d → 11d | BOOM Suite FM 1 Bakeout, IDPU FM 1 Bakeout → 350, 337 | baseline start none → 2004-08-02; baseline finish none → 2004-08-13 |
| 352 | **FM 2** | 2004-04-12 → 2004-06-11 (+60d) | 2004-09-09 → 2004-10-06 (+27d) | 107d → 83d |  | 33d → 14d |  | baseline start none → 2004-05-11; baseline finish none → 2004-09-28 |
| 353 | FM 2 Boom/MAG/STE-U I&T | 2004-04-12 → 2004-06-11 (+60d) | 2004-04-15 → 2004-06-16 (+62d) |  |  | 87d → 49d |  | baseline start none → 2004-05-11; baseline finish none → 2004-05-14 |
| 354 | FM 2 Boom/SWEA/STE/MAG I&T | 2004-08-04 → 2004-09-08 (+35d) | 2004-08-05 → 2004-09-09 (+35d) |  |  | 33d → 14d |  | baseline start none → 2004-08-30; baseline finish none → 2004-08-31 |
| 355 | FM 2 Integrated Boom/IDPU I&T | 2004-08-06 → 2004-09-10 (+35d) | 2004-08-11 → 2004-09-15 (+35d) |  |  | 33d → 14d |  | baseline start none → 2004-09-01; baseline finish none → 2004-09-07 |

| ID | Task | Start | Finish | Duration | Complete | Total float | Predecessors | Other |
| --- | --- | --- | --- | --- | --- | --- | --- | --- |
| 356 | Boom Suite FM 2 EMC | 2004-08-12 → 2004-09-16 (+35d) | 2004-08-18 → 2004-09-22 (+35d) |  |  | 33d → 14d |  | baseline start none → 2004-09-08; baseline finish none → 2004-09-14 |
| 357 | Final BOOM Suite FM 2 I & T | 2004-08-26 → 2004-09-23 (+28d) | 2004-09-09 → 2004-10-06 (+27d) |  |  | 33d → 14d | BOOM Suite FM 2 Bakeout, IDPU FM 2 Bakeout → 356 | baseline start none → 2004-09-15; baseline finish none → 2004-09-28 |
| 358 | **SEP Suite - CIT** |  | 2004-10-20 → 2004-10-26 (+6d) | 351d → 355d | 29% → 56% | 255d → 277d |  | baseline start none → 2003-06-02; baseline finish none → 2004-10-21 |
| 359 | **SEP Mechanical - Sandy Shuman (GSFC)** | 2004-01-22 → 2004-01-27 A (+5d) | 2004-06-02 → 2004-07-07 (+35d) | 93d → 115d | 0% → 27% | 19d → 26d |  | baseline start none → 2004-01-27; baseline finish none → 2004-06-02 |
| 360 | **SIT Electronics Enclosure (Priority 1)** | 2004-01-22 → 2004-02-09 A (+18d) | 2004-02-20 → 2004-04-30 (+70d) | 21d → 59d | 0% → 37% | 22d → 28d |  | baseline start none → 2004-02-09; baseline finish none → 2004-03-16 |
| 361 | Complete Design/Drawings for SIT Enclosure | 2004-01-22 → 2004-02-09 A (+18d) | 2004-01-28 → 2004-02-23 A (+26d) | 5d → 10d | 0% → 100% | 22d → none |  | constraint start no earlier than 2004-01-22 → start no earlier than 2004-02-09; baseline start none → 2004-02-09; baseline finish none → 2004-02-23 |
| 362 | Fabrication of SIT Enclosure | 2004-01-29 → 2004-04-08 (+70d) | 2004-02-11 → 2004-04-21 (+70d) |  |  | 33d → 28d | 361 → 361FS+32d | baseline start none → 2004-02-24; baseline finish none → 2004-03-08 |
| 363 | Inspection and Final Assembly of SIT Enclosure | 2004-02-12 → 2004-04-22 (+70d) | 2004-02-19 → 2004-04-29 (+70d) | 5d → 6d |  | 33d → 28d |  | baseline start none → 2004-03-09; baseline finish none → 2004-03-15 |
| 364 | Deliver SIT Enclosure to UMD | 2004-02-20 → 2004-04-30 (+70d) | 2004-02-20 → 2004-04-30 (+70d) |  |  | 33d → 28d |  | baseline start none → 2004-03-16; baseline finish none → 2004-03-16 |
| 365 | **SEP FM 1 & FM 2 LVPS Boxes (Priority 2)** | 2004-01-29 → 2004-02-09 A (+11d) | 2004-03-02 → 2004-04-28 (+57d) | 23d → 57d | 0% → 75% | 22d → 13d |  | baseline start none → 2004-02-09; baseline finish none → 2004-03-11 |
| 366 | Complete Design/Drawings for SEP LVPS Boxes | 2004-01-29 → 2004-02-09 A (+11d) | 2004-02-04 → 2004-02-13 A (+9d) |  | 0% → 100% | 22d → none | 361 → 361SS | baseline start none → 2004-02-09; baseline finish none → 2004-02-13 |
| 367 | Fabrication of SEP LVPS Boxes | 2004-02-05 → 2004-02-17 A (+12d) | 2004-02-19 → 2004-04-05 A (+46d) | 10d → 35d | 0% → 100% | 50d → none |  | baseline start none → 2004-02-17; baseline finish none → 2004-03-01 |
| 368 | Inspection and Final Assembly of SEP LVPS Boxes | 2004-02-20 → 2004-04-12 (+52d) | 2004-02-26 → 2004-04-23 (+57d) | 5d → 10d |  | 50d → 13d | 367 → 367FS+4d | baseline start none → 2004-03-02; baseline finish none → 2004-03-08 |
| 369 | Deliver SEP LVPS Boxes to UCB | 2004-02-27 → 2004-04-26 (+59d) | 2004-03-02 → 2004-04-28 (+57d) |  |  | 50d → 13d |  | constraint none → start no earlier than 2004-04-07; baseline start none → 2004-03-09; baseline finish none → 2004-03-11 |
| 370 | **SEP Electronics Enclosure (Priority 3)** | 2004-02-05 → 2004-02-17 A (+12d) | 2004-03-19 → 2004-05-21 (+63d) | 31d → 69d | 0% → 46% | 22d → 24d |  | baseline start none → 2004-02-17; baseline finish none → 2004-03-30 |
| 371 | Complete Design/Drawings for SEP Enclosure | 2004-02-05 → 2004-02-17 A (+12d) | 2004-02-24 → 2004-04-19 (+55d) | 13d → 45d | 0% → 71% | 22d → -10d |  | baseline start none → 2004-02-17; baseline finish none → 2004-03-04 |
| 372 | Fabrication of SEP Enclosure | 2004-02-25 → 2004-04-20 (+55d) | 2004-03-09 → 2004-05-10 (+62d) | 10d → 15d |  | 65d → 24d |  | baseline start none → 2004-03-05; baseline finish none → 2004-03-18 |
| 373 | Inspection and Final Assembly of SEP Enclosure | 2004-03-10 → 2004-05-11 (+62d) | 2004-03-16 → 2004-05-18 (+63d) | 5d → 6d |  | 65d → 24d |  | baseline start none → 2004-03-19; baseline finish none → 2004-03-25 |
| 374 | Deliver SEP Enclosure to CIT | 2004-03-17 → 2004-05-19 (+63d) | 2004-03-19 → 2004-05-21 (+63d) |  |  | 65d → 24d |  | baseline start none → 2004-03-26; baseline finish none → 2004-03-30 |
| 375 | **SEP Central Bias Supply Shields (Priority 4)** | 2004-02-25 → 2004-04-15 (+50d) | 2004-03-23 → 2004-05-12 (+50d) |  |  | 22d → -10d |  | baseline start none → 2004-03-05; baseline finish none → 2004-04-01 |
| 376 | Complete Design/Drawings for Bias Supply Shields | 2004-02-25 → 2004-04-15 (+50d) | 2004-03-02 → 2004-04-21 (+50d) |  |  | 22d → -10d | 371 → 371FS-3d | baseline start none → 2004-03-05; baseline finish none → 2004-03-11 |
| 377 | Fabrication of Bias Supply Shields | 2004-03-03 → 2004-04-22 (+50d) | 2004-03-16 → 2004-05-05 (+50d) |  |  | 22d → -10d |  | baseline start none → 2004-03-12; baseline finish none → 2004-03-25 |
| 378 | Inspection and Delivery (to CIT) of Bias Supply Shields | 2004-03-17 → 2004-05-06 (+50d) | 2004-03-23 → 2004-05-12 (+50d) |  |  | 22d → -10d |  | baseline start none → 2004-03-26; baseline finish none → 2004-04-01 |
| 379 | **LET Telescope (Priority 5)** | 2004-03-03 → 2004-04-22 (+50d) | 2004-04-07 → 2004-06-02 (+56d) | 26d → 29d |  | 25d → 0d |  | baseline start none → 2004-03-12; baseline finish none → 2004-04-16 |
| 380 | Complete Design/Drawings for LET Telescope | 2004-03-03 → 2004-04-22 (+50d) | 2004-03-12 → 2004-05-03 (+52d) |  |  | 25d → 0d |  | baseline start none → 2004-03-12; baseline finish none → 2004-03-23 |
| 381 | Fabrication of LET Telescope | 2004-03-15 → 2004-05-04 (+50d) | 2004-03-26 → 2004-05-17 (+52d) |  |  | 38d → 3d |  | baseline start none → 2004-03-24; baseline finish none → 2004-04-06 |
| 382 | Inspection and Final Assembly of LET Telescope (CIT has detectors) | 2004-03-29 → 2004-05-18 (+50d) | 2004-04-02 → 2004-05-27 (+55d) | 5d → 8d |  | 38d → 3d |  | was named Inspection and Final Assembly of LET Telescope; baseline start none → 2004-04-07; baseline finish none → 2004-04-13 |
| 383 | Deliver LET Telescope to CIT | 2004-04-05 → 2004-05-28 (+53d) | 2004-04-07 → 2004-06-02 (+56d) |  |  | 38d → 3d |  | baseline start none → 2004-04-14; baseline finish none → 2004-04-16 |
| 384 | **HET Electronics Enclosure (Priority 6)** | 2004-03-15 → 2004-03-22 A (+7d) | 2004-04-14 → 2004-05-25 (+41d) | 23d → 47d | 0% → 21% | 25d → -3d |  | baseline start none → 2004-03-24; baseline finish none → 2004-04-23 |
| 385 | Complete Design/Drawings for HET Enclosure | 2004-03-15 → 2004-03-22 A (+7d) | 2004-03-24 → 2004-05-04 (+41d) | 8d → 23d | 0% → 35% | 25d → 0d | 380 → 380FS-14d | baseline start none → 2004-03-24; baseline finish none → 2004-04-02 |
| 386 | Fabrication of HET Enclosure | 2004-03-25 → 2004-05-05 (+41d) | 2004-04-07 → 2004-05-18 (+41d) |  |  | 25d → -3d |  | baseline start none → 2004-04-05; baseline finish none → 2004-04-16 |
| 387 | Inspection and Final Assembly of HET Enclosure | 2004-04-08 → 2004-05-19 (+41d) | 2004-04-14 → 2004-05-25 (+41d) |  |  | 25d → -3d |  | baseline start none → 2004-04-19; baseline finish none → 2004-04-23 |
| 388 | Deliver HET Enclosure (stays at GSFC) | 2004-04-14 → 2004-05-25 (+41d) | 2004-04-14 → 2004-05-25 (+41d) |  |  | 25d → -3d |  | baseline start none → 2004-04-23; baseline finish none → 2004-04-23 |
| 389 | **HET Telescope (Priority 7)** | 2004-01-27 A | 2004-04-21 → 2004-06-04 (+44d) | 61d → 92d | 0% → 32% | 16d → -3d |  | baseline start none → 2004-01-27; baseline finish none → 2004-04-30 |
| 390 | On Going work for HET Telescope (Complete Design/Drawings & Prep for Fab) | 2004-01-27 A | 2004-03-31 → 2004-04-14 (+14d) | 46d → 56d | 0% → 41% | 16d → 1d |  | baseline start none → 2004-01-27; baseline finish none → 2004-03-31 |
| 391 | Fabrication of HET Telescope | 2004-04-01 → 2004-04-15 (+14d) | 2004-04-14 → 2004-04-28 (+14d) |  |  | 25d → 16d |  | baseline start none → 2004-04-01; baseline finish none → 2004-04-14 |
| 392 | Inspection and Final Assembly of HET Telescope | 2004-04-15 → 2004-05-26 (+41d) | 2004-04-21 → 2004-06-04 (+44d) | 5d → 7d |  | 25d → -3d |  | baseline start none → 2004-04-26; baseline finish none → 2004-04-30 |
| 393 | Deliver HET Telescope (stays at GSFC) | 2004-04-21 → 2004-06-04 (+44d) | 2004-04-21 → 2004-06-04 (+44d) |  |  | 25d → -3d |  | baseline start none → 2004-04-30; baseline finish none → 2004-04-30 |
| 394 | **SIT Telescope (Priority 8)** | 2004-04-01 → 2004-04-15 (+14d) | 2004-05-18 → 2004-06-09 (+22d) | 34d → 39d |  | 16d → 1d |  | baseline start none → 2004-04-01; baseline finish none → 2004-05-18 |
| 395 | Complete Design/Drawings for SIT Telescope | 2004-04-01 → 2004-04-15 (+14d) | 2004-04-26 → 2004-05-10 (+14d) |  |  | 16d → 1d |  | baseline start none → 2004-04-01; baseline finish none → 2004-04-26 |
| 396 | Fabrication of SIT Telescope | 2004-04-27 → 2004-05-11 (+14d) | 2004-05-10 → 2004-05-24 (+14d) |  |  | 16d → 1d |  | baseline start none → 2004-04-27; baseline finish none → 2004-05-10 |
| 397 | Inspection and Final Assembly of SIT Telescope | 2004-05-11 → 2004-05-25 (+14d) | 2004-05-17 → 2004-06-08 (+22d) | 5d → 10d |  | 16d → 1d |  | baseline start none → 2004-05-11; baseline finish none → 2004-05-17 |
| 398 | Deliver SIT Telescope to UMD (Includes the Foils and Detectors) | 2004-05-18 → 2004-06-09 (+22d) | 2004-05-18 → 2004-06-09 (+22d) |  |  | 16d → 1d |  | was named Deliver SIT Telescope to UMD; baseline start none → 2004-05-18; baseline finish none → 2004-05-18 |
| 399 | **Shipping Containers for HET, SIT & SEP Central (Priority 9)** | 2004-04-27 → 2004-05-11 (+14d) | 2004-05-27 → 2004-06-11 (+15d) |  |  | 23d → 3d |  | baseline start none → 2004-04-27; baseline finish none → 2004-05-27 |
| 400 | Design | 2004-04-27 → 2004-05-11 (+14d) | 2004-05-03 → 2004-05-17 (+14d) |  |  | 23d → 3d |  | baseline start none → 2004-04-27; baseline finish none → 2004-05-03 |
| 401 | Fabrication/Machining | 2004-05-04 → 2004-05-18 (+14d) | 2004-05-17 → 2004-06-01 (+15d) |  |  | 23d → 17d |  | baseline start none → 2004-05-04; baseline finish none → 2004-05-17 |
| 402 | Inspection and Assembly | 2004-05-18 → 2004-06-02 (+15d) | 2004-05-24 → 2004-06-08 (+15d) |  |  | 23d → 17d |  | baseline start none → 2004-05-18; baseline finish none → 2004-05-24 |
| 403 | HET Container stays at GSFC | 2004-05-24 → 2004-06-08 (+15d) | 2004-05-24 → 2004-06-08 (+15d) |  |  | 23d → 17d |  | baseline start none → 2004-05-24; baseline finish none → 2004-05-24 |
| 404 | SIT Container to UMD | 2004-05-25 → 2004-06-09 (+15d) | 2004-05-25 → 2004-06-09 (+15d) |  |  | 25d → 19d |  | baseline start none → 2004-05-25; baseline finish none → 2004-05-25 |
| 405 | SEP Central Container to CIT | 2004-05-25 → 2004-06-09 (+15d) | 2004-05-27 → 2004-06-11 (+15d) |  |  | 40d → 34d |  | baseline start none → 2004-05-25; baseline finish none → 2004-05-27 |
| 412 | **LET Radiation Test Fixture (Priority 11)** | 2004-05-04 → 2004-06-02 (+29d) | 2004-06-02 → 2004-07-07 (+35d) | 21d → 26d |  | 24d → 3d |  | was named LET Radiation Test Fixture (Priority 10); baseline start none → 2004-05-04; baseline finish none → 2004-06-02 |
| 413 | Design | 2004-05-04 → 2004-06-02 (+29d) | 2004-05-10 → 2004-06-08 (+29d) |  |  | 24d → 3d | 400 → 407 | baseline start none → 2004-05-04; baseline finish none → 2004-05-10 |
| 414 | Fabrication | 2004-05-11 → 2004-06-09 (+29d) | 2004-05-24 → 2004-06-22 (+29d) |  |  | 24d → 3d |  | baseline start none → 2004-05-11; baseline finish none → 2004-05-24 |
| 415 | Inspection and Assembly | 2004-05-25 → 2004-06-23 (+29d) | 2004-06-01 → 2004-07-06 (+35d) | 5d → 10d |  | 24d → 3d |  | baseline start none → 2004-05-25; baseline finish none → 2004-06-01 |
| 416 | Deliver to CIT for SEP I&T | 2004-06-02 → 2004-07-07 (+35d) | 2004-06-02 → 2004-07-07 (+35d) |  |  | 24d → 3d |  | baseline start none → 2004-06-02; baseline finish none → 2004-06-02 |
| 417 | **SEP Central - CIT** |  | 2004-06-03 → 2004-06-21 (+18d) | 211d → 223d | 27% → 56% | 26d → 37d |  | baseline start none → 2003-08-01; baseline finish none → 2004-06-03 |
| 418 | **Deliveries** |  | 2004-06-03 → 2004-06-21 (+18d) | 35d → 47d |  | 26d → 37d |  | baseline start none → 2004-04-14; baseline finish none → 2004-06-03 |
| 419 | Deliver all SEP Cen FM 1 Boards to SEP I&T (stays at CIT) | 2004-04-29 → 2004-06-21 (+53d) | 2004-04-29 → 2004-06-21 (+53d) |  |  | 36d → 4d |  | baseline start none → 2004-05-10; baseline finish none → 2004-05-10 |
| 420 | Deliver all SEP Cen FM 2 Boards & FM 2 LVPS to SEP I&T (stays at CIT) | 2004-04-29 → 2004-06-21 (+53d) | 2004-04-29 → 2004-06-21 (+53d) |  |  | 50d → 37d |  | baseline start none → 2004-05-10; baseline finish none → 2004-05-10 |
| 421 | SEP Central Build 3 Software Complete |  |  |  |  | 47d → 51d |  | baseline start none → 2004-04-14; baseline finish none → 2004-04-14 |
| 422 | Final SEP Central Flight Software Complete |  |  |  |  | 26d → 30d |  | baseline start none → 2004-06-03; baseline finish none → 2004-06-03 |
| 423 | **Logic Board** | 2004-02-13 A |  |  | 0% → 33% | 29d → 33d |  | baseline start none → 2004-02-13; baseline finish none → 2004-03-26 |
| 424 | **Assembly** | 2004-02-13 A | 2004-02-27 A |  | 0% → 100% | 29d → none |  | baseline start none → 2004-02-13; baseline finish none → 2004-02-27 |
| 425 | Assemble FM 1 SEP Central Logic board | 2004-02-13 A | 2004-02-27 A |  | 0% → 100% | 29d → none |  | baseline start none → 2004-02-13; baseline finish none → 2004-02-27 |
| 426 | Assemble FM 2 SEP Central Logic board | 2004-02-13 A | 2004-02-27 A |  | 0% → 100% | 29d → none |  | baseline start none → 2004-02-13; baseline finish none → 2004-02-27 |
| 427 | **Test** |  |  |  |  | 29d → 33d |  | baseline start none → 2004-03-01; baseline finish none → 2004-03-26 |
| 428 | Test FM 1 SEP Central Logic board (initial) |  |  |  |  | 29d → 33d |  | baseline start none → 2004-03-01; baseline finish none → 2004-03-26 |
| 429 | Test FM 2 SEP Central Logic board (initial) |  |  |  |  | 29d → 33d |  | baseline start none → 2004-03-01; baseline finish none → 2004-03-26 |
| 430 | **Analog/Post-Reg Board** |  |  |  |  |  |  | baseline start none → 2004-01-27; baseline finish none → 2004-01-27 |
| 431 | FM 1 Analog/Post-Reg Board Complete Test and awaiting Conformal Coat with other SEP Central Boards |  |  |  |  |  |  | baseline start none → 2004-01-27; baseline finish none → 2004-01-27 |

| ID | Task | Start | Finish | Duration | Complete | Total float | Predecessors | Other |
| --- | --- | --- | --- | --- | --- | --- | --- | --- |
| 432 | FM 2 Analog/Post-Reg Board Complete Test and awaiting Conformal Coat with other SEP Central Boards |  |  |  |  |  |  | baseline start none → 2004-01-27; baseline finish none → 2004-01-27 |
| 433 | **SEP Solid State Detector Bias Supply Board** | 2004-01-20 A | 2004-04-06 → 2004-05-26 (+50d) | 55d → 91d | 0% → 56% | 22d → -10d |  | baseline start none → 2004-01-20; baseline finish none → 2004-04-15 |
| 434 | **Assembly & Initial Test** | 2004-01-20 A |  |  | 0% → 70% | 27d → 31d |  | baseline start none → 2004-01-20; baseline finish none → 2004-03-16 |
| 435 | Assemble and Initial Test FM 1 SSD Bias Supply Board | 2004-01-20 A |  |  | 0% → 70% | 27d → 31d |  | baseline start none → 2004-01-20; baseline finish none → 2004-03-16 |
| 436 | Assemble and Initial Test FM 2 SSD Bias Supply Board | 2004-01-20 A |  |  | 0% → 70% | 27d → 31d |  | baseline start none → 2004-01-20; baseline finish none → 2004-03-16 |
| 437 | **Final Test** | 2004-03-24 → 2004-05-13 (+50d) | 2004-04-06 → 2004-05-26 (+50d) |  |  | 22d → -10d |  | baseline start none → 2004-04-02; baseline finish none → 2004-04-15 |
| 438 | Final Test FM 1 SSD Bias Supply Board | 2004-03-24 → 2004-05-13 (+50d) | 2004-04-06 → 2004-05-26 (+50d) |  |  | 22d → -10d |  | baseline start none → 2004-04-02; baseline finish none → 2004-04-15 |
| 439 | Final Test FM 2 SSD Bias Supply Board | 2004-03-24 → 2004-05-13 (+50d) | 2004-04-06 → 2004-05-26 (+50d) |  |  | 22d → -10d |  | baseline start none → 2004-04-02; baseline finish none → 2004-04-15 |
| 440 | **Conformal Coat, Mass Properties and Bake Out (SEP Central, LET, SEP LVPS)** | 2004-04-07 → 2004-05-27 (+50d) | 2004-04-29 → 2004-06-21 (+53d) |  |  | 22d → -10d |  | baseline start none → 2004-04-16; baseline finish none → 2004-05-10 |
| 441 | Stake/Conformal Coat All SEP Central and LET Boards | 2004-04-07 → 2004-05-27 (+50d) | 2004-04-20 → 2004-06-10 (+51d) |  |  | 22d → -10d |  | baseline start none → 2004-04-16; baseline finish none → 2004-04-29 |
| 442 | Mass Properties/Photo All SEP Central and LET Boards | 2004-04-21 → 2004-06-11 (+51d) | 2004-04-26 → 2004-06-16 (+51d) |  |  | 22d → -10d |  | baseline start none → 2004-04-30; baseline finish none → 2004-05-05 |
| 443 | Bake Out All SEP Central/LET Boards and SEP LVPS (FM 1 & 2) | 2004-04-27 → 2004-06-17 (+51d) | 2004-04-29 → 2004-06-21 (+53d) |  |  | 22d → -10d |  | baseline start none → 2004-05-06; baseline finish none → 2004-05-10 |
| 444 | **Flight Software** |  |  |  | 49% → 68% | 26d → 30d |  | baseline start none → 2003-08-01; baseline finish none → 2004-06-03 |
| 445 | SEP Central Build 3 |  |  |  | 59% → 81% | 26d → 30d |  | baseline start none → 2003-08-01; baseline finish none → 2004-04-14 |
| 446 | Final Flight S/W Build |  |  |  |  | 26d → 30d |  | baseline start none → 2004-04-15; baseline finish none → 2004-06-03 |
| 447 | **HET - Tycho (GSFC)** | 2004-01-06 A | 2004-06-22 → 2004-07-29 (+37d) | 118d → 145d | 0% → 48% | 19d → 15d |  | was named HET - GSFC; baseline start none → 2004-01-06; baseline finish none → 2004-06-23 |
| 448 | **Deliveries** | 2004-04-30 → 2004-05-18 (+18d) | 2004-06-22 → 2004-07-29 (+37d) | 37d → 52d |  | 19d → 15d |  | baseline start none → 2004-04-30; baseline finish none → 2004-06-23 |
| 449 | Deliver HET FM 1 (to CIT for SEP Suite I&T) | 2004-05-28 → 2004-07-07 (+40d) | 2004-06-01 → 2004-07-08 (+37d) |  |  | 20d → -3d | 492, 403 → 403, 494 | baseline start none → 2004-06-01; baseline finish none → 2004-06-02 |
| 450 | Deliver HET FM 2 (to CIT for SEP Suite I&T) | 2004-06-21 → 2004-07-28 (+37d) | 2004-06-22 → 2004-07-29 (+37d) |  |  | 19d → 15d |  | baseline start none → 2004-06-22; baseline finish none → 2004-06-23 |
| 451 | Deliver Final HET Flight Software to SEP I&T | 2004-04-30 → 2004-05-18 (+18d) | 2004-05-03 → 2004-05-19 (+16d) |  |  | 40d → 32d |  | baseline start none → 2004-04-30; baseline finish none → 2004-05-03 |
| 452 | **Detectors (Batch 1)** | 2004-01-06 A | 2004-03-31 → 2004-03-03 A (-28d) | 60d → 40d | 0% → 100% | 40d → none |  | was named Detectors; baseline start none → 2004-01-06; baseline finish none → 2004-03-31 |
| 453 | Receive & Inspect HET Flight Detectors | 2004-01-06 A | 2004-03-03 A |  | 0% → 100% | 40d → none |  | baseline start none → 2004-01-06; baseline finish none → 2004-03-03 |
| 454 | **Detector Testing** | 2004-01-06 A | 2004-03-31 → 2004-03-03 A (-28d) | 60d → 40d | 0% → 100% | 40d → none |  | baseline start none → 2004-01-06; baseline finish none → 2004-03-31 |
| 455 | Capacitance, Current, Depletion, Alpha Resolution Testing | 2004-01-06 A | 2004-03-31 → 2004-03-03 A (-28d) | 60d → 40d | 0% → 100% | 40d → none |  | baseline start none → 2004-01-06; baseline finish none → 2004-03-31 |
| 456 | Life Test HET Detectors | 2004-01-06 A | 2004-03-31 → 2004-03-03 A (-28d) | 60d → 40d | 0% → 100% | 40d → none |  | baseline start none → 2004-01-06; baseline finish none → 2004-03-31 |
| 463 | **Electronics Board** | 2004-01-22 A | 2004-05-13 → 2004-05-11 (-2d) | 80d → 78d | 0% → 42% | 24d → 48d |  | baseline start none → 2004-01-22; baseline finish none → 2004-05-13 |
| 464 | **Assembly** | 2004-01-22 A | 2004-03-12 → 2004-03-16 (+4d) | 36d → 38d | 0% → 50% | 24d → 59d |  | baseline start none → 2004-01-22; baseline finish none → 2004-03-12 |
| 465 | Install Socket on HET Electronics FM 1 Board for ETU ACTEL | 2004-01-22 A | 2004-01-22 A |  | 0% → 100% | 24d → none |  | baseline start none → 2004-01-22; baseline finish none → 2004-01-22 |
| 466 | Complete Population of HET Electronics FM 1 Board (ETU ACTEL) | 2004-01-23 A | 2004-01-23 A |  | 0% → 100% | 24d → none |  | baseline start none → 2004-01-23; baseline finish none → 2004-01-23 |
| 467 | Complete Population of HET Electronics FM 2 Board (Flight ACTEL) | 2004-03-11 → 2004-03-15 (+4d) | 2004-03-12 → 2004-03-16 (+4d) |  |  | 30d → 59d |  | baseline start none → 2004-03-11; baseline finish none → 2004-03-12 |
| 468 | **Test** | 2004-01-26 A | 2004-05-13 → 2004-05-11 (-2d) | 78d → 76d | 0% → 42% | 24d → 48d |  | baseline start none → 2004-01-26; baseline finish none → 2004-05-13 |
| 469 | **FM 1** | 2004-01-26 A | 2004-03-22 → 2004-03-26 (+4d) | 40d → 44d | 0% → 55% | 24d → 46d |  | baseline start none → 2004-01-26; baseline finish none → 2004-03-22 |
| 470 | Test HET FM 1 Electronics Board w/ETU ACTEL | 2004-01-26 A | 2004-02-23 → 2004-02-26 A (+3d) | 20d → 23d | 0% → 100% | 24d → none |  | baseline start none → 2004-01-26; baseline finish none → 2004-02-23 |
| 471 | Remove ETU ACTEL and socket from HET FM 1 Electronics Board | 2004-02-24 → 2004-02-27 A (+3d) | 2004-02-24 → 2004-02-27 A (+3d) | 1d → 0.5d | 0% → 100% | 24d → none |  | baseline start none → 2004-02-24; baseline finish none → 2004-02-24 |
| 472 | Install Flight ACTEL on HET FM 1 Electronics Board | 2004-02-25 → 2004-02-27 A (+2d) | 2004-02-25 → 2004-02-27 A (+2d) | 1d → 0.5d | 0% → 100% | 24d → none |  | baseline start none → 2004-02-25; baseline finish none → 2004-02-25 |
| 473 | Retest HET FM 1 Electronics Board w/Flight ACTEL | 2004-02-26 → 2004-03-01 (+4d) | 2004-03-10 → 2004-03-12 (+2d) |  |  | 24d → 46d |  | baseline start none → 2004-02-26; baseline finish none → 2004-03-10 |
| 474 | Clean, Bake, Conformal Coat HET FM 1 Electronics Board | 2004-03-11 → 2004-03-15 (+4d) | 2004-03-12 → 2004-03-19 (+7d) | 2d → 5d |  | 24d → 46d |  | was named Conformal Coat HET FM 1 Electronics Board; baseline start none → 2004-03-11; baseline finish none → 2004-03-12 |
| 475 | Retest Conformal Coated HET FM 1 Electronics Board | 2004-03-15 → 2004-03-22 (+7d) | 2004-03-16 → 2004-03-26 (+10d) | 2d → 5d |  | 24d → 46d |  | baseline start none → 2004-03-15; baseline finish none → 2004-03-16 |
| 476 | **FM 2** | 2004-03-23 → 2004-03-17 A (-6d) | 2004-05-13 → 2004-05-11 (-2d) | 38d → 40d | 0% → 28% | 24d → 48d |  | baseline start none → 2004-03-23; baseline finish none → 2004-05-13 |
| 477 | Test HET FM 2 Electronics Board | 2004-03-23 → 2004-03-17 A (-6d) | 2004-05-03 → 2004-04-27 (-6d) |  | 0% → 37% | 24d → 48d | 467, 470, Retest Bakedout HET FM 1 Electronics Board → 467, 470 | baseline start none → 2004-03-23; baseline finish none → 2004-05-03 |
| 478 | Clean, Bake, Conformal Coat HET FM 2 Electronics Board | 2004-05-04 → 2004-04-28 (-6d) | 2004-05-05 → 2004-05-04 (-1d) | 2d → 5d |  | 24d → 48d |  | was named Conformal Coat HET FM 2 Electronics Board; baseline start none → 2004-05-04; baseline finish none → 2004-05-05 |
| 479 | Retest Conformal Coated HET FM 2 Electronics Board | 2004-05-06 → 2004-05-05 (-1d) | 2004-05-07 → 2004-05-11 (+4d) | 2d → 5d |  | 24d → 48d |  | baseline start none → 2004-05-06; baseline finish none → 2004-05-07 |
| 480 | **Flight Software** | 2004-01-22 A | 2004-04-29 → 2004-05-17 (+18d) | 70d → 82d | 0% → 32% | 19d → 10d |  | baseline start none → 2004-01-22; baseline finish none → 2004-04-29 |
| 481 | **Design** | 2004-01-22 A | 2004-02-04 → 2004-02-23 A (+19d) | 10d → 22d | 0% → 100% | 19d → none |  | baseline start none → 2004-01-22; baseline finish none → 2004-02-04 |
| 482 | Complete Definition of HET PH Event Processing | 2004-01-22 A | 2004-02-04 → 2004-02-23 A (+19d) | 10d → 22d | 0% → 100% | 19d → none |  | baseline start none → 2004-01-22; baseline finish none → 2004-02-04 |
| 483 | **Coding** | 2004-02-05 → 2004-02-24 A (+19d) | 2004-03-04 → 2004-03-22 (+18d) |  | 0% → 20% | 19d → 10d |  | baseline start none → 2004-02-05; baseline finish none → 2004-03-04 |
| 484 | Code HET PH Event Processing Update for Flight | 2004-02-05 → 2004-02-24 A (+19d) | 2004-02-19 → 2004-03-08 (+18d) |  | 0% → 40% | 19d → 10d |  | baseline start none → 2004-02-05; baseline finish none → 2004-02-19 |
| 485 | Code HET Telemetry Formatting Update for Flight | 2004-02-20 → 2004-03-09 (+18d) | 2004-03-04 → 2004-03-22 (+18d) |  |  | 19d → 10d |  | baseline start none → 2004-02-20; baseline finish none → 2004-03-04 |
| 486 | **Test** | 2004-03-05 → 2004-03-23 (+18d) | 2004-04-29 → 2004-05-17 (+18d) |  |  | 19d → 10d |  | baseline start none → 2004-03-05; baseline finish none → 2004-04-29 |
| 487 | Test Integrated HET S/W with Simulated Data | 2004-03-05 → 2004-03-23 (+18d) | 2004-03-25 → 2004-04-12 (+18d) |  |  | 19d → 10d |  | baseline start none → 2004-03-05; baseline finish none → 2004-03-25 |
| 488 | Verify HET On-Board Software | 2004-03-26 → 2004-04-13 (+18d) | 2004-04-29 → 2004-05-17 (+18d) |  |  | 19d → 10d |  | baseline start none → 2004-03-26; baseline finish none → 2004-04-29 |
| 489 | **Integration & Test** | 2004-04-30 → 2004-06-07 (+38d) | 2004-06-18 → 2004-07-27 (+39d) | 35d → 37d |  | 19d → -3d |  | baseline start none → 2004-05-03; baseline finish none → 2004-06-21 |
| 490 | **FM 1** | 2004-04-30 → 2004-06-07 (+38d) | 2004-05-27 → 2004-07-06 (+40d) | 20d → 22d |  | 19d → -3d |  | baseline start none → 2004-05-03; baseline finish none → 2004-05-28 |
| 491 | Integrate HET FM 1 Electronics Telescope (Ahead) | 2004-04-30 → 2004-06-07 (+38d) | 2004-05-06 → 2004-06-11 (+36d) |  |  | 19d → -3d | Retest Bakedout HET FM 1 Electronics Board, 456, 488, 393 → 456, 488, 393, 475 | baseline start none → 2004-05-03; baseline finish none → 2004-05-07 |
| 492 | Test HET FM 1 Telescope (Ahead) | 2004-05-07 → 2004-06-14 (+38d) | 2004-05-27 → 2004-07-02 (+36d) |  |  | 19d → -3d |  | baseline start none → 2004-05-10; baseline finish none → 2004-05-28 |
| 495 | **FM 2** | 2004-05-14 → 2004-06-14 (+31d) | 2004-06-18 → 2004-07-27 (+39d) | 25d → 32d |  | 19d → 15d |  | baseline start none → 2004-05-14; baseline finish none → 2004-06-21 |
| 496 | Integrate HET FM 2 Electronics Telescope (Behind) | 2004-05-14 → 2004-06-14 (+31d) | 2004-05-20 → 2004-06-18 (+29d) |  |  | 24d → 26d | Retest Bakedout HET FM 2 Electronics Board, 491, 456, 488, 393 → 491, 456, 488, 393, 479 | baseline start none → 2004-05-14; baseline finish none → 2004-05-20 |
| 498 | Test HET FM 2 Telescope (Behind) | 2004-05-28 → 2004-07-07 (+40d) | 2004-06-18 → 2004-07-27 (+39d) |  |  | 19d → 15d | 492, 496 → 497 | baseline start none → 2004-06-01; baseline finish none → 2004-06-21 |
| 499 | **LET - CIT** |  | 2004-05-27 → 2004-07-19 (+53d) | 221d → 257d | 56% → 76% | 36d → 23d |  | baseline start none → 2003-07-14; baseline finish none → 2004-06-08 |
| 500 | **Deliveries** |  | 2004-05-27 → 2004-07-19 (+53d) | 17d → 53d |  | 36d → 23d |  | baseline start none → 2004-05-04; baseline finish none → 2004-06-08 |
| 501 | Deliver LET FM 1 (stays at CIT for SEP I&T) | 2004-05-27 → 2004-07-19 (+53d) | 2004-05-27 → 2004-07-19 (+53d) |  |  | 22d → -10d |  | baseline start none → 2004-06-08; baseline finish none → 2004-06-08 |
| 502 | Deliver LET FM 2 (stays at CIT for SEP I&T) | 2004-05-27 → 2004-07-19 (+53d) | 2004-05-27 → 2004-07-19 (+53d) |  |  | 36d → 23d |  | baseline start none → 2004-06-08; baseline finish none → 2004-06-08 |
| 503 | Deliver LET Flight Software Build 3 |  |  |  |  | 39d → 43d |  | baseline start none → 2004-05-04; baseline finish none → 2004-05-04 |
| 504 | **Detectors** |  |  |  | 71% → 94% | 56d → 60d |  | baseline start none → 2003-07-14; baseline finish none → 2004-03-12 |
| 505 | Complete LET Flight Detector Testing |  |  |  | 71% → 94% | 56d → 60d |  | baseline start none → 2003-07-14; baseline finish none → 2004-03-12 |
| 506 | **Hybrids** |  | 2004-03-01 A |  | 72% → 100% | 27d → none |  | baseline start none → 2003-08-01; baseline finish none → 2004-03-01 |
| 507 | Complete Test of Flight Hybrids (LET and to GSFC for HET FM 2) |  | 2004-03-01 A |  | 72% → 100% | 27d → none |  | baseline start none → 2003-08-01; baseline finish none → 2004-03-01 |
| 508 | **Detector/Misc Board** |  |  |  |  | 27d → 31d |  | baseline start none → 2004-03-02; baseline finish none → 2004-03-30 |
| 509 | **Assembly** |  |  |  |  | 27d → 31d |  | baseline start none → 2004-03-02; baseline finish none → 2004-03-15 |
| 510 | Assemble LET FM 1 Detector Board |  |  |  |  | 27d → 31d |  | baseline start none → 2004-03-02; baseline finish none → 2004-03-15 |

| ID | Task | Start | Finish | Duration | Complete | Total float | Predecessors | Other |
| --- | --- | --- | --- | --- | --- | --- | --- | --- |
| 511 | Assemble LET FM 2 Detector Board |  |  |  |  | 27d → 31d |  | baseline start none → 2004-03-02; baseline finish none → 2004-03-15 |
| 512 | **Test** |  |  |  |  | 27d → 31d |  | baseline start none → 2004-03-16; baseline finish none → 2004-03-30 |
| 513 | Test LET FM 1 Detector Board |  |  |  |  | 27d → 31d |  | baseline start none → 2004-03-16; baseline finish none → 2004-03-30 |
| 514 | Test LET FM 2 Detector Board |  |  |  |  | 27d → 31d |  | baseline start none → 2004-03-16; baseline finish none → 2004-03-30 |
| 515 | **Flight Software** |  |  |  | 55% → 75% | 39d → 43d |  | baseline start none → 2003-08-01; baseline finish none → 2004-05-04 |
| 516 | Let Flight Software Build 3 |  |  |  | 55% → 75% | 39d → 43d |  | baseline start none → 2003-08-01; baseline finish none → 2004-05-04 |
| 517 | **Integration & Test** | 2004-04-30 → 2004-06-22 (+53d) | 2004-05-27 → 2004-07-19 (+53d) |  |  | 22d → -10d |  | baseline start none → 2004-05-11; baseline finish none → 2004-06-08 |
| 518 | **FM 1** | 2004-04-30 → 2004-06-22 (+53d) | 2004-05-27 → 2004-07-19 (+53d) |  |  | 22d → -10d |  | baseline start none → 2004-05-11; baseline finish none → 2004-06-08 |
| 519 | Integrate LET FM 1 Housing With Detectors | 2004-04-30 → 2004-06-22 (+53d) | 2004-05-27 → 2004-07-19 (+53d) |  |  | 22d → -10d |  | baseline start none → 2004-05-11; baseline finish none → 2004-06-08 |
| 520 | **FM 2** | 2004-04-30 → 2004-06-22 (+53d) | 2004-05-27 → 2004-07-19 (+53d) |  |  | 36d → 23d |  | baseline start none → 2004-05-11; baseline finish none → 2004-06-08 |
| 521 | Integrate LET FM 2 Housing With Detectors | 2004-04-30 → 2004-06-22 (+53d) | 2004-05-27 → 2004-07-19 (+53d) |  |  | 36d → 23d |  | baseline start none → 2004-05-11; baseline finish none → 2004-06-08 |
| 522 | **SEPT - Kiel/ESTEC** |  | 2004-07-21 → 2004-09-02 (+43d) | 240d → 271d | 35% → 90% | 318d → 23d |  | baseline start none → 2003-08-08; baseline finish none → 2004-07-28 |
| 523 | **Deliveries** | 2004-03-01 → 2004-03-15 (+14d) | 2004-07-21 → 2004-09-02 (+43d) | 102d → 123d |  | 68d → 23d |  | baseline start none → 2004-03-11; baseline finish none → 2004-07-28 |
| 524 | Deliver SEPT-NS FM 1 to CIT for SEP I&T and Suite EMC | 2004-03-12 → 2004-03-15 (+3d) | 2004-03-18 → 2004-03-19 (+1d) |  |  | 70d → 73d |  | baseline start none → 2004-03-11; baseline finish none → 2004-03-17 |
| 525 | Deliver SEPT-E FM 1 to CIT for SEP I&T and Suite EMC | 2004-03-01 → 2004-03-15 (+14d) | 2004-03-05 → 2004-03-19 (+14d) |  |  | 79d → 73d |  | baseline start none → 2004-03-11; baseline finish none → 2004-03-17 |
| 526 | Final Delivery of SEPT FM 1 to APL (after Therm Bal @ GSFC) | 2004-07-20 → 2004-09-01 (+43d) | 2004-07-21 → 2004-09-02 (+43d) |  |  | 54d → 23d | 565, 572 → 565, 572, 556 | was named Final Delivery of SEPT FM 1 to APL; baseline start none → 2004-07-27; baseline finish none → 2004-07-28 |
| 527 | Deliver SEPT-NS FM 2 to CIT for SEP I&T and Suite EMC | 2004-03-08 → 2004-03-18 (+10d) | 2004-03-12 → 2004-03-24 (+12d) |  |  | 88d → 103d |  | baseline start none → 2004-03-22; baseline finish none → 2004-03-26 |
| 528 | Deliver SEPT-E FM 2 to CIT for SEP I&T and Suite EMC | 2004-03-08 → 2004-03-18 (+10d) | 2004-03-12 → 2004-03-24 (+12d) |  |  | 88d → 103d |  | baseline start none → 2004-03-22; baseline finish none → 2004-03-26 |
| 529 | **Mechanical Assembly** |  | 2004-02-27 A |  | 66% → 100% | 420d → none |  | baseline start none → 2003-12-22; baseline finish none → 2004-02-27 |
| 530 | **FM 1** |  |  |  |  |  |  | baseline start none → 2003-12-22; baseline finish none → 2004-01-09 |
| 531 | Assemble SEPT-NS FM 1 Sensor and E-Box Housing |  |  |  |  |  |  | baseline start none → 2003-12-22; baseline finish none → 2004-01-09 |
| 532 | Assemble SEPT-E FM 1 Sensor and E-Box Housing |  |  |  |  |  |  | baseline start none → 2003-12-22; baseline finish none → 2004-01-09 |
| 533 | **FM 2** |  |  |  |  |  |  | baseline start none → 2003-12-29; baseline finish none → 2004-01-16 |
| 534 | Assemble SEPT-NS FM 2 Sensor and E-Box Housing |  |  |  |  |  |  | baseline start none → 2003-12-29; baseline finish none → 2004-01-16 |
| 535 | Assemble SEPT-E FM 2 Sensor and E-Box Housing |  |  |  |  |  |  | baseline start none → 2003-12-29; baseline finish none → 2004-01-16 |
| 536 | **Spare** | 2004-01-20 A | 2004-02-27 A |  | 0% → 100% | 420d → none |  | baseline start none → 2004-01-20; baseline finish none → 2004-02-27 |
| 537 | Assemble SEPT Spare Sensor and E-Box Housing | 2004-01-20 A | 2004-02-27 A |  | 0% → 100% | 420d → none |  | baseline start none → 2004-01-20; baseline finish none → 2004-02-27 |
| 538 | **Electronics** |  | 2004-03-08 → 2004-05-21 (+74d) | 144d → 198d | 43% → 94% | 414d → 94d |  | baseline start none → 2003-08-08; baseline finish none → 2004-05-21 |
| 539 | **Assembly** |  | 2004-02-06 → 2004-04-15 (+69d) | 124d → 172d | 44% → 97% | 414d → 105d |  | baseline start none → 2003-08-08; baseline finish none → 2004-04-15 |
| 540 | **FM 2** |  |  |  |  |  |  | baseline start none → 2003-08-08; baseline finish none → 2004-01-12 |
| 541 | Assemble SEPT-NS FM 2 Electronics |  |  |  |  |  |  | baseline start none → 2003-08-08; baseline finish none → 2004-01-12 |
| 542 | Assemble SEPT-E FM 2 Electronics |  |  |  |  |  |  | baseline start none → 2003-08-08; baseline finish none → 2003-12-19 |
| 543 | **Spare** | 2003-08-08 A | 2004-02-06 → 2004-04-15 (+69d) | 124d → 172d | 0% → 94% | 414d → 105d |  | baseline start none → 2003-08-08; baseline finish none → 2004-04-15 |
| 544 | Assemble SEPT FS Electronics | 2003-08-08 A | 2004-02-06 → 2004-04-15 (+69d) | 124d → 172d | 0% → 94% | 414d → 105d |  | was named Assemble SEPT-NS FS Electronics; baseline start none → 2003-08-08; baseline finish none → 2004-04-15 |
| 545 | **Test** |  | 2004-03-08 → 2004-05-21 (+74d) | 59d → 113d | 35% → 70% | 414d → 94d |  | baseline start none → 2003-12-11; baseline finish none → 2004-05-21 |
| 546 | **FM 2** |  | 2004-01-30 A |  | 74% → 100% | 439d → none |  | baseline start none → 2003-12-11; baseline finish none → 2004-01-30 |
| 547 | SEPT-NS FM 2 Electronics Test |  |  |  |  |  |  | baseline start none → 2004-01-13; baseline finish none → 2004-01-16 |
| 548 | SEPT-E FM 2 Electronics Test |  |  |  |  |  |  | baseline start none → 2003-12-11; baseline finish none → 2003-12-16 |
| 549 | Coat SEPT-NS FM 2 Electronics Board | 2004-01-20 A | 2004-01-23 A |  | 0% → 100% | 439d → none |  | baseline start none → 2004-01-20; baseline finish none → 2004-01-23 |
| 550 | Coat SEPT-E FM 2 Electronics Board |  |  |  |  |  |  | baseline start none → 2003-12-17; baseline finish none → 2003-12-23 |
| 551 | SEPT-NS FM 2 Mechanical Integration | 2004-01-26 A | 2004-01-30 A |  | 0% → 100% | 439d → none |  | baseline start none → 2004-01-26; baseline finish none → 2004-01-30 |
| 552 | SEPT-E FM 2 Mechanical Integration |  |  |  |  |  |  | baseline start none → 2003-12-24; baseline finish none → 2004-01-13 |
| 553 | **Spare** | 2004-02-09 → 2004-04-26 (+77d) | 2004-03-08 → 2004-05-21 (+74d) |  |  | 414d → 94d |  | baseline start none → 2004-04-26; baseline finish none → 2004-05-21 |
| 554 | SEPT Flight Spare Electronics Test | 2004-02-09 → 2004-04-26 (+77d) | 2004-02-13 → 2004-04-30 (+77d) |  |  | 414d → 99d |  | was named SEPT-NS Flight Spare Electronics Test; constraint none → start no earlier than 2004-04-26; baseline start none → 2004-04-26; baseline finish none → 2004-04-30 |
| 555 | Coat SEPT FS Electronics Board | 2004-02-17 → 2004-05-10 (+83d) | 2004-02-23 → 2004-05-14 (+81d) |  |  | 414d → 94d |  | was named Coat SEPT-NS FS Electronics Board; constraint none → start no earlier than 2004-05-10; baseline start none → 2004-05-10; baseline finish none → 2004-05-14 |
| 556 | SEPT FS Mechanical Integration | 2004-02-24 → 2004-05-17 (+83d) | 2004-03-08 → 2004-05-21 (+74d) | 10d → 5d |  | 414d → 94d |  | was named SEPT-NS FS Mechanical Integration; baseline start none → 2004-05-17; baseline finish none → 2004-05-21 |
| 557 | **Integration & Test** |  | 2004-07-19 → 2004-08-31 (+43d) | 133d → 164d | 3% → 84% | 68d → 23d |  | baseline start none → 2004-01-12; baseline finish none → 2004-07-26 |
| 558 | **FM 1** |  | 2004-07-19 → 2004-08-31 (+43d) | 133d → 164d | 6% → 73% | 54d → 23d |  | baseline start none → 2004-01-12; baseline finish none → 2004-07-26 |
| 559 | **SEPT-NS** | 2004-01-26 A | 2004-07-19 → 2004-08-31 (+43d) | 124d → 155d | 0% → 73% | 54d → 23d |  | baseline start none → 2004-01-26; baseline finish none → 2004-07-26 |
| 560 | SEPT-NS FM 1 Integration & Test | 2004-01-26 A | 2004-01-30 A |  | 0% → 100% | 70d → none |  | baseline start none → 2004-01-26; baseline finish none → 2004-01-30 |
| 561 | Muon and Radioactive Source Test | 2004-02-02 A | 2004-02-06 A |  | 0% → 100% | 70d → none |  | baseline start none → 2004-02-02; baseline finish none → 2004-02-06 |
| 562 | SEPT-NS FM 1 Vibration | 2004-02-09 → 2004-02-19 A (+10d) | 2004-02-23 → 2004-02-24 A (+1d) | 10d → 4d | 0% → 100% | 70d → none |  | was named SEPT-NS FM 1 Vibration and Acoustics; constraint none → start no earlier than 2004-02-19; baseline start none → 2004-02-17; baseline finish none → 2004-02-20 |
| 563 | SEPT-NS FM 1 Thermal Vac | 2004-02-24 → 2004-02-27 A (+3d) | 2004-03-08 → 2004-03-12 A (+4d) | 10d → 11d | 0% → 100% | 70d → none | 562 → 562FS+2d | baseline start none → 2004-02-25; baseline finish none → 2004-03-08 |
| 564 | SEPT-NS FM 1 Bake Out | 2004-03-09 → 2004-03-05 A (-4d) | 2004-03-11 → 2004-03-08 A (-3d) | 3d → 2d | 0% → 100% | 70d → none | 563 → 563FS-6d | baseline start none → 2004-03-09; baseline finish none → 2004-03-10 |
| 565 | SEPT-NS FM 1 Thermal Balance (at GSFC after Suite EMC) | 2004-07-06 → 2004-08-18 (+43d) | 2004-07-19 → 2004-08-31 (+43d) |  |  | 54d → 23d |  | was named SEPT-NS FM 1 Thermal Balance; baseline start none → 2004-07-13; baseline finish none → 2004-07-26 |
| 566 | **SEPT-E** |  | 2004-07-19 → 2004-08-31 (+43d) | 133d → 164d | 12% → 73% | 54d → 23d |  | baseline start none → 2004-01-12; baseline finish none → 2004-07-26 |
| 567 | SEPT-E FM 1 Integration & Test |  |  |  |  |  |  | baseline start none → 2004-01-12; baseline finish none → 2004-01-16 |
| 568 | Muon and Radioactive Source Test | 2004-01-20 → 2004-01-29 A (+9d) | 2004-01-26 → 2004-02-04 A (+9d) |  | 0% → 100% | 79d → none |  | constraint none → start no earlier than 2004-01-29; baseline start none → 2004-01-29; baseline finish none → 2004-02-04 |
| 570 | SEPT-E FM 1 Thermal Vac | 2004-02-10 → 2004-02-27 A (+17d) | 2004-02-24 → 2004-03-12 A (+17d) | 10d → 11d | 0% → 100% | 79d → none | SEPT-E FM 1 Vibration and Acoustics → 569, 563SS | baseline start none → 2004-02-25; baseline finish none → 2004-03-08 |
| 571 | SEPT-E FM 1 Bake Out | 2004-02-25 → 2004-03-05 A (+9d) | 2004-02-27 → 2004-03-08 A (+10d) | 3d → 2d | 0% → 100% | 79d → none | 570 → 570FS-6d | baseline start none → 2004-03-09; baseline finish none → 2004-03-10 |
| 572 | SEPT-E FM 1 Thermal Balance (at GSFC after Suite EMC) | 2004-07-06 → 2004-08-18 (+43d) | 2004-07-19 → 2004-08-31 (+43d) |  |  | 54d → 23d |  | was named SEPT-E FM 1 Thermal Balance; baseline start none → 2004-07-13; baseline finish none → 2004-07-26 |
| 573 | **FM 2** | 2004-01-20 → 2004-01-12 A (-8d) | 2004-07-19 → 2004-03-17 A (-124d) | 128d → 46d | 0% → 100% | 68d → none |  | baseline start none → 2004-01-12; baseline finish none → 2004-03-19 |
| 574 | **SEPT-NS** | 2004-01-20 A | 2004-07-19 → 2004-03-17 A (-124d) | 128d → 41d | 0% → 100% | 68d → none |  | baseline start none → 2004-01-20; baseline finish none → 2004-03-19 |
| 575 | SEPT-NS FM 2 Integration & Test | 2004-01-20 A | 2004-01-26 → 2004-01-29 A (+3d) | 5d → 8d | 0% → 100% | 88d → none |  | baseline start none → 2004-01-20; baseline finish none → 2004-01-29 |
| 576 | Muon and Radioactive Source Test | 2004-01-27 → 2004-01-30 A (+3d) | 2004-02-02 → 2004-02-06 A (+4d) | 5d → 6d | 0% → 100% | 88d → none |  | baseline start none → 2004-01-30; baseline finish none → 2004-02-06 |
| 577 | SEPT-NS FM 2 Vibration | 2004-02-03 → 2004-02-19 A (+16d) | 2004-02-17 → 2004-02-24 A (+7d) | 10d → 4d | 0% → 100% | 88d → none | 576 → 576, 562SS | was named SEPT-NS FM 2 Vibration and Acoustics; baseline start none → 2004-02-17; baseline finish none → 2004-02-20 |
| 578 | SEPT-NS FM 2 Thermal Vac | 2004-02-18 → 2004-03-05 A (+16d) | 2004-03-02 → 2004-03-17 A (+15d) | 10d → 9d | 0% → 100% | 88d → none |  | constraint none → start no earlier than 2004-03-05; baseline start none → 2004-03-09; baseline finish none → 2004-03-17 |
| 579 | SEPT-NS FM 2 Bake Out | 2004-03-03 → 2004-03-12 A (+9d) | 2004-03-05 → 2004-03-15 A (+10d) | 3d → 2d | 0% → 100% | 88d → none | 578 → 578FS-4d | baseline start none → 2004-03-18; baseline finish none → 2004-03-19 |
| 580 | **SEPT-E** | 2004-01-20 → 2004-01-12 A (-8d) | 2004-07-19 → 2004-03-17 A (-124d) | 128d → 46d | 0% → 100% | 68d → none |  | baseline start none → 2004-01-12; baseline finish none → 2004-03-19 |
| 581 | SEPT-E FM 2 Integration & Test | 2004-01-20 → 2004-01-12 A (-8d) | 2004-01-26 → 2004-01-16 A (-10d) |  | 0% → 100% | 88d → none | 535 → 567SS | baseline start none → 2004-01-12; baseline finish none → 2004-01-16 |

| ID | Task | Start | Finish | Duration | Complete | Total float | Predecessors | Other |
| --- | --- | --- | --- | --- | --- | --- | --- | --- |
| 582 | Muon and Radioactive Source Test | 2004-01-27 → 2004-01-29 A (+2d) | 2004-02-02 → 2004-02-04 A (+2d) |  | 0% → 100% | 88d → none | 581 → 581, 568SS | baseline start none → 2004-01-29; baseline finish none → 2004-02-04 |
| 583 | SEPT-E FM 2 Vibration | 2004-02-03 → 2004-02-19 A (+16d) | 2004-02-17 → 2004-02-24 A (+7d) | 10d → 4d | 0% → 100% | 88d → none | 582 → 582, 562SS | was named SEPT-E FM 2 Vibration and Acoustics; baseline start none → 2004-02-21; baseline finish none → 2004-02-24 |
| 584 | SEPT-E FM 2 Thermal Vac | 2004-02-18 → 2004-03-05 A (+16d) | 2004-03-02 → 2004-03-17 A (+15d) | 10d → 9d | 0% → 100% | 88d → none | 583 → 583, 578SS | baseline start none → 2004-03-09; baseline finish none → 2004-03-17 |
| 585 | SEPT-E FM 2 Bake Out | 2004-03-03 → 2004-03-12 A (+9d) | 2004-03-05 → 2004-03-15 A (+10d) | 3d → 2d | 0% → 100% | 88d → none | 584 → 584FS-4d | baseline start none → 2004-03-18; baseline finish none → 2004-03-19 |
| 586 | **SIT - UMD** |  | 2004-10-20 → 2004-10-22 (+2d) | 351d → 353d | 26% → 51% | 255d → 279d |  | baseline start none → 2003-06-02; baseline finish none → 2004-10-20 |
| 587 | **Deliveries** | 2004-06-11 → 2004-07-26 (+45d) | 2004-10-04 → 2004-10-22 (+18d) | 81d → 63d |  | 14d → -13d |  | baseline start none → 2004-06-18; baseline finish none → 2004-10-12 |
| 588 | Deliver SIT FM 1 to CIT for SEP I&T and Suite EMC | 2004-06-11 → 2004-07-26 (+45d) | 2004-06-14 → 2004-07-27 (+43d) |  |  | 14d → -13d |  | baseline start none → 2004-06-18; baseline finish none → 2004-06-21 |
| 589 | Deliver SIT FM 1 back to GSFC for Environmental Testing (after EMC Test) | 2004-07-06 → 2004-08-18 (+43d) | 2004-07-07 → 2004-08-19 (+43d) |  |  | 29d → -3d | 19 → 19, 411 | baseline start none → 2004-07-13; baseline finish none → 2004-07-14 |
| 590 | Final Delivery of SIT FM 1 to APL | 2004-08-25 → 2004-10-12 (+48d) | 2004-08-25 → 2004-10-12 (+48d) |  |  | 29d → -3d |  | baseline start none → 2004-09-01; baseline finish none → 2004-09-01 |
| 591 | Deliver SIT FM 2 to CIT for SEP I&T | 2004-07-23 → 2004-08-13 (+21d) | 2004-07-26 → 2004-08-16 (+21d) |  |  | 16d → 1d |  | baseline start none → 2004-07-23; baseline finish none → 2004-07-26 |
| 592 | Deliver SIT FM 2 back to GSFC for Environmental Testing | 2004-08-12 → 2004-08-31 (+19d) | 2004-08-13 → 2004-09-01 (+19d) |  |  | 16d → 3d |  | baseline start none → 2004-08-19; baseline finish none → 2004-08-20 |
| 593 | Final Delivery of SIT FM 2 to APL | 2004-10-04 → 2004-10-22 (+18d) | 2004-10-04 → 2004-10-22 (+18d) |  |  | 16d → 3d | 724 → 724, 730 | baseline start none → 2004-10-12; baseline finish none → 2004-10-12 |
| 594 | **ACTEL - for SIT Logic Board** | 2004-02-27 → 2004-05-17 (+80d) | 2004-03-12 → 2004-06-01 (+81d) |  |  | 60d → 8d |  | baseline start none → 2004-02-27; baseline finish none → 2004-03-12 |
| 595 | Burn Final SIT ACTEL Chip (at GSFC) | 2004-02-27 → 2004-05-17 (+80d) | 2004-02-27 → 2004-05-17 (+80d) |  |  | 60d → 8d |  | constraint start no earlier than 2004-02-27 → start no earlier than 2004-05-17; baseline start none → 2004-02-27; baseline finish none → 2004-02-27 |
| 596 | Evaluate (Test) SIT Final ACTEL Chip | 2004-03-01 → 2004-05-18 (+78d) | 2004-03-12 → 2004-06-01 (+81d) |  |  | 60d → 8d |  | baseline start none → 2004-03-01; baseline finish none → 2004-03-12 |
| 597 | **TOF Boards** | 2004-02-17 → 2004-02-12 A (-5d) | 2004-03-15 → 2004-05-05 (+51d) | 20d → 59d | 0% → 38% | 40d → 28d |  | baseline start none → 2004-02-12; baseline finish none → 2004-03-11 |
| 598 | Receive Analog and Digital TOF Boards (FM 1) | 2004-02-17 → 2004-02-12 A (-5d) | 2004-02-17 → 2004-02-12 A (-5d) |  | 0% → 100% | 40d → none |  | was named Receive Analog and Digital TOF Boards (FM 1 & FM 2); constraint start no earlier than 2004-02-17 → start no earlier than 2004-02-12; baseline start none → 2004-02-12; baseline finish none → 2004-02-12 |
| 600 | **Test** | 2004-02-17 → 2004-03-01 A (+13d) | 2004-03-15 → 2004-05-05 (+51d) | 20d → 48d | 0% → 64% | 40d → 28d |  | baseline start none → 2004-02-12; baseline finish none → 2004-03-11 |
| 601 | **FM 1** | 2004-02-17 → 2004-03-01 A (+13d) | 2004-03-01 → 2004-03-24 A (+23d) | 10d → 18d | 0% → 100% | 40d → none |  | baseline start none → 2004-02-12; baseline finish none → 2004-02-26 |
| 602 | FM 1 TOF Boards Functional Test | 2004-02-17 → 2004-03-01 A (+13d) | 2004-03-01 → 2004-03-24 A (+23d) | 10d → 18d | 0% → 100% | 40d → none |  | constraint none → start no earlier than 2004-03-01; baseline start none → 2004-02-12; baseline finish none → 2004-02-26 |
| 603 | **FM 2** | 2004-03-02 → 2004-04-22 (+51d) | 2004-03-15 → 2004-05-05 (+51d) |  |  | 65d → 28d |  | baseline start none → 2004-02-27; baseline finish none → 2004-03-11 |
| 604 | FM 2 TOF Boards Functional Test | 2004-03-02 → 2004-04-22 (+51d) | 2004-03-15 → 2004-05-05 (+51d) |  |  | 65d → 28d | 598, 602 → 598, 599 | baseline start none → 2004-02-27; baseline finish none → 2004-03-11 |
| 605 | **Energy Board** |  | 2004-03-02 → 2004-05-14 (+73d) | 76d → 129d | 57% → 81% | 74d → 21d |  | baseline start none → 2003-11-10; baseline finish none → 2004-04-02 |
| 606 | **Assembly** |  | 2004-01-16 → 2004-04-23 (+98d) | 46d → 114d | 76% → 94% | 89d → 21d |  | baseline start none → 2003-11-10; baseline finish none → 2004-02-20 |
| 607 | **FM 1** |  | 2004-01-16 → 2004-03-24 A (+68d) | 46d → 92d | 76% → 100% | 54d → none |  | baseline start none → 2003-11-10; baseline finish none → 2004-02-20 |
| 608 | Assemble FM 1 Energy Board |  | 2004-01-16 → 2004-03-24 A (+68d) | 46d → 92d | 76% → 100% | 54d → none |  | baseline start none → 2003-11-10; baseline finish none → 2004-02-20 |
| 609 | **FM 2** |  | 2004-01-16 → 2004-04-23 (+98d) | 46d → 114d | 76% → 88% | 89d → 21d |  | baseline start none → 2003-11-10; baseline finish none → 2004-02-20 |
| 610 | Assemble FM 2 Energy Board |  | 2004-01-16 → 2004-04-23 (+98d) | 46d → 84d | 76% → 88% | 89d → 21d | 608SS → 608FF+22d | baseline start none → 2003-11-10; baseline finish none → 2004-02-20 |
| 611 | **Test** | 2004-01-20 → 2004-03-25 (+65d) | 2004-03-02 → 2004-05-14 (+73d) | 30d → 37d |  | 54d → 12d |  | baseline start none → 2004-02-23; baseline finish none → 2004-04-02 |
| 612 | **FM 1** | 2004-01-20 → 2004-03-25 (+65d) | 2004-02-09 → 2004-04-14 (+65d) |  |  | 54d → 12d |  | baseline start none → 2004-02-23; baseline finish none → 2004-03-12 |
| 613 | Bench Test/Calibration | 2004-01-20 → 2004-03-25 (+65d) | 2004-02-02 → 2004-04-07 (+65d) |  |  | 54d → 12d |  | baseline start none → 2004-02-23; baseline finish none → 2004-03-05 |
| 614 | Thermal | 2004-02-03 → 2004-04-08 (+65d) | 2004-02-05 → 2004-04-12 (+67d) |  |  | 54d → 12d |  | baseline start none → 2004-03-08; baseline finish none → 2004-03-10 |
| 615 | Voltage Margin | 2004-02-06 → 2004-04-13 (+67d) | 2004-02-09 → 2004-04-14 (+65d) |  |  | 54d → 12d |  | baseline start none → 2004-03-11; baseline finish none → 2004-03-12 |
| 616 | **FM 2** | 2004-02-10 → 2004-04-26 (+76d) | 2004-03-02 → 2004-05-14 (+73d) |  |  | 74d → 21d |  | baseline start none → 2004-03-15; baseline finish none → 2004-04-02 |
| 617 | FM 2 Energy Board Functional Test | 2004-02-10 → 2004-04-26 (+76d) | 2004-03-02 → 2004-05-14 (+73d) |  |  | 74d → 21d |  | baseline start none → 2004-03-15; baseline finish none → 2004-04-02 |
| 618 | **Logic Board** |  | 2004-07-09 → 2004-07-30 (+21d) | 168d → 183d | 31% → 61% | 16d → 1d |  | baseline start none → 2003-11-10; baseline finish none → 2004-07-09 |
| 619 | **Design** |  |  |  |  |  |  | baseline start none → 2003-11-17; baseline finish none → 2003-11-19 |
| 620 | Layout new Logic Board Design |  |  |  |  |  |  | baseline start none → 2003-11-17; baseline finish none → 2003-11-19 |
| 621 | **Fabrication** | 2004-02-02 → 2004-03-08 A (+35d) | 2004-02-13 → 2004-03-19 A (+35d) |  | 0% → 100% | 14d → none |  | baseline start none → 2004-02-09; baseline finish none → 2004-02-23 |
| 622 | FM 1 & FM 2 Logic Board Fabrication | 2004-02-02 → 2004-03-08 A (+35d) | 2004-02-13 → 2004-03-19 A (+35d) |  | 0% → 100% | 14d → none |  | baseline start none → 2004-02-09; baseline finish none → 2004-02-23 |
| 623 | **Assembly** | 2004-03-02 → 2004-04-14 (+43d) | 2004-07-07 → 2004-07-28 (+21d) | 91d → 75d |  | 14d → -13d |  | baseline start none → 2004-03-09; baseline finish none → 2004-07-07 |
| 624 | **FM 1** | 2004-03-02 → 2004-04-14 (+43d) | 2004-05-20 → 2004-07-05 (+46d) |  |  | 14d → -13d |  | baseline start none → 2004-03-09; baseline finish none → 2004-05-27 |
| 625 | Assemble FM 1 Logic Board with ETU ACTELs | 2004-03-02 → 2004-04-14 (+43d) | 2004-03-16 → 2004-04-28 (+43d) |  |  | 14d → -13d | 638 → 638FS+9d | baseline start none → 2004-03-09; baseline finish none → 2004-03-23 |
| 626 | Disassembel FM 1 Logic Board with ETU ACTELs | 2004-05-17 → 2004-06-30 (+44d) | 2004-05-17 → 2004-06-30 (+44d) |  |  | 14d → -13d |  | baseline start none → 2004-05-24; baseline finish none → 2004-05-24 |
| 627 | Retrofit/Inspect FM 1 Flight ACTELs | 2004-05-18 → 2004-07-01 (+44d) | 2004-05-19 → 2004-07-02 (+44d) |  |  | 14d → -13d |  | baseline start none → 2004-05-25; baseline finish none → 2004-05-26 |
| 628 | Reassemble FM 1 Logic Board with Flight ACTELs | 2004-05-20 → 2004-07-05 (+46d) | 2004-05-20 → 2004-07-05 (+46d) |  |  | 14d → -13d |  | baseline start none → 2004-05-27; baseline finish none → 2004-05-27 |
| 629 | **FM 2** | 2004-03-02 → 2004-04-14 (+43d) | 2004-07-07 → 2004-07-28 (+21d) | 91d → 75d |  | 16d → 1d |  | baseline start none → 2004-03-09; baseline finish none → 2004-07-07 |
| 630 | Assemble FM 2 Logic Board with ETU ACTELS | 2004-03-02 → 2004-04-14 (+43d) | 2004-03-16 → 2004-04-28 (+43d) |  |  | 49d → 18d | 638 → 638FS+9d | baseline start none → 2004-03-09; baseline finish none → 2004-03-23 |
| 631 | Disassemble FM 2 Logic Boards | 2004-07-02 → 2004-07-23 (+21d) | 2004-07-02 → 2004-07-23 (+21d) |  |  | 16d → 1d |  | baseline start none → 2004-07-02; baseline finish none → 2004-07-02 |
| 632 | Retrofit/Inspect Flight ACTELS | 2004-07-05 → 2004-07-26 (+21d) | 2004-07-06 → 2004-07-27 (+21d) |  |  | 16d → 1d |  | baseline start none → 2004-07-05; baseline finish none → 2004-07-06 |
| 633 | Reassemble FM 2 Logic Boards | 2004-07-07 → 2004-07-28 (+21d) | 2004-07-07 → 2004-07-28 (+21d) |  |  | 16d → 1d |  | baseline start none → 2004-07-07; baseline finish none → 2004-07-07 |
| 634 | **Test** |  | 2004-07-09 → 2004-07-30 (+21d) | 168d → 183d | 42% → 72% | 16d → 1d |  | baseline start none → 2003-11-10; baseline finish none → 2004-07-09 |
| 635 | **ETU** |  | 2004-01-30 → 2004-03-05 A (+35d) | 55d → 79d | 75% → 100% | 14d → none |  | baseline start none → 2003-11-10; baseline finish none → 2004-02-06 |
| 636 | Test New ETU Logic Board |  | 2004-01-30 → 2004-03-05 A (+35d) | 55d → 79d | 75% → 100% | 14d → none |  | baseline start none → 2003-11-10; baseline finish none → 2004-02-06 |
| 637 | **FM1 & FM 2** | 2004-02-17 → 2004-03-22 A (+34d) | 2004-03-01 → 2004-03-31 A (+30d) | 10d → 8d | 0% → 100% | 14d → none |  | baseline start none → 2004-02-24; baseline finish none → 2004-03-08 |
| 638 | Coupon Testing | 2004-02-17 → 2004-03-22 A (+34d) | 2004-03-01 → 2004-03-31 A (+30d) | 10d → 8d | 0% → 100% | 14d → none |  | baseline start none → 2004-02-24; baseline finish none → 2004-03-08 |
| 639 | **FM 1** | 2004-03-17 → 2004-04-29 (+43d) | 2004-05-24 → 2004-07-07 (+44d) |  |  | 14d → -13d |  | baseline start none → 2004-03-24; baseline finish none → 2004-06-01 |
| 640 | Functional Test of FM 1 Logic Board w/ETU ACTELS | 2004-03-17 → 2004-04-29 (+43d) | 2004-04-06 → 2004-05-19 (+43d) |  |  | 14d → -13d |  | baseline start none → 2004-03-24; baseline finish none → 2004-04-13 |
| 641 | Funtional Test of FM 1 Logic Board w/Flight ACTELS | 2004-05-21 → 2004-07-06 (+46d) | 2004-05-24 → 2004-07-07 (+44d) |  |  | 14d → -13d |  | baseline start none → 2004-05-28; baseline finish none → 2004-06-01 |
| 642 | **FM 2** | 2004-04-07 → 2004-05-20 (+43d) | 2004-07-09 → 2004-07-30 (+21d) | 67d → 51d |  | 16d → 1d |  | baseline start none → 2004-04-14; baseline finish none → 2004-07-09 |
| 643 | Functional Test of FM 2 Logic Board w/ETU ACTELS | 2004-04-07 → 2004-05-20 (+43d) | 2004-04-27 → 2004-06-10 (+44d) |  |  | 34d → 3d |  | baseline start none → 2004-04-14; baseline finish none → 2004-05-04 |
| 644 | Functional Test of FM 2 Logic Board w/Flight ACTELS | 2004-07-08 → 2004-07-29 (+21d) | 2004-07-09 → 2004-07-30 (+21d) |  |  | 16d → 1d |  | baseline start none → 2004-07-08; baseline finish none → 2004-07-09 |
| 645 | **Mother Board** | 2003-12-22 A | 2004-03-04 → 2004-05-24 (+81d) | 50d → 107d | 0% → 57% | 42d → 2d |  | baseline start none → 2003-12-22; baseline finish none → 2004-03-25 |
| 646 | **Design** | 2003-12-22 A | 2004-01-13 → 2004-03-29 A (+76d) | 15d → 67d | 0% → 100% | 42d → none |  | baseline start none → 2003-12-22; baseline finish none → 2004-02-04 |
| 647 | **FM 1 & FM 2** | 2003-12-22 A | 2004-01-13 → 2004-03-29 A (+76d) | 15d → 67d | 0% → 100% | 42d → none |  | baseline start none → 2003-12-22; baseline finish none → 2004-02-04 |
| 648 | Finalize Mother Board Layout | 2003-12-22 A | 2004-01-13 → 2004-02-04 A (+22d) | 15d → 30d | 0% → 100% | 42d → none |  | baseline start none → 2003-12-22; baseline finish none → 2004-02-04 |
| 650 | **Fabrication** | 2004-01-14 → 2004-02-05 A (+22d) | 2004-02-04 → 2004-04-19 (+75d) | 15d → 52d | 0% → 50% | 42d → -11d |  | baseline start none → 2004-02-05; baseline finish none → 2004-02-26 |
| 651 | **FM 1 & FM 2** | 2004-01-14 → 2004-02-05 A (+22d) | 2004-02-04 → 2004-04-19 (+75d) | 15d → 52d | 0% → 50% | 42d → -11d |  | baseline start none → 2004-02-05; baseline finish none → 2004-02-26 |
| 652 | Fabricate FM 1 & FM 2 Mother Boards | 2004-01-14 → 2004-02-05 A (+22d) | 2004-02-04 → 2004-02-26 A (+22d) |  | 0% → 100% | 42d → none | 648 → none | baseline start none → 2004-02-05; baseline finish none → 2004-02-26 |
| 654 | **Assembly** | 2004-02-05 → 2004-04-27 (+82d) | 2004-02-19 → 2004-05-10 (+81d) |  |  | 42d → -11d |  | baseline start none → 2004-02-27; baseline finish none → 2004-03-11 |

| ID | Task | Start | Finish | Duration | Complete | Total float | Predecessors | Other |
| --- | --- | --- | --- | --- | --- | --- | --- | --- |
| 655 | Assemble FM 1 Mother Board | 2004-02-05 → 2004-04-27 (+82d) | 2004-02-19 → 2004-05-10 (+81d) |  |  | 42d → -11d | 652 → 652, 660 | constraint none → start no earlier than 2004-03-15; baseline start none → 2004-02-27; baseline finish none → 2004-03-11 |
| 656 | Assemble FM 2 Mother Board | 2004-02-05 → 2004-04-27 (+82d) | 2004-02-19 → 2004-05-10 (+81d) |  |  | 64d → 7d |  | baseline start none → 2004-02-27; baseline finish none → 2004-03-11 |
| 657 | **Test** | 2004-02-05 → 2004-02-27 A (+22d) | 2004-03-04 → 2004-05-24 (+81d) | 20d → 62d | 0% → 25% | 52d → 2d |  | baseline start none → 2004-02-27; baseline finish none → 2004-03-25 |
| 658 | **FM 1 & FM 2** | 2004-02-05 → 2004-02-27 A (+22d) | 2004-02-26 → 2004-04-26 (+60d) | 15d → 42d | 0% → 50% | 421d → -11d |  | baseline start none → 2004-02-27; baseline finish none → 2004-03-18 |
| 659 | Coupon Testing of Mother Boards | 2004-02-05 → 2004-02-27 A (+22d) | 2004-02-26 → 2004-03-04 A (+7d) | 15d → 5d | 0% → 100% | 421d → none | 652 → none | baseline start none → 2004-02-27; baseline finish none → 2004-03-18 |
| 661 | **FM 1** | 2004-02-20 → 2004-05-11 (+81d) | 2004-02-26 → 2004-05-17 (+81d) |  |  | 42d → -11d |  | baseline start none → 2004-03-12; baseline finish none → 2004-03-18 |
| 662 | Functional Test FM 1 Mother Board | 2004-02-20 → 2004-05-11 (+81d) | 2004-02-26 → 2004-05-17 (+81d) |  |  | 42d → -11d |  | baseline start none → 2004-03-12; baseline finish none → 2004-03-18 |
| 663 | **FM 2** | 2004-02-27 → 2004-05-18 (+81d) | 2004-03-04 → 2004-05-24 (+81d) |  |  | 59d → 2d |  | baseline start none → 2004-03-19; baseline finish none → 2004-03-25 |
| 664 | Functional Test FM 2 Mother Board | 2004-02-27 → 2004-05-18 (+81d) | 2004-03-04 → 2004-05-24 (+81d) |  |  | 59d → 2d |  | baseline start none → 2004-03-19; baseline finish none → 2004-03-25 |
| 665 | **HVPS** | 2004-01-12 A | 2004-04-08 → 2004-06-08 (+61d) | 62d → 104d | 0% → 75% | 44d → 2d |  | baseline start none → 2004-01-12; baseline finish none → 2004-04-27 |
| 666 | **Test** | 2004-01-12 A | 2004-04-08 → 2004-06-08 (+61d) | 62d → 104d | 0% → 75% | 44d → 2d |  | baseline start none → 2004-01-12; baseline finish none → 2004-04-27 |
| 667 | **FM 1** | 2004-01-12 A | 2004-01-26 → 2004-02-24 A (+29d) | 10d → 30d | 0% → 100% | 61d → none |  | baseline start none → 2004-01-12; baseline finish none → 2004-02-09 |
| 668 | Functional Test SIT FM 1 HVPS | 2004-01-12 A | 2004-01-26 → 2004-02-24 A (+29d) | 10d → 30d | 0% → 100% | 61d → none |  | baseline start none → 2004-01-12; baseline finish none → 2004-02-09 |
| 669 | **FM 2** | 2004-03-26 → 2004-05-25 (+60d) | 2004-04-08 → 2004-06-08 (+61d) |  |  | 44d → 2d |  | baseline start none → 2004-04-14; baseline finish none → 2004-04-27 |
| 670 | Functional Test SIT FM 2 HVPS | 2004-03-26 → 2004-05-25 (+60d) | 2004-04-08 → 2004-06-08 (+61d) |  |  | 44d → 2d |  | baseline start none → 2004-04-14; baseline finish none → 2004-04-27 |
| 671 | **Flight Software** |  |  |  | 70% → 89% | 44d → 48d |  | baseline start none → 2003-06-02; baseline finish none → 2004-04-01 |
| 672 | **Test** |  |  |  | 70% → 89% | 44d → 48d |  | baseline start none → 2003-06-02; baseline finish none → 2004-04-01 |
| 673 | **FM 1 & FM 2** |  |  |  | 70% → 89% | 44d → 48d |  | baseline start none → 2003-06-02; baseline finish none → 2004-04-01 |
| 674 | Validate SIT On-Board Code |  |  |  | 70% → 89% | 44d → 48d |  | baseline start none → 2003-06-02; baseline finish none → 2004-04-01 |
| 675 | **Integration & Test (using ETU Telescope for FM 1)** | 2004-03-08 → 2004-02-25 A (-12d) | 2004-07-22 → 2004-08-12 (+21d) | 98d → 121d | 0% → 4% | 16d → 1d |  | baseline start none → 2004-03-31; baseline finish none → 2004-07-22 |
| 676 | **FM 1 (Flight Telescope)** | 2004-05-25 → 2004-07-08 (+44d) | 2004-06-10 → 2004-07-23 (+43d) |  |  | 14d → -13d |  | baseline start none → 2004-06-02; baseline finish none → 2004-06-17 |
| 677 | Disassemble SIT FM 1 | 2004-05-25 → 2004-07-08 (+44d) | 2004-05-25 → 2004-07-08 (+44d) |  |  | 14d → -13d |  | baseline start none → 2004-06-02; baseline finish none → 2004-06-02 |
| 678 | Conformal Coat SIT FM 1 Boards (includes FM 1 LVPS) | 2004-05-26 → 2004-07-09 (+44d) | 2004-05-27 → 2004-07-12 (+46d) |  |  | 14d → -13d |  | was named Conformal Coat SIT FM 1 Boards; baseline start none → 2004-06-03; baseline finish none → 2004-06-04 |
| 679 | Reassemble SIT FM 1 with Flight Telescope | 2004-05-28 → 2004-07-13 (+46d) | 2004-05-28 → 2004-07-13 (+46d) |  |  | 14d → -13d | 678, 398 → 678, 398, 364 | baseline start none → 2004-06-07; baseline finish none → 2004-06-07 |
| 680 | Bench Calibration SIT FM 1 w/Flight Telescope | 2004-06-01 → 2004-07-14 (+43d) | 2004-06-03 → 2004-07-16 (+43d) |  |  | 14d → -13d |  | baseline start none → 2004-06-08; baseline finish none → 2004-06-10 |
| 681 | Vacuum Test SIT FM 1 w/Flight Telescope | 2004-06-04 → 2004-07-19 (+45d) | 2004-06-10 → 2004-07-23 (+43d) |  |  | 14d → -13d |  | baseline start none → 2004-06-11; baseline finish none → 2004-06-17 |
| 682 | **FM 2** | 2004-07-12 → 2004-08-02 (+21d) | 2004-07-22 → 2004-08-12 (+21d) |  |  | 16d → 1d |  | baseline start none → 2004-07-12; baseline finish none → 2004-07-22 |
| 683 | Disassemble SIT FM 2 | 2004-07-12 → 2004-08-02 (+21d) | 2004-07-12 → 2004-08-02 (+21d) |  |  | 16d → 1d |  | baseline start none → 2004-07-12; baseline finish none → 2004-07-12 |
| 684 | Conformal Coat SIT FM 2 Boards | 2004-07-13 → 2004-08-03 (+21d) | 2004-07-14 → 2004-08-04 (+21d) |  |  | 16d → 1d |  | baseline start none → 2004-07-13; baseline finish none → 2004-07-14 |
| 685 | Reassemble SIT FM 2 | 2004-07-15 → 2004-08-05 (+21d) | 2004-07-15 → 2004-08-05 (+21d) |  |  | 16d → 1d |  | baseline start none → 2004-07-15; baseline finish none → 2004-07-15 |
| 686 | Post-Coat Retest SIT FM 2 | 2004-07-16 → 2004-08-06 (+21d) | 2004-07-22 → 2004-08-12 (+21d) |  |  | 16d → 1d |  | baseline start none → 2004-07-16; baseline finish none → 2004-07-22 |
| 687 | **FM 1 (ETU Telescope)** | 2004-03-08 → 2004-02-25 A (-12d) | 2004-05-14 → 2004-06-29 (+46d) | 50d → 89d | 0% → 10% | 14d → -13d |  | baseline start none → 2004-03-31; baseline finish none → 2004-05-21 |
| 688 | Integrate SIT FM 1 HVPS and SIT ETU Telescope Without Electronics | 2004-03-08 → 2004-02-25 A (-12d) | 2004-03-10 → 2004-02-27 A (-12d) |  | 0% → 100% | 33d → none | 668, Alpha Tests FM 1 w/Proto Elect → 668 | baseline start none → 2004-03-31; baseline finish none → 2004-04-02 |
| 689 | Integrate Electronics to SIT ETU Telescope | 2004-04-07 → 2004-05-20 (+43d) | 2004-04-08 → 2004-05-21 (+43d) |  |  | 14d → -13d |  | baseline start none → 2004-04-14; baseline finish none → 2004-04-15 |
| 690 | SIT FM 1 Debug | 2004-04-09 → 2004-05-24 (+45d) | 2004-04-15 → 2004-05-28 (+43d) |  |  | 14d → -13d |  | baseline start none → 2004-04-16; baseline finish none → 2004-04-22 |
| 691 | SIT FM 1 Bench Test | 2004-04-16 → 2004-06-01 (+46d) | 2004-04-22 → 2004-06-07 (+46d) |  |  | 14d → -13d |  | baseline start none → 2004-04-23; baseline finish none → 2004-04-29 |
| 692 | SIT FM 1 Alpha TEST | 2004-04-23 → 2004-06-08 (+46d) | 2004-04-29 → 2004-06-14 (+46d) |  |  | 14d → -13d |  | baseline start none → 2004-04-30; baseline finish none → 2004-05-06 |
| 693 | SIT FM 1 Noise Removal | 2004-04-30 → 2004-06-15 (+46d) | 2004-05-06 → 2004-06-21 (+46d) |  |  | 14d → -13d |  | baseline start none → 2004-05-07; baseline finish none → 2004-05-13 |
| 694 | SIT FM 1 Thermal Test | 2004-05-07 → 2004-06-22 (+46d) | 2004-05-13 → 2004-06-28 (+46d) |  |  | 14d → -13d |  | baseline start none → 2004-05-14; baseline finish none → 2004-05-20 |
| 695 | SIT FM 1 Functional Test | 2004-05-14 → 2004-06-29 (+46d) | 2004-05-14 → 2004-06-29 (+46d) |  |  | 14d → -13d |  | baseline start none → 2004-05-21; baseline finish none → 2004-05-21 |
| 696 | **FM 2** | 2004-05-19 → 2004-06-10 (+22d) | 2004-07-01 → 2004-07-22 (+21d) |  |  | 16d → 1d |  | baseline start none → 2004-05-19; baseline finish none → 2004-07-01 |
| 697 | Integrate SIT FM 2 HVPS and SIT FM 2 Telescope Without Electronics | 2004-05-19 → 2004-06-10 (+22d) | 2004-05-21 → 2004-06-14 (+24d) |  |  | 16d → 1d | 670, Alpha Tests FM 2 w/Proto Elect, 398 → 670, 398, 364 | baseline start none → 2004-05-19; baseline finish none → 2004-05-21 |
| 698 | Integrate Electronics to SIT FM 2 Telescope | 2004-05-24 → 2004-06-15 (+22d) | 2004-05-25 → 2004-06-16 (+22d) |  |  | 16d → 1d |  | baseline start none → 2004-05-24; baseline finish none → 2004-05-25 |
| 699 | SIT FM 2 Debug | 2004-05-26 → 2004-06-17 (+22d) | 2004-06-02 → 2004-06-23 (+21d) |  |  | 16d → 1d |  | baseline start none → 2004-05-26; baseline finish none → 2004-06-02 |
| 700 | SIT FM 2 Bench Test | 2004-06-03 → 2004-06-24 (+21d) | 2004-06-09 → 2004-06-30 (+21d) |  |  | 16d → 1d |  | baseline start none → 2004-06-03; baseline finish none → 2004-06-09 |
| 701 | SIT FM 2 Alpha Test | 2004-06-10 → 2004-07-01 (+21d) | 2004-06-16 → 2004-07-07 (+21d) |  |  | 16d → 1d |  | baseline start none → 2004-06-10; baseline finish none → 2004-06-16 |
| 702 | SIT FM 2 Noise Removal | 2004-06-17 → 2004-07-08 (+21d) | 2004-06-23 → 2004-07-14 (+21d) |  |  | 16d → 1d |  | baseline start none → 2004-06-17; baseline finish none → 2004-06-23 |
| 703 | SIT FM 2 Thermal Test | 2004-06-24 → 2004-07-15 (+21d) | 2004-06-30 → 2004-07-21 (+21d) |  |  | 16d → 1d |  | baseline start none → 2004-06-24; baseline finish none → 2004-06-30 |
| 704 | SIT FM 2 Functional Test | 2004-07-01 → 2004-07-22 (+21d) | 2004-07-01 → 2004-07-22 (+21d) |  |  | 16d → 1d |  | baseline start none → 2004-07-01; baseline finish none → 2004-07-01 |
| 707 | **Environmental Testing at GSFC (FM 1)** | 2004-07-08 → 2004-08-23 (+46d) | 2004-08-24 → 2004-10-08 (+45d) |  |  | 29d → -3d |  | baseline start none → 2004-07-15; baseline finish none → 2004-08-31 |
| 708 | SIT FM 1 Vibration and Acoustics | 2004-07-08 → 2004-08-23 (+46d) | 2004-07-21 → 2004-09-03 (+44d) |  |  | 29d → -3d | 589 → 589, 705 | constraint none → start no earlier than 2004-08-23; baseline start none → 2004-07-15; baseline finish none → 2004-07-28 |
| 709 | Functional Test | 2004-07-22 → 2004-09-07 (+47d) | 2004-07-22 → 2004-09-07 (+47d) |  |  | 29d → -3d |  | baseline start none → 2004-07-29; baseline finish none → 2004-07-29 |
| 710 | SIT FM 1 Thermal Balance | 2004-07-23 → 2004-09-08 (+47d) | 2004-07-29 → 2004-09-14 (+47d) |  |  | 29d → -3d |  | baseline start none → 2004-07-30; baseline finish none → 2004-08-05 |
| 711 | SIT FM 1 Thermal Vac | 2004-07-30 → 2004-09-15 (+47d) | 2004-08-12 → 2004-09-28 (+47d) |  |  | 29d → -3d |  | baseline start none → 2004-08-06; baseline finish none → 2004-08-19 |
| 712 | Disassemble SIT Instruments | 2004-08-13 → 2004-09-29 (+47d) | 2004-08-16 → 2004-09-30 (+45d) |  |  | 29d → -3d |  | baseline start none → 2004-08-20; baseline finish none → 2004-08-23 |
| 713 | Bake Out | 2004-08-17 → 2004-10-01 (+45d) | 2004-08-19 → 2004-10-05 (+47d) |  |  | 29d → -3d |  | baseline start none → 2004-08-24; baseline finish none → 2004-08-26 |
| 714 | Reassemble Instruments | 2004-08-20 → 2004-10-06 (+47d) | 2004-08-23 → 2004-10-07 (+45d) |  |  | 29d → -3d |  | baseline start none → 2004-08-27; baseline finish none → 2004-08-30 |
| 715 | Functional Test | 2004-08-24 → 2004-10-08 (+45d) | 2004-08-24 → 2004-10-08 (+45d) |  |  | 29d → -3d |  | baseline start none → 2004-08-31; baseline finish none → 2004-08-31 |
| 716 | **Environmental Testing at GSFC (FM 2)** | 2004-08-16 → 2004-09-02 (+17d) | 2004-10-01 → 2004-10-21 (+20d) |  |  | 16d → 3d |  | baseline start none → 2004-08-23; baseline finish none → 2004-10-08 |
| 717 | SIT FM 2 Vibration and Acoustics | 2004-08-16 → 2004-09-02 (+17d) | 2004-08-27 → 2004-09-16 (+20d) |  |  | 16d → 3d |  | constraint none → start no earlier than 2004-09-02; baseline start none → 2004-08-23; baseline finish none → 2004-09-03 |
| 718 | Functional Test | 2004-08-30 → 2004-09-17 (+18d) | 2004-08-30 → 2004-09-17 (+18d) |  |  | 16d → 3d |  | baseline start none → 2004-09-07; baseline finish none → 2004-09-07 |
| 719 | SIT FM 2 Thermal Balance | 2004-08-31 → 2004-09-20 (+20d) | 2004-09-07 → 2004-09-24 (+17d) |  |  | 16d → 3d |  | baseline start none → 2004-09-08; baseline finish none → 2004-09-14 |
| 720 | SIT FM 2 Thermal Vac | 2004-09-08 → 2004-09-27 (+19d) | 2004-09-21 → 2004-10-08 (+17d) |  |  | 16d → 3d |  | baseline start none → 2004-09-15; baseline finish none → 2004-09-28 |
| 721 | Disassemble SIT Instruments | 2004-09-22 → 2004-10-12 (+20d) | 2004-09-23 → 2004-10-13 (+20d) |  |  | 16d → 3d |  | baseline start none → 2004-09-29; baseline finish none → 2004-09-30 |
| 722 | Bake Out | 2004-09-24 → 2004-10-14 (+20d) | 2004-09-28 → 2004-10-18 (+20d) |  |  | 16d → 3d |  | baseline start none → 2004-10-01; baseline finish none → 2004-10-05 |
| 723 | Reassemble Instruments | 2004-09-29 → 2004-10-19 (+20d) | 2004-09-30 → 2004-10-20 (+20d) |  |  | 16d → 3d |  | baseline start none → 2004-10-06; baseline finish none → 2004-10-07 |
| 724 | Functional Test | 2004-10-01 → 2004-10-21 (+20d) | 2004-10-01 → 2004-10-21 (+20d) |  |  | 16d → 3d |  | baseline start none → 2004-10-08; baseline finish none → 2004-10-08 |
| 725 | **Emulators/Simulators/GSE** |  | 2004-10-20 → 2004-10-13 (-7d) | 214d → 209d | 9% → 10% | 255d → 9d |  | baseline start none → 2003-12-17; baseline finish none → 2004-10-20 |
| 726 | **Simulators** |  |  |  |  | 389d → 98d |  | baseline start none → 2003-12-17; baseline finish none → 2004-04-12 |
| 727 | Labview CPU Ready |  |  |  |  | 389d → 0d |  | constraint start no earlier than 2003-12-17 → must start on 2003-12-17; baseline start none → 2003-12-17; baseline finish none → 2004-04-12 |

| ID | Task | Start | Finish | Duration | Complete | Total float | Predecessors | Other |
| --- | --- | --- | --- | --- | --- | --- | --- | --- |
| 728 | Test Simulator |  |  |  |  | 389d → 98d |  | baseline start none → 2003-12-17; baseline finish none → 2004-04-12 |
| 729 | **GSE** | 2004-07-27 → 2004-08-17 (+21d) | 2004-10-20 → 2004-10-13 (-7d) | 60d → 40d |  | 255d → 9d |  | baseline start none → 2004-07-27; baseline finish none → 2004-10-20 |
| 730 | Pulse Generator | 2004-07-27 → 2004-08-17 (+21d) | 2004-10-20 → 2004-10-13 (-7d) | 60d → 40d |  | 255d → 9d | 588, 591 → 588, 591, 728 | baseline start none → 2004-07-27; baseline finish none → 2004-10-20 |
| 731 | **SEP Suite I&T - CIT** |  | 2004-10-15 → 2004-10-26 (+11d) | 305d → 312d | 31% → 39% | 258d → 2d |  | baseline start none → 2003-08-01; baseline finish none → 2004-10-21 |
| 732 | **ETU** | 2004-02-23 → 2004-01-26 A (-28d) | 2004-02-27 → 2004-01-30 A (-28d) |  | 0% → 100% | 420d → none |  | baseline start none → 2004-01-26; baseline finish none → 2004-01-30 |
| 733 | Complete Integration/Test of SEP Central EM with Sensors | 2004-02-23 → 2004-01-26 A (-28d) | 2004-02-27 → 2004-01-30 A (-28d) |  | 0% → 100% | 420d → none |  | constraint start no earlier than 2004-02-23 → start no earlier than 2004-01-26; baseline start none → 2004-01-26; baseline finish none → 2004-01-30 |
| 734 | **FM 1 & FM 2** | 2004-03-08 → 2004-03-09 (+1d) | 2004-10-12 → 2004-07-22 (-82d) | 154d → 97d |  | 74d → -8d |  | baseline start none → 2004-03-05; baseline finish none → 2004-10-21 |
| 735 | Generate SEPT integration & test procedure | 2004-03-08 → 2004-03-09 (+1d) | 2004-03-12 → 2004-03-15 (+3d) |  |  | 75d → 78d |  | baseline start none → 2004-03-05; baseline finish none → 2004-03-11 |
| 736 | Generate LET integration & test procedure | 2004-04-26 → 2004-06-16 (+51d) | 2004-04-30 → 2004-06-22 (+53d) |  |  | 41d → 9d |  | baseline start none → 2004-05-05; baseline finish none → 2004-05-11 |
| 737 | Generate HET integration & test procedure | 2004-05-19 → 2004-06-28 (+40d) | 2004-05-25 → 2004-07-02 (+38d) |  |  | 25d → 2d |  | baseline start none → 2004-05-20; baseline finish none → 2004-05-26 |
| 738 | Generate SIT integration & test procedure | 2004-06-02 → 2004-07-15 (+43d) | 2004-06-08 → 2004-07-21 (+43d) |  |  | 19d → -8d |  | baseline start none → 2004-06-09; baseline finish none → 2004-06-15 |
| 739 | Generate SEP system test procedure | 2004-06-03 → 2004-07-16 (+43d) | 2004-06-09 → 2004-07-22 (+43d) |  |  | 19d → -8d |  | baseline start none → 2004-06-10; baseline finish none → 2004-06-16 |
| 740 | Generate SEP-IDPU integration procedure | 2004-05-20 → 2004-07-08 (+49d) | 2004-05-26 → 2004-07-14 (+49d) |  |  | 21d → -9d |  | baseline start none → 2004-05-27; baseline finish none → 2004-06-03 |
| 741 | Generate SEP-IDPU test procedure | 2004-05-27 → 2004-07-15 (+49d) | 2004-06-03 → 2004-07-21 (+48d) |  |  | 21d → -9d |  | baseline start none → 2004-06-04; baseline finish none → 2004-06-10 |
| 742 | **FM 1** | 2004-03-19 → 2004-03-22 (+3d) | 2004-06-21 → 2004-08-03 (+43d) | 66d → 96d |  | 14d → -13d |  | baseline start none → 2004-03-18; baseline finish none → 2004-06-28 |
| 743 | Integrate/test SEP Central FM 1 | 2004-04-30 → 2004-06-22 (+53d) | 2004-05-06 → 2004-06-28 (+53d) |  |  | 36d → 4d |  | baseline start none → 2004-05-11; baseline finish none → 2004-05-17 |
| 744 | Receive & inspect SEPT FM 1 | 2004-03-19 → 2004-03-22 (+3d) | 2004-03-19 → 2004-03-22 (+3d) |  |  | 70d → 73d |  | baseline start none → 2004-03-18; baseline finish none → 2004-03-18 |
| 745 | Integrate & test SEPT FM 1 | 2004-05-07 → 2004-06-29 (+53d) | 2004-05-07 → 2004-06-29 (+53d) |  |  | 36d → 4d |  | baseline start none → 2004-05-18; baseline finish none → 2004-05-18 |
| 746 | Integrate & test LET FM 1 | 2004-05-28 → 2004-07-20 (+53d) | 2004-05-28 → 2004-07-20 (+53d) |  |  | 22d → -10d |  | baseline start none → 2004-06-09; baseline finish none → 2004-06-09 |
| 747 | Receive & inspect HET FM 1 | 2004-06-02 → 2004-07-09 (+37d) | 2004-06-02 → 2004-07-09 (+37d) |  |  | 20d → -3d |  | baseline start none → 2004-06-03; baseline finish none → 2004-06-03 |
| 748 | Integrate & test HET FM 1 | 2004-06-03 → 2004-07-21 (+48d) | 2004-06-03 → 2004-07-21 (+48d) |  |  | 20d → -10d |  | baseline start none → 2004-06-10; baseline finish none → 2004-06-10 |
| 749 | Integrate SEP FM 1 - IDPU FM 1 | 2004-06-04 → 2004-07-22 (+48d) | 2004-06-04 → 2004-07-22 (+48d) |  |  | 20d → -10d |  | baseline start none → 2004-06-11; baseline finish none → 2004-06-11 |
| 750 | Test SEP FM 1 - IDPU FM 1 | 2004-06-07 → 2004-07-23 (+46d) | 2004-06-07 → 2004-07-23 (+46d) |  |  | 20d → -10d |  | baseline start none → 2004-06-22; baseline finish none → 2004-06-22 |
| 751 | Receive & inspect SIT FM 1 | 2004-06-15 → 2004-07-28 (+43d) | 2004-06-15 → 2004-07-28 (+43d) |  |  | 14d → -13d |  | baseline start none → 2004-06-22; baseline finish none → 2004-06-22 |
| 752 | Integrate & test SIT FM 1 | 2004-06-16 → 2004-07-29 (+43d) | 2004-06-16 → 2004-07-29 (+43d) |  |  | 14d → -13d |  | baseline start none → 2004-06-23; baseline finish none → 2004-06-23 |
| 753 | SEP system test FM 1 | 2004-06-17 → 2004-07-30 (+43d) | 2004-06-21 → 2004-08-03 (+43d) |  |  | 14d → -13d |  | baseline start none → 2004-06-24; baseline finish none → 2004-06-28 |
| 754 | **FM 2** | 2004-03-15 → 2004-03-25 (+10d) | 2004-08-04 → 2004-08-23 (+19d) | 102d → 107d |  | 14d → 2d |  | baseline start none → 2004-03-29; baseline finish none → 2004-08-11 |
| 755 | Integrate/testSEP Central FM 2 | 2004-04-30 → 2004-06-22 (+53d) | 2004-05-06 → 2004-06-28 (+53d) |  |  | 50d → 37d |  | baseline start none → 2004-05-11; baseline finish none → 2004-05-17 |
| 756 | Receive & inspect SEPT FM 2 | 2004-03-15 → 2004-03-25 (+10d) | 2004-03-15 → 2004-03-25 (+10d) |  |  | 88d → 103d |  | baseline start none → 2004-03-29; baseline finish none → 2004-03-29 |
| 757 | Integrate & test SEPT FM 2 | 2004-05-07 → 2004-06-29 (+53d) | 2004-05-07 → 2004-06-29 (+53d) |  |  | 50d → 37d |  | baseline start none → 2004-05-18; baseline finish none → 2004-05-18 |
| 758 | Integrate & test LET FM 2 | 2004-05-28 → 2004-07-20 (+53d) | 2004-05-28 → 2004-07-20 (+53d) |  |  | 36d → 23d |  | baseline start none → 2004-06-09; baseline finish none → 2004-06-09 |
| 759 | Receive & inspect HET FM 2 | 2004-06-23 → 2004-07-30 (+37d) | 2004-06-23 → 2004-07-30 (+37d) |  |  | 19d → 15d |  | baseline start none → 2004-06-24; baseline finish none → 2004-06-24 |
| 760 | Integrate & test HET FM 2 | 2004-06-24 → 2004-08-02 (+39d) | 2004-06-24 → 2004-08-02 (+39d) |  |  | 19d → 15d |  | baseline start none → 2004-06-25; baseline finish none → 2004-06-25 |
| 761 | Integrate SEP FM 2 - IDPU FM 2 | 2004-06-25 → 2004-08-03 (+39d) | 2004-06-25 → 2004-08-03 (+39d) |  |  | 19d → 15d |  | baseline start none → 2004-06-28; baseline finish none → 2004-06-28 |
| 762 | Test SEP FM 2 - IDPU FM 2 | 2004-06-28 → 2004-08-04 (+37d) | 2004-06-28 → 2004-08-04 (+37d) |  |  | 19d → 15d |  | baseline start none → 2004-06-29; baseline finish none → 2004-06-29 |
| 763 | Receive & inspect SIT FM 2 | 2004-07-27 → 2004-08-17 (+21d) | 2004-07-27 → 2004-08-17 (+21d) |  |  | 16d → 1d |  | baseline start none → 2004-07-27; baseline finish none → 2004-07-27 |
| 764 | Integrate & test SIT FM 2 | 2004-07-30 → 2004-08-18 (+19d) | 2004-07-30 → 2004-08-18 (+19d) |  |  | 14d → 1d | 738, 763, 778 → 738, 763 | baseline start none → 2004-08-06; baseline finish none → 2004-08-06 |
| 765 | SEP FM 2 system test | 2004-08-02 → 2004-08-19 (+17d) | 2004-08-04 → 2004-08-23 (+19d) |  |  | 14d → 1d |  | baseline start none → 2004-08-09; baseline finish none → 2004-08-11 |
| 766 | **Environmental Test (at JPL)** |  | 2004-09-17 → 2004-10-26 (+39d) | 88d → 114d |  | 28d → 2d |  | baseline start none → 2004-05-17; baseline finish none → 2004-09-24 |
| 767 | Generate Environmental Test Procedures |  |  |  |  |  |  | baseline start none → 2004-05-17; baseline finish none → 2004-06-07 |
| 768 | Manufacture test cables (JPL) |  |  |  |  |  |  | baseline start none → 2004-06-01; baseline finish none → 2004-06-28 |
| 769 | **FM 1** | 2004-07-16 → 2004-08-30 (+45d) | 2004-09-17 → 2004-10-26 (+39d) | 45d → 40d |  | 14d → -13d |  | baseline start none → 2004-07-23; baseline finish none → 2004-09-24 |
| 770 | FM 1 LET/HET/SEP Central Vibration/Acoustics Test | 2004-07-16 → 2004-08-30 (+45d) | 2004-07-29 → 2004-09-13 (+46d) |  |  | 18d → -13d |  | baseline start none → 2004-07-23; baseline finish none → 2004-08-05 |
| 771 | FM 1 LET/HET/SEP Central Thermal Balance Test | 2004-07-30 → 2004-09-14 (+46d) | 2004-08-05 → 2004-09-20 (+46d) |  |  | 18d → -13d |  | baseline start none → 2004-08-06; baseline finish none → 2004-08-12 |
| 772 | FM 1 LET/HET/SEP Central T/V Test | 2004-08-12 → 2004-09-21 (+40d) | 2004-09-01 → 2004-10-12 (+41d) |  |  | 14d → -13d |  | baseline start none → 2004-08-19; baseline finish none → 2004-09-09 |
| 773 | Evaluate SEP performance | 2004-09-02 → 2004-10-13 (+41d) | 2004-09-16 → 2004-10-26 (+40d) |  |  | 14d → -13d |  | baseline start none → 2004-09-10; baseline finish none → 2004-09-23 |
| 774 | Generate test reports | 2004-09-02 → 2004-09-23 (+21d) | 2004-09-17 → 2004-10-07 (+20d) |  |  | 14d → -13d |  | baseline start none → 2004-09-10; baseline finish none → 2004-09-24 |
| 775 | Bakeout Clean SEP exterior & prepare for delivery | 2004-09-02 → 2004-10-13 (+41d) | 2004-09-07 → 2004-10-15 (+38d) |  |  | 21d → -6d |  | baseline start none → 2004-09-10; baseline finish none → 2004-09-14 |
| 776 | **FM 2** | 2004-07-16 → 2004-08-24 (+39d) | 2004-09-17 → 2004-10-21 (+34d) | 45d → 41d |  | 14d → 1d |  | baseline start none → 2004-07-23; baseline finish none → 2004-09-24 |
| 777 | FM 2 EMI/EMC Test at CalTech | 2004-08-05 → 2004-08-24 (+19d) | 2004-08-11 → 2004-08-30 (+19d) |  |  | 14d → 1d |  | baseline start none → 2004-08-12; baseline finish none → 2004-08-18 |
| 778 | FM 2 LET/HET/SEP Central Vibration/Acoustics Test | 2004-07-16 → 2004-08-31 (+46d) | 2004-07-29 → 2004-09-14 (+47d) |  |  | 14d → 5d | 785FS+3d → 785FS+3d, 777 | baseline start none → 2004-07-23; baseline finish none → 2004-08-05 |
| 779 | FM 2 LET/HET/SEP Central T/V Test | 2004-08-12 → 2004-09-15 (+34d) | 2004-09-01 → 2004-10-05 (+34d) |  |  | 28d → 5d | 777 → 777, 778 | baseline start none → 2004-08-19; baseline finish none → 2004-09-09 |
| 780 | Evaluate SEP performance | 2004-09-02 → 2004-10-06 (+34d) | 2004-09-16 → 2004-10-20 (+34d) |  |  | 28d → 5d |  | baseline start none → 2004-09-10; baseline finish none → 2004-09-23 |
| 781 | Generate test reports | 2004-09-02 → 2004-10-06 (+34d) | 2004-09-17 → 2004-10-21 (+34d) |  |  | 28d → 5d |  | baseline start none → 2004-09-10; baseline finish none → 2004-09-24 |
| 782 | Bakeout Clean SEP exterior & prepare for delivery | 2004-09-02 → 2004-10-06 (+34d) | 2004-09-07 → 2004-10-08 (+31d) |  |  | 35d → 12d |  | baseline start none → 2004-09-10; baseline finish none → 2004-09-14 |
| 783 | **Accelerator Test (at MSU)** | 2004-07-06 → 2004-08-18 (+43d) | 2004-07-12 → 2004-08-24 (+43d) |  |  | 14d → -13d |  | baseline start none → 2004-07-13; baseline finish none → 2004-07-19 |
| 784 | FM 1 LET/SEP Cen end-to-end test at Accelerator | 2004-07-06 → 2004-08-18 (+43d) | 2004-07-12 → 2004-08-24 (+43d) |  |  | 14d → -13d |  | baseline start none → 2004-07-13; baseline finish none → 2004-07-19 |
| 785 | FM 2 LET/SEP Cen end-to-end test at Accelerator | 2004-07-06 → 2004-08-18 (+43d) | 2004-07-12 → 2004-08-24 (+43d) |  |  | 14d → 6d |  | baseline start none → 2004-07-13; baseline finish none → 2004-07-19 |
| 786 | **GSE** |  |  |  |  | 258d → 9d |  | baseline start none → 2003-08-01; baseline finish none → 2004-10-15 |
| 787 | **End-to-End Test Equipment** |  |  |  |  | 23d → 27d |  | baseline start none → 2003-08-11; baseline finish none → 2004-06-22 |
| 788 | Design |  |  |  |  | 23d → 27d |  | baseline start none → 2003-08-11; baseline finish none → 2004-05-14 |
| 789 | Assemble |  |  |  |  | 23d → 27d |  | baseline start none → 2004-05-17; baseline finish none → 2004-06-15 |
| 790 | Test |  |  |  |  | 23d → 27d |  | baseline start none → 2004-06-16; baseline finish none → 2004-06-22 |
| 791 | **GSE software** |  |  |  |  | 258d → 9d |  | baseline start none → 2003-08-01; baseline finish none → 2004-10-15 |
| 792 | Build GSE software release 2 |  |  |  |  | 281d → 0d |  | constraint start no earlier than 2003-08-01 → must start on 2003-08-01; baseline start none → 2003-08-01; baseline finish none → 2004-03-18 |
| 793 | Write user's guide |  |  |  |  | 280d → 31d |  | baseline start none → 2004-03-22; baseline finish none → 2004-03-31 |
| 794 | Build GSE software release 3 |  |  |  |  | 258d → 9d |  | baseline start none → 2004-05-03; baseline finish none → 2004-10-15 |
| 795 | Write user's guide supplement |  |  |  |  | 258d → 9d |  | constraint none → finish no later than 2004-10-28; baseline start none → 2004-09-15; baseline finish none → 2004-10-15 |
| 796 | **SWEA and SIT Refurbishment (after S/C Environmental Testing)** |  | 2005-10-14 → 2005-11-21 (+38d) | 14d → 40d |  |  |  | baseline start none → 2005-09-27; baseline finish none → 2005-11-18 |
| 797 | Ship SWEA FM 1 to UCB |  |  |  |  | 0d → 25d |  | baseline start none → 2005-09-27; baseline finish none → 2005-09-29 |

| ID | Task | Start | Finish | Total float | Predecessors | Other |
| --- | --- | --- | --- | --- | --- | --- |
| 798 | Ship (Hand Carry) SIT FM 1 to UMD |  |  | 2d → 27d |  | baseline start none → 2005-09-27; baseline finish none → 2005-09-27 |
| 799 | Ship SWEA FM 2 to UCB |  |  | 1d → 20d |  | baseline start none → 2005-10-04; baseline finish none → 2005-10-06 |
| 800 | Ship (Hand Carry) SIT FM 2 to UMD |  |  | 3d → 22d |  | baseline start none → 2005-10-04; baseline finish none → 2005-10-04 |
| 801 | Vacuum Testing of SWEA FM 1 @ UCB |  |  | 0d → 25d |  | baseline start none → 2005-09-30; baseline finish none → 2005-10-06 |
| 802 | Vacuum Testing of SIT FM 1 @ UMD |  |  | 2d → 27d |  | baseline start none → 2005-09-28; baseline finish none → 2005-10-04 |
| 803 | Vacuum Testing of SWEA FM 2 @ UCB |  |  | 1d → 20d |  | baseline start none → 2005-10-07; baseline finish none → 2005-10-13 |
| 804 | Vacuum Testing of SIT FM 2 @ UMD |  |  | 3d → 22d |  | baseline start none → 2005-10-05; baseline finish none → 2005-10-11 |
| 805 | Ship SWEA FM 1 & 2 to Launch Site for Re-integration to S/C | 2005-10-07 → 2005-10-14 (+7d) | 2005-10-11 → 2005-10-18 (+7d) | 0d → 20d | 801 → 801, 803 | baseline start none → 2005-10-07; baseline finish none → 2005-10-11 |
| 806 | Ship SIT FM 1 & 2 to Launch Site for Re-integration to S/C | 2005-10-05 → 2005-10-12 (+7d) | 2005-10-07 → 2005-10-14 (+7d) | 2d → 22d | 802 → 802, 804 | baseline start none → 2005-10-05; baseline finish none → 2005-10-07 |
| 807 | Reintegration of SWEA and SIT to S/C (at Launch Site) | 2005-10-12 → 2005-10-19 (+7d) | 2005-10-14 → 2005-10-21 (+7d) | 0d → 20d |  | constraint finish no later than 2005-11-18 → none; baseline start none → 2005-10-12; baseline finish none → 2005-10-14 |

## Version 3 (data date 2004-04-30, saved 2004-07-27, file IMPACT Master Schedule_ IMPACT Monthly.mpp)

Last finish stays 2005-11-21. Complete tasks 147 → 306.

Added:

| ID | Task | Duration | Start | Finish | Predecessors | Constraint |
| --- | --- | --- | --- | --- | --- | --- |
| 144 | Bakeout SEP LVPS FM 2 Boards | 3d | 2004-08-05 | 2004-08-09 | 143 |  |
| 157 | **Replacement of LTC1877s** | 15.5d | 2004-08-18 | 2004-09-10 |  |  |
| 158 | Receive new parts | 0d | 2004-08-18 | 2004-08-18 |  | finish no earlier than 2004-08-18 |
| 159 | **FM 1** | 12.5d | 2004-08-19 | 2004-09-07 | 158 |  |
| 160 | **IDPU w/ replacement part** | 6.5d | 2004-08-20 | 2004-08-30 |  |  |
| 161 | Replace LTC1877 | 0.5d | 2004-08-20 | 2004-08-20 | 185 |  |
| 162 | Test IDPU FM 1 LVPS | 1d | 2004-08-23 | 2004-08-23 | 161 |  |
| 163 | Coat & Stake IDPU LVPS FM 1 Boards | 3d | 2004-08-24 | 2004-08-26 | 162 |  |
| 164 | Retest/Reassenble IDPU LVPS FM 1 Boards | 2d | 2004-08-27 | 2004-08-30 | 163 |  |
| 165 | **SEP w/ replacement part** | 7.5d | 2004-08-19 | 2004-08-30 |  |  |
| 166 | Receive SEP FM 1 LVPS from CIT | 1d | 2004-08-19 | 2004-08-19 |  |  |
| 167 | Replace LTC1877 | 0.5d | 2004-08-23 | 2004-08-23 | 166, 161 |  |
| 168 | Test SEP FM 1 LVPS | 1d | 2004-08-23 | 2004-08-24 | 167 |  |
| 169 | Coat & Stake SEP LVPS FM 1 Boards | 2d | 2004-08-24 | 2004-08-26 | 168 |  |
| 170 | Retest/ Reassmeble SEP LVPS FM 1 Boards | 2d | 2004-08-26 | 2004-08-30 | 169 |  |
| 171 | **SWEA w/ replacement part** | 6.5d | 2004-08-23 | 2004-08-31 |  |  |
| 172 | Replace LTC1877 | 0.5d | 2004-08-23 | 2004-08-23 | 167 |  |
| 173 | Test SWEA FM 1 LVPS | 1d | 2004-08-24 | 2004-08-24 | 172 |  |
| 174 | Coat & Stake SWEA LVPS FM 1 Boards | 3d | 2004-08-25 | 2004-08-27 | 173 |  |
| 175 | Retest/ Reassmeble SWEA LVPS FM 1 Boards | 2d | 2004-08-30 | 2004-08-31 | 174 |  |
| 176 | **PLASTIC w/ replacement part** | 6.5d | 2004-08-27 | 2004-09-07 |  |  |
| 177 | Receive PLASTIC FM 1 LVPS from UNH | 0.5d | 2004-08-27 | 2004-08-27 |  | start no earlier than 2004-08-27 |
| 178 | Replace LTC1877 | 1d | 2004-08-27 | 2004-08-30 | 177, 172 |  |
| 179 | Test PLASTIC FM 1 LVPS | 1d | 2004-08-30 | 2004-08-31 | 178 |  |
| 180 | Coat & Stake PLASTIC LVPS FM 1 Boards | 2d | 2004-08-31 | 2004-09-02 | 179 |  |
| 181 | Retest/ Reassmeble PLASTIC LVPS FM 1 Boards | 2d | 2004-09-02 | 2004-09-07 | 180 |  |
| 182 | **FM 2** | 14.5d | 2004-08-19 | 2004-09-09 | 158 |  |
| 183 | **PLASTIC w/ replacement part** | 7d | 2004-08-19 | 2004-08-27 |  |  |
| 184 | Receive PLASTIC FM 2 LVPS from UNH | 1d | 2004-08-19 | 2004-08-19 |  |  |
| 185 | Replace LTC1877 | 0.5d | 2004-08-20 | 2004-08-20 | 184 |  |
| 186 | Test PLASTIC FM 2 LVPS | 1d | 2004-08-20 | 2004-08-23 | 185 |  |
| 187 | Final Coat & Stake PLASTIC LVPS FM 2 Boards | 2d | 2004-08-23 | 2004-08-25 | 186 |  |
| 188 | Retest/ Reassmeble PLASTIC LVPS FM 2 Boards | 2d | 2004-08-25 | 2004-08-27 | 187 |  |
| 189 | Deliver PLASTIC LVPS FM 2 (to UNH) | 2d | 2004-08-26 | 2004-08-27 | 188 | finish no later than 2004-08-27 |
| 190 | **IDPU w/ replacement part** | 6.5d | 2004-08-30 | 2004-09-08 |  |  |
| 191 | Replace LTC1877 | 0.5d | 2004-08-30 | 2004-08-30 | 178 |  |
| 192 | Test IDPU FM 2 LVPS | 1d | 2004-08-31 | 2004-08-31 | 191 |  |
| 193 | Final Coat & Stake IDPU LVPS FM 2 Boards | 3d | 2004-09-01 | 2004-09-03 | 192 |  |
| 194 | Retest/Reassenble IDPU LVPS FM 1 Boards | 2d | 2004-09-07 | 2004-09-08 | 193 |  |
| 195 | **SEP w/ replacement part** | 13.5d | 2004-08-19 | 2004-09-08 |  |  |
| 196 | Receive SEP FM 2 LVPS from CIT | 1d | 2004-08-19 | 2004-08-19 |  |  |
| 197 | Replace LTC1877 | 0.5d | 2004-08-31 | 2004-08-31 | 191, 196 |  |
| 198 | Test SEP FM 2 LVPS | 1d | 2004-08-31 | 2004-09-01 | 197 |  |
| 199 | Final Coat & Stake SEP LVPS FM 2 Boards | 2d | 2004-09-01 | 2004-09-03 | 198 |  |
| 200 | Retest/ Reassmeble SEP LVPS FM 2 Boards | 2d | 2004-09-03 | 2004-09-08 | 199 |  |
| 201 | **SWEA w/ replacement part** | 14.5d | 2004-08-19 | 2004-09-09 |  |  |
| 202 | Replace LTC1877 | 0.5d | 2004-08-19 | 2004-08-19 |  |  |
| 203 | Test SWEA FM 2 LVPS | 1d | 2004-08-31 | 2004-09-01 | 202, 197 |  |
| 204 | Final Coat & Stake SWEA LVPS FM 2 Boards | 3d | 2004-09-01 | 2004-09-07 | 203 |  |
| 205 | Retest/ Reassmeble SWEA LVPS FM 2 Boards | 2d | 2004-09-07 | 2004-09-09 | 204 |  |
| 206 | Deliver all LVPS w/ Replacement Parts ( to CIT for re-integration before EMC) | 1d | 2004-09-09 | 2004-09-10 | 159, 182 | finish no later than 2004-09-10 |
| 454 | **Remaining LET Brackets (Priority 10)** | 19d | 2004-07-26 | 2004-08-19 |  |  |
| 455 | Complete Drawings for Remaining LET Brackets | 3d | 2004-07-26 | 2004-07-28 | 443FS-11d |  |
| 456 | Fabrication of Remaining LET Brackets | 10d | 2004-07-29 | 2004-08-11 | 455 |  |
| 457 | Inspection and Final Assembly of Remaining LET Brackets | 5d | 2004-08-12 | 2004-08-18 | 456 |  |
| 458 | Deliver Remaining LET Brackets to CIT for SEP I&T | 1d | 2004-08-19 | 2004-08-19 | 457 |  |
| 459 | **Rework of SEP Central MDM side panel (Priority 11)** | 21d | 2004-07-29 | 2004-08-26 |  |  |
| 460 | Complete Drawings for Reworked SEP Central MDM side panels | 5d | 2004-07-29 | 2004-08-04 | 455 |  |
| 461 | Fabrication of ReworkedSEP Central MDM side panels | 10d | 2004-08-05 | 2004-08-18 | 460 |  |
| 462 | Inspection and Final Assembly of Reworked SEP Central MDM side panels | 5d | 2004-08-19 | 2004-08-25 | 461 |  |
| 463 | Deliver Reworked SEP Central MDM side panels to CIT for SEP I&T | 1d | 2004-08-26 | 2004-08-26 | 462 |  |
| 464 | **Redesign of HET Housings (Priority 12)** | 23d | 2004-08-05 | 2004-09-07 |  |  |
| 465 | Complete Design/Drawings for Redesign of HET Housings | 8d | 2004-08-05 | 2004-08-16 | 460 | start no earlier than 2004-07-19 |
| 466 | Fabrication of Redesigned HET Housings | 10d | 2004-08-17 | 2004-08-30 | 465 |  |
| 467 | Inspection and Final Assembly of Redesigned HET Housings | 5d | 2004-08-31 | 2004-09-07 | 466 |  |
| 468 | Deliver Redesigned HET Housings (stays at GSFC) | 0d | 2004-09-07 | 2004-09-07 | 467 |  |
| 513 | Deliver HET FM 1 w/ replacement detectors & FM 2 after coating (to CIT for SEP Suite I&T) | 2d | 2004-09-08 | 2004-09-09 | 468, 561 |  |
| 514 | Deliver HET FM 2 w/o replacement detectors (to CIT for SEP Suite I&T) | 2d | 2004-06-28 A | 2004-06-29 A | 564, 451 |  |
| 548 | Design Change of HET PH Event Processing | 20d | 2004-04-05 A | 2004-04-30 A |  | start no earlier than 2004-04-05 |
| 559 | Receive HET FM1 from CIT | 0d | 2004-07-22 | 2004-07-22 | 890 |  |
| 565 | Receive HET FM2 from CIT | 0d | 2004-07-22 | 2004-07-22 | 892 |  |
| 567 | Performance Test FM 2 with New Flight Detectors | 1d | 2004-08-17 | 2004-08-17 | 566 |  |
| 622 | Repair SEPT-NS FM 2 Electronic Board for use as Spare | 104d | 2004-04-06 A | 2004-08-31 | 668SS |  |
| 635 | **SEPT-NS FM 1 Repair** | 82d | 2004-04-06 A | 2004-07-30 | 634FS+20d |  |
| 636 | SEPT-NS FM 1 Initial Repair | 45d | 2004-04-06 A | 2004-06-08 A |  |  |
| 637 | SEPT-NS FM 1 Titanium Parts Repair (GSFC) | 17d | 2004-06-09 A | 2004-07-01 A | 636 |  |
| 638 | SEPT-NS FM 1 Final Repair | 20d | 2004-07-02 | 2004-07-30 | 637 |  |
| 639 | SEPT-NS FM 1 Post Repair Integration & Test | 5d | 2004-08-02 | 2004-08-06 | 635 |  |
| 640 | Cleaning, Packing, Customs, Transport | 5d | 2004-08-16 | 2004-08-20 | 639, 673SS |  |
| 641 | SEPT-NS FM 1 Install Thermal H/W (GSFC) | 4d | 2004-10-06 | 2004-10-12 | 19 |  |
| 643 | SEPT-NS FM 1 Post Repair Vibration (ESTEC) | 5d | 2004-10-27 | 2004-11-02 | 642 |  |
| 644 | SEPT-NSFM 1 Post Repair Thermal Vac (ESTEC) | 6d | 2004-11-03 | 2004-11-10 | 643 |  |
| 651 | **SEPT-E FM 1 Repair** | 82d | 2004-04-06 A | 2004-07-30 | 650FS+20d |  |
| 652 | SEPT-E FM 1 Initial Repair | 45d | 2004-04-06 A | 2004-06-08 A |  |  |
| 653 | SEPT-E FM 1 Titanium Parts Repair (at GSFC then shipped back to Kiel) | 17d | 2004-06-09 A | 2004-07-01 A | 652 |  |
| 654 | SEPT-E FM 1 Final Repair | 20d | 2004-07-02 | 2004-07-30 | 653 |  |
| 655 | SEPT-E FM 1 Post Repair Integration & Test | 5d | 2004-08-02 | 2004-08-06 | 651 |  |
| 656 | Cleaning, Packing, Customs, Transport | 5d | 2004-08-16 | 2004-08-20 | 655, 689SS |  |
| 657 | SEPT-E FM 1 Install Thermal H/W (GSFC) | 4d | 2004-10-06 | 2004-10-12 | 19 |  |
| 658 | SEPT-E FM 1Thermal Balance (at GSFC after Suite EMC) | 10d | 2004-10-13 | 2004-10-26 | 657, 691SS |  |
| 659 | SEPT-E FM1 Post Repair Vibration (ESTEC) | 5d | 2004-10-27 | 2004-11-02 | 658 |  |
| 660 | SEPT-E FM1 Post Repair Thermal Vac (ESTEC) | 6d | 2004-11-03 | 2004-11-10 | 659 |  |
| 668 | **SEPT-NS FM 2 Repair** | 82d | 2004-04-06 A | 2004-07-30 | 667FS+15d |  |
| 669 | SEPT-NS FM 2 Initial Repair | 45d | 2004-04-06 A | 2004-06-08 A |  |  |
| 670 | SEPT-NS FM 2 Titanium Parts Repair (at GSFC then shipped back to Kiel) | 17d | 2004-06-09 A | 2004-07-01 A | 669 |  |
| 671 | SEPT-NS FM 2 Final Repair | 20d | 2004-07-02 | 2004-07-30 | 670 |  |
| 672 | SEPT-NS FM 2 Post Repair Integration & Test | 5d | 2004-08-09 | 2004-08-13 | 625, 668, 639 |  |
| 673 | Cleaning, Packing, Customs, Transport | 5d | 2004-08-16 | 2004-08-20 | 672 |  |
| 674 | SEPT-NS FM 2 Install Thermal H/W (GSFC) | 4d | 2004-10-06 | 2004-10-12 | 673, 641SS |  |
| 675 | SEPT-NS FM 2 Thermal Balance (GSFC) | 10d | 2004-10-13 | 2004-10-26 | 674 |  |
| 676 | SEPT-NS FM 2 Post Repair Vibration (ESTEC) | 5d | 2004-10-27 | 2004-11-02 | 675 |  |
| 677 | SEPT-NS FM 2 Post Repair Thermal Vac (ESTEC) | 6d | 2004-11-12 | 2004-11-19 | 676, 644 |  |
| 684 | **SEPT-E FM 2 Repair** | 82d | 2004-04-06 A | 2004-07-30 | 683FS+15d |  |
| 685 | SEPT-E FM 2 Initial Repair | 45d | 2004-04-06 A | 2004-06-08 A |  |  |
| 686 | SEPT-E FM 2 Titanium Parts Repair (at GSFC then shipped back to Kiel) | 17d | 2004-06-09 A | 2004-07-01 A | 685 |  |
| 687 | SEPT-E FM 2 Final Repair | 20d | 2004-07-02 | 2004-07-30 | 686 |  |
| 688 | SEPT-E FM 2 Post Repair Integration & Test | 5d | 2004-08-09 | 2004-08-13 | 686, 684, 655 |  |
| 689 | Cleaning, Packing, Customs, Transport | 5d | 2004-08-16 | 2004-08-20 | 688 |  |
| 690 | SEPT-E FM 2 Install Thermal H/W (GSFC) | 4d | 2004-10-06 | 2004-10-12 | 657SS |  |
| 691 | SEPT-E FM 2 Thermal Balance (GSFC) | 10d | 2004-10-13 | 2004-10-26 | 690 |  |
| 692 | SEPT-E FM 2 Post Repair Vibration (ESTEC) | 5d | 2004-10-27 | 2004-11-02 | 691 |  |
| 693 | SEPT-E FM 2 Post Repair Thermal Vac (ESTEC) | 6d | 2004-11-12 | 2004-11-19 | 692, 660 |  |
| 777 | Reassemble SIT FM 1 | 1d | 2004-08-20 | 2004-08-20 | 776 |  |
| 778 | SIT FM 1 end-to-end test at Accelerator w/ ETU Telescope (at Brookhaven) | 3d | 2004-08-11 | 2004-08-13 | 777 | must start on 2004-08-11 |
| 846 | Re-integrate & test HET FM 1 w/ Flight detectors | 1d | 2004-09-10 | 2004-09-10 | 513, 886 |  |
| 847 | Re-integrate & Test LET/SEP Central FM 1 | 1d | 2004-08-27 | 2004-08-27 | 506, 458, 463 |  |
| 860 | Re-integrate SEP FM 2 LVPS after Coat and Stake | 1d | 2004-08-10 | 2004-08-10 | 859, 144 |  |
| 861 | Re-integrate HET FM 2 after Confromal Coating | 1d | 2004-09-10 | 2004-09-10 | 860, 515 |  |
| 884 | Deliver SEP/SIT FM 2 to APL | 1d | 2004-12-20 | 2004-12-20 | 883 |  |
| 888 | **Continue I&T for HET, LET and SEP Cen** | 3d | 2004-07-20 | 2004-07-22 | 887 |  |
| 889 | Detach HET LET and SEP Cen from SEP Suite | 1d | 2004-07-20 | 2004-07-20 | 886, 887FS+5d |  |
| 890 | Deliver HET FM 1 (Rplcmnt Detectors and Conformal Coating @ GSFC) | 2d | 2004-07-21 | 2004-07-22 | 889 |  |
| 891 | Deliver LET and SEP Central (Conformal Coating @ CIT) | 0d | 2004-07-20 | 2004-07-20 | 889 |  |
| 892 | Deliver HET FM 2 (Conformal Coating @ GSFC) | 2d | 2004-07-21 | 2004-07-22 | 889, 887 |  |
| 893 | Deliver SEP LVPS FM2 (Coat & Stake @UCB) | 1d | 2004-07-21 | 2004-07-21 | 889 |  |

Removed: 60 SIT Thermal Balance (at GSFC); 212 FM 1 Boom Structure Post Environmental Deployment Test; 234 FM 2 Boom Structure Post Environmental Deployment Test; 572 SEPT-E FM 1 Thermal Balance (at GSFC after Suite EMC); 591 Deliver SIT FM 2 to CIT for SEP I&T; 592 Deliver SIT FM 2 back to GSFC for Environmental Testing; 626 Disassembel FM 1 Logic Board with ETU ACTELs; 627 Retrofit/Inspect FM 1 Flight ACTELs; 628 Reassemble FM 1 Logic Board with Flight ACTELs; 631 Disassemble FM 2 Logic Boards; 632 Retrofit/Inspect Flight ACTELS; 633 Reassemble FM 2 Logic Boards; 641 Funtional Test of FM 1 Logic Board w/Flight ACTELS; 643 Functional Test of FM 2 Logic Board w/ETU ACTELS; 719 SIT FM 2 Thermal Balance; 756 Receive & inspect SEPT FM 2; 763 Receive & inspect SIT FM 2

Changed:

| ID | Task | Start | Finish | Duration | Complete | Total float | Predecessors | Other |
| --- | --- | --- | --- | --- | --- | --- | --- | --- |
| 1 | **IMPACT - Dave Curtis (UCB) & Lil Reichenthal (GSFC)** |  |  | 699d → 698d | 60% → 81% |  |  |  |
| 2 | **Suite Deliveries to APL** | 2004-09-21 → 2004-10-07 (+16d) | 2004-10-28 → 2004-12-20 (+53d) | 25d → 50d |  | 0d → -36d |  |  |
| 4 | FM 2 Target Delivery Date |  |  |  |  | 0d → -36d |  | was named FM 1 Target Delivery Date |
| 5 | Boom Suite FM 1 Ready for Delivery to APL | 2004-09-21 → 2004-11-09 (+49d) | 2004-09-21 → 2004-11-09 (+49d) |  |  | 11d → -23d |  |  |
| 6 | Boom Suite FM 2 Ready for Delivery to APL | 2004-10-06 → 2004-11-30 (+55d) | 2004-10-06 → 2004-11-30 (+55d) |  |  | 14d → -22d |  |  |
| 7 | SEP Suite FM 1 Ready for Delivery to APL | 2004-10-15 → 2004-12-01 (+47d) | 2004-10-15 → 2004-12-01 (+47d) |  |  | -6d → -37d |  |  |
| 8 | SEP Suite FM 2 Ready for Delivery to APL | 2004-10-22 → 2004-12-20 (+59d) | 2004-10-22 → 2004-12-20 (+59d) |  |  | 3d → -36d | 880, 699 → 884 |  |
| 9 | **Environmental Testing - PER, Impact Suite EMC, Snapshots of Boom & SEP Suite Test Flows** |  | 2004-10-18 → 2004-12-22 (+65d) | 194d → 238d | 3% → 23% | 283d → 238d |  |  |
| 10 | **Reviews (PER and TRR's) - TRR Dates are Tentative** |  | 2004-08-16 → 2004-10-04 (+49d) | 151d → 184d | 25% → 50% | 326d → 292d |  |  |
| 13 | TRR 2 - Prior to FM 1 STE-U Thermal Vac/Thermal Balance | 2004-04-19 A | 2004-04-19 A |  | 0% → 100% | 410d → none | 21SS → 21SS-6d |  |
| 14 | TRR 3 - Prior to FM 1 Boom Structure Vibration | 2004-04-19 A | 2004-04-19 A |  | 0% → 100% | 410d → none | 22SS-9d → 22SS-19d |  |
| 15 | TRR 4 - Prior to FM 1 IDPU Vibration | 2004-05-18 → 2004-09-29 (+134d) | 2004-05-18 → 2004-09-29 (+134d) |  |  | 389d → 295d |  |  |
| 16 | TRR 5 - Prior to FM 1 SWEA Vibration | 2004-06-08 → 2004-09-29 (+113d) | 2004-06-08 → 2004-09-29 (+113d) |  |  | 375d → 295d |  |  |
| 17 | TRR 6 - Prior to FM 1 Impact Suite EMC (for Boom and SEP) | 2004-07-28 → 2004-09-15 (+49d) | 2004-07-28 → 2004-09-15 (+49d) |  |  | 339d → 305d |  |  |
| 18 | TRR 7 - Prior to FM 1 SIT Vibration | 2004-08-16 → 2004-10-04 (+49d) | 2004-08-16 → 2004-10-04 (+49d) |  |  | 326d → 292d |  |  |
| 19 | IMPACT Suite FM 1 EMC Testing at UCB | 2004-08-04 → 2004-09-22 (+49d) | 2004-08-17 → 2004-10-05 (+49d) |  |  | -13d → -42d | 398, 854, 485 → 854, 485, 479 |  |
| 20 | **Boom Suite FM 1 Environmental Test Flow Snapshot - UCB** | 2004-04-05 → 2004-04-26 A (+21d) | 2004-09-07 → 2004-11-02 (+56d) | 110d → 133d | 0% → 48% | 311d → 272d |  |  |
| 21 | STE-U Thermal Vac/Thermal Balance/Bake Out | 2004-04-05 → 2004-04-26 A (+21d) | 2004-04-22 → 2004-06-16 A (+55d) | 14d → 37d | 0% → 100% | 407d → none |  |  |
| 22 | Boom Structure Vibration | 2004-04-30 → 2004-06-23 A (+54d) | 2004-05-05 → 2004-06-28 A (+54d) |  | 0% → 100% | 398d → none |  |  |
| 23 | IDPU Vibration | 2004-05-25 → 2004-10-06 (+134d) | 2004-06-01 → 2004-10-13 (+134d) |  |  | 380d → 286d |  |  |
| 24 | Boom Structure Thermal Vac & Bake Out | 2004-05-06 → 2004-06-29 A (+54d) | 2004-05-26 → 2004-07-20 (+55d) |  | 0% → 13% | 383d → 345d |  |  |
| 25 | IDPU Thermal Vac & Bake Out | 2004-06-02 → 2004-10-14 (+134d) | 2004-06-15 → 2004-10-27 (+134d) |  |  | 370d → 276d |  |  |
| 26 | SWEA/STE Vibration | 2004-06-15 → 2004-10-06 (+113d) | 2004-06-21 → 2004-10-13 (+114d) |  |  | 366d → 286d |  |  |
| 27 | SWEA/STE Thermal Vac/Thermal Balance/Bake Out | 2004-08-18 → 2004-10-14 (+57d) | 2004-09-07 → 2004-11-02 (+56d) |  |  | 311d → 272d |  |  |
| 28 | **Boom Suite FM 2 Environmental Test Flow Snapshot - UCB** | 2004-05-27 → 2004-08-02 (+67d) | 2004-09-22 → 2004-11-22 (+61d) | 83d → 78d |  | 300d → 259d |  |  |
| 29 | STE-U Thermal Vac/Bake Out | 2004-05-27 → 2004-08-02 (+67d) | 2004-06-10 → 2004-08-13 (+64d) |  |  | 373d → 327d |  |  |
| 30 | IDPU Vibration | 2004-07-07 → 2004-09-16 (+71d) | 2004-07-13 → 2004-09-22 (+71d) |  |  | 350d → 300d |  |  |
| 31 | Boom Structure Vibration | 2004-06-17 → 2004-08-20 (+64d) | 2004-06-22 → 2004-08-25 (+64d) |  |  | 365d → 319d |  |  |
| 32 | IDPU Thermal Vac & Bake Out | 2004-07-14 → 2004-09-23 (+71d) | 2004-07-27 → 2004-10-06 (+71d) |  |  | 340d → 290d |  |  |
| 33 | Boom Structure Thermal Vac & Bake Out | 2004-06-23 → 2004-08-26 (+64d) | 2004-07-13 → 2004-09-16 (+65d) |  |  | 350d → 304d |  |  |
| 34 | SWEA/STE Vibration | 2004-08-17 → 2004-10-15 (+59d) | 2004-08-23 → 2004-10-21 (+59d) |  |  | 321d → 280d |  |  |
| 35 | SWEA/STE Thermal Vac & Bake Out | 2004-08-24 → 2004-10-22 (+59d) | 2004-09-07 → 2004-11-04 (+58d) |  |  | 311d → 270d |  |  |
| 36 | Boom Suite FM 2 EMC | 2004-09-16 → 2004-11-16 (+61d) | 2004-09-22 → 2004-11-22 (+61d) |  |  | 300d → 259d |  |  |
| 37 | **SEP Suite FM 1 Environmental Test Flow Snapshot** |  | 2004-10-15 → 2004-11-29 (+45d) | 169d → 197d | 4% → 19% | 284d → 255d |  |  |
| 39 | SEPT (NS & E) Thermal Vac (in Europe) | 2004-02-27 A | 2004-03-11 → 2004-03-12 A (+1d) | 10d → 11d | 0% → 100% | 437d → none |  |  |
| 40 | SEPT (NS & E) Bake Out (in Europe) | 2004-03-05 A | 2004-03-08 A |  | 0% → 100% | 440d → none |  |  |
| 41 | SEPT (NS & E) Thermal Balance (at GSFC) | 2004-08-18 → 2004-10-13 (+56d) | 2004-08-31 → 2004-10-26 (+56d) |  |  | 315d → 277d | 642SS, SEPT-E FM 1 Thermal Balance (at GSFC after Suite EMC)SS → 642SS, 658SS |  |
| 42 | LET/HET/SEP Cen Accelerator Test (at MSU) | 2004-08-18 → 2004-07-10 (-39d) | 2004-09-01 → 2004-07-12 (-51d) | 11d → 3d |  | 314d → 355d |  |  |
| 43 | SIT Vibe and Acoustics (at GSFC) | 2004-08-23 → 2004-10-12 (+50d) | 2004-09-03 → 2004-10-25 (+52d) |  |  | 312d → 278d |  |  |
| 44 | LET/HET/SEP Cen Vibe and Acoustics (at JPL) | 2004-08-30 → 2004-10-12 (+43d) | 2004-09-13 → 2004-10-25 (+42d) |  |  | 307d → 278d |  |  |
| 45 | SIT Thermal Balance (at GSFC) | 2004-09-08 → 2004-10-27 (+49d) | 2004-09-14 → 2004-11-02 (+49d) |  |  | 306d → 272d |  |  |
| 46 | LET/HET/SEP Cen Thermal Balance (at JPL) | 2004-09-14 → 2004-10-26 (+42d) | 2004-09-20 → 2004-11-01 (+42d) |  |  | 302d → 273d |  |  |
| 47 | SIT Thermal Vac (at GSFC) | 2004-09-15 → 2004-11-03 (+49d) | 2004-09-28 → 2004-11-17 (+50d) |  |  | 296d → 262d |  |  |
| 48 | LET/HET/SEP Cen Thermal Vac (at JPL) | 2004-09-21 → 2004-11-02 (+42d) | 2004-10-12 → 2004-11-23 (+42d) |  |  | 287d → 258d |  |  |
| 49 | SIT Bake Out (at GSFC) | 2004-10-01 → 2004-11-22 (+52d) | 2004-10-05 → 2004-11-24 (+50d) |  |  | 291d → 257d |  |  |
| 50 | LET/HET/SEP Cen Bake Out (at JPL) | 2004-10-13 → 2004-11-24 (+42d) | 2004-10-15 → 2004-11-29 (+45d) |  |  | 284d → 255d |  |  |
| 51 | **SEP Suite FM 2 Environmental Test Flow Snapshot** |  | 2004-10-18 → 2004-12-22 (+65d) | 170d → 214d | 5% → 20% | 283d → 238d |  |  |
| 53 | SEPT (NS & E) Thermal Vac (in Europe) | 2004-03-05 A | 2004-03-18 → 2004-03-17 A (-1d) | 10d → 9d | 0% → 100% | 432d → none |  |  |
| 54 | SEPT (NS & E) Bake Out (in Europe) | 2004-03-12 A | 2004-03-15 A |  | 0% → 100% | 435d → none |  |  |
| 55 | LET/HET/SEP Cen Accelerator Test (at MSU) | 2004-08-18 → 2004-07-10 (-39d) | 2004-09-01 → 2004-07-12 (-51d) | 11d → 3d |  | 314d → 355d |  |  |
| 56 | LET/HET/SEP Cen Vibe and Acoustics (at JPL) | 2004-08-31 → 2004-10-12 (+42d) | 2004-09-14 → 2004-10-25 (+41d) |  |  | 306d → 278d |  |  |
| 57 | SEP Suite FM 2 EMC (at Caltech) | 2004-08-24 → 2004-12-16 (+114d) | 2004-08-30 → 2004-12-22 (+114d) |  |  | 316d → 238d |  |  |
| 58 | LET/HET/SEP Cen Thermal Vac (at JPL) | 2004-09-15 → 2004-10-26 (+41d) | 2004-10-05 → 2004-11-16 (+42d) |  |  | 291d → 263d |  |  |
| 59 | SIT Vibe and Acoustics (at GSFC) | 2004-09-02 → 2004-11-01 (+60d) | 2004-09-16 → 2004-11-15 (+60d) |  |  | 304d → 264d |  |  |
| 60 | LET/HET/SEP Cen Bake Out (at JPL) | 2004-10-06 → 2004-11-17 (+42d) | 2004-10-08 → 2004-11-19 (+42d) |  |  | 288d → 260d |  |  |
| 61 | SIT Thermal Vac (at GSFC) | 2004-09-27 → 2004-11-17 (+51d) | 2004-10-08 → 2004-12-01 (+54d) |  |  | 288d → 253d |  |  |
| 62 | SIT Bake Out (at GSFC) | 2004-10-14 → 2004-12-06 (+53d) | 2004-10-18 → 2004-12-08 (+51d) |  |  | 283d → 248d |  |  |
| 63 | **Power Converters - UCB** |  | 2004-06-29 → 2004-09-10 (+73d) | 339d → 389.5d | 63% → 82% | 19d → 2.5d |  |  |
| 64 | **Deliveries** |  | 2004-06-29 → 2004-08-24 (+56d) | 141d → 180d | 20% → 60% | 19d → -1d |  |  |
| 65 | **FM 1** |  | 2004-05-17 → 2004-07-23 (+67d) | 111d → 158d | 40% → 99% | 13d → -15d |  |  |
| 66 | Deliver IDPU FM 1 LVPS (stays at UCB) | 2004-05-17 → 2004-07-20 (+64d) | 2004-05-17 → 2004-07-20 (+64d) |  |  | 13d → -12d |  |  |
| 67 | Deliver SEP FM 1 LVPS (to Caltech) | 2004-05-13 → 2004-06-01 A (+19d) | 2004-05-13 → 2004-06-01 A (+19d) |  | 0% → 100% | 13d → none |  |  |
| 68 | Deliver SWEA/STE FM 1 LVPS (stays at UCB) | 2004-04-23 → 2004-07-23 (+91d) | 2004-04-23 → 2004-07-23 (+91d) |  |  | 7d → -42d |  |  |
| 69 | Deliver PLASTIC FM 1 LVPS (to UNH) | 2004-04-12 → 2004-05-24 A (+42d) | 2004-04-13 → 2004-05-25 A (+42d) |  | 0% → 100% | 15d → none |  | constraint finish no later than 2004-05-04 → finish no later than 2004-06-10 |
| 71 | **FM 2** | 2004-05-14 → 2004-06-29 A (+46d) | 2004-06-29 → 2004-08-24 (+56d) | 32d → 40d | 0% → 20% | 7d → -1d |  |  |
| 72 | Deliver IDPU FM 2 LVPS (stays at UCB) | 2004-06-29 → 2004-08-24 (+56d) | 2004-06-29 → 2004-08-24 (+56d) |  |  | 19d → -1d |  |  |
| 73 | Deliver SEP FM 2 LVPS (to Caltech) | 2004-05-18 → 2004-06-29 A (+42d) | 2004-05-18 → 2004-06-29 A (+42d) |  | 0% → 100% | 10d → none | 143 → 141 |  |
| 74 | Deliver SWEA/STE FM 2 LVPS (stays at UCB) | 2004-06-07 → 2004-08-24 (+78d) | 2004-06-07 → 2004-08-24 (+78d) |  |  | 24d → -22d |  |  |
| 75 | Deliver PLASTIC FM 2 LVPS (to UNH) | 2004-05-21 → 2004-07-27 (+67d) | 2004-05-24 → 2004-07-28 (+65d) |  |  | 12d → 16d |  | constraint finish no later than 2004-06-10 → finish no later than 2004-08-19 |
| 76 | Deliver SIT FM 2 HVPS (to UMD) | 2004-05-14 → 2004-08-17 (+95d) | 2004-05-17 → 2004-08-18 (+93d) |  |  | 7d → -36d |  |  |

| ID | Task | Start | Finish | Duration | Complete | Total float | Predecessors |
| --- | --- | --- | --- | --- | --- | --- | --- |
| 77 | **Remaining Flight Procurements** |  | 2004-03-12 A |  | 75% → 100% | 13d → none |  |
| 78 | Procure IDPU Flight Printed Wiring Board | 2004-03-01 A | 2004-03-12 A |  | 0% → 100% | 13d → none |  |
| 98 | **Assembly** |  | 2004-05-17 → 2004-07-20 (+64d) | 98d → 142d | 45% → 88% | 19d → 39d |  |
| 99 | **FM 1** |  | 2004-04-05 → 2004-04-27 A (+22d) | 68d → 84d | 78% → 100% | 13d → none |  |
| 100 | Assemble IDPU FM 1 LVPS | 2004-03-19 → 2004-04-05 A (+17d) | 2004-04-05 → 2004-04-27 A (+22d) | 12d → 17d | 0% → 100% | 13d → none | 88, 112 → 88, 112FS+2d |
| 102 | Assemble SWEA FM 1 LVPS |  | 2004-03-12 → 2004-03-26 A (+14d) | 20d → 30d | 50% → 100% | 7d → none |  |
| 104 | **FM 2** | 2004-03-15 → 2004-03-29 A (+14d) | 2004-05-17 → 2004-07-20 (+64d) | 46d → 80d | 0% → 80% | 7d → 39d |  |
| 105 | Assemble IDPU FM 2 LVPS | 2004-04-27 → 2004-06-28 A (+62d) | 2004-05-17 → 2004-07-12 (+56d) | 15d → 10d | 0% → 30% | 19d → 5d | 94, 118 → 94, 118FS-25d |
| 106 | Assemble SEP FM 2 LVPS | 2004-03-16 → 2004-05-24 A (+69d) | 2004-04-05 → 2004-06-21 A (+77d) | 15d → 20d | 0% → 100% | 10d → none | 95, 122 → 95, 122FS+5d |
| 107 | Assemble SWEA FM 2 LVPS | 2004-04-05 → 2004-06-22 A (+78d) | 2004-04-23 → 2004-07-20 (+88d) | 15d → 14d | 0% → 50% | 24d → -22d |  |
| 108 | Assemble PLASTIC FM 2 LVPS | 2004-03-22 → 2004-05-10 A (+49d) | 2004-04-08 → 2004-07-20 (+103d) | 14d → 50d | 0% → 74% | 12d → 39d |  |
| 109 | Assemble SIT FM 2 HVPS | 2004-03-15 → 2004-03-29 A (+14d) | 2004-04-01 → 2004-07-12 (+102d) | 14d → 74d | 0% → 91% | 7d → -36d |  |
| 110 | **Testing** |  | 2004-06-29 → 2004-08-24 (+56d) | 166d → 205d | 21% → 69% | 19d → 4d |  |
| 111 | **FM 1 & FM 2** |  | 2004-03-18 → 2004-03-31 A (+13d) | 79d → 88d | 80% → 100% | 13d → none |  |
| 112 | Coupon Test IDPU Flight Printed Wiring Board | 2004-03-15 → 2004-03-26 A (+11d) | 2004-03-18 → 2004-03-31 A (+13d) |  | 0% → 100% | 13d → none | 78 → 78FS+9d |
| 116 | **FM 1** |  | 2004-05-17 → 2004-07-23 (+67d) | 136d → 183d | 35% → 89% | 13d → -3d |  |
| 117 | **IDPU** | 2004-04-06 → 2004-06-21 A (+76d) | 2004-05-17 → 2004-07-20 (+64d) | 30d → 21d | 0% → 38% | 13d → 0d |  |
| 118 | Test IDPU FM 1 LVPS | 2004-04-06 → 2004-06-21 A (+76d) | 2004-04-26 → 2004-07-20 (+85d) | 15d → 21d | 0% → 38% | 13d → -12d | 100 → 100FS+37d |
| 119 | Coat & Stake IDPU LVPS FM 1 Boards | 2004-04-27 → 2004-07-20 (+84d) | 2004-05-03 → 2004-07-20 (+78d) | 5d → 0d |  | 13d → -12d |  |
| 120 | Retest IDPU LVPS FM 1 Boards | 2004-05-04 → 2004-07-20 (+77d) | 2004-05-17 → 2004-07-20 (+64d) | 10d → 0d |  | 13d → -12d |  |
| 121 | **SEP** | 2004-03-10 A | 2004-05-12 → 2004-05-28 A (+16d) | 46d → 58d | 0% → 100% | 10d → none |  |
| 122 | Test SEP FM 1 LVPS | 2004-03-10 A | 2004-03-15 → 2004-05-14 A (+60d) | 4d → 48d | 0% → 100% | 10d → none |  |
| 123 | Coat & Stake SEP LVPS FM 1 Boards | 2004-03-16 → 2004-05-17 A (+62d) | 2004-03-22 → 2004-05-21 A (+60d) |  | 0% → 100% | 40d → none |  |
| 124 | Retest SEP LVPS FM 1 Boards | 2004-04-29 → 2004-05-24 A (+25d) | 2004-05-12 → 2004-05-28 A (+16d) | 10d → 5d | 0% → 100% | 13d → none |  |
| 125 | **SWEA** |  | 2004-04-23 → 2004-07-23 (+91d) | 30d → 93d | 43% → 83% | 7d → -10d |  |
| 126 | Test SWEA FM 1 LVPS |  | 2004-04-02 → 2004-07-09 (+98d) | 15d → 83d | 87% → 93% | 7d → -42d |  |
| 127 | Coat & Stake SWEA LVPS FM 1 Boards | 2004-04-05 → 2004-07-12 (+98d) | 2004-04-09 → 2004-07-16 (+98d) |  |  | 7d → -42d |  |
| 128 | Retest SWEA LVPS FM 1 Boards | 2004-04-12 → 2004-07-19 (+98d) | 2004-04-23 → 2004-07-23 (+91d) | 10d → 5d |  | 7d → -42d |  |
| 129 | **PLASTIC** |  | 2004-04-09 → 2004-05-21 A (+42d) | 43d → 73d | 30% → 100% | 15d → none |  |
| 130 | Test PLASTIC FM 1 LVPS |  | 2004-03-19 → 2004-05-07 A (+49d) | 28d → 63d | 46% → 100% | 12d → none |  |
| 131 | Coat & Stake PLASTIC LVPS FM 1 Boards | 2004-03-22 → 2004-05-10 A (+49d) | 2004-03-26 → 2004-05-14 A (+49d) |  | 0% → 100% | 15d → none |  |
| 132 | Retest PLASTIC LVPS FM 1 Boards | 2004-03-29 → 2004-05-17 A (+49d) | 2004-04-09 → 2004-05-21 A (+42d) | 10d → 5d | 0% → 100% | 15d → none |  |
| 135 | **FM 2** | 2004-04-02 → 2004-05-28 A (+56d) | 2004-06-29 → 2004-08-24 (+56d) | 62d → 61d | 0% → 27% | 7d → 4d |  |
| 136 | **IDPU** | 2004-05-18 → 2004-07-21 (+64d) | 2004-06-29 → 2004-08-24 (+56d) | 30d → 25d |  | 19d → -1d |  |
| 137 | Test IDPU FM 2 LVPS | 2004-05-18 → 2004-07-21 (+64d) | 2004-06-08 → 2004-08-10 (+63d) |  |  | 19d → -1d | 105 → 105, 118 |
| 138 | Coat & Stake IDPU LVPS FM 2 Boards | 2004-06-09 → 2004-08-11 (+63d) | 2004-06-15 → 2004-08-17 (+63d) |  |  | 19d → -1d |  |
| 139 | Retest IDPU LVPS FM 2 Boards | 2004-06-16 → 2004-08-18 (+63d) | 2004-06-29 → 2004-08-24 (+56d) | 10d → 5d |  | 19d → -1d |  |
| 140 | **SEP** | 2004-04-06 → 2004-06-08 A (+63d) | 2004-05-17 → 2004-08-09 (+84d) | 30d → 44d | 0% → 54% | 10d → 15d |  |
| 141 | Test SEP FM 2 LVPS | 2004-04-06 → 2004-06-08 A (+63d) | 2004-04-26 → 2004-06-28 A (+63d) |  | 0% → 100% | 10d → none | 106 → 106FS-10d |
| 142 | Coat & Stake SEP LVPS FM 2 Boards | 2004-04-27 → 2004-07-22 (+86d) | 2004-05-03 → 2004-07-28 (+86d) |  |  | 10d → 15d | 141 → 141, 893 |
| 143 | Retest SEP LVPS FM 2 Boards | 2004-05-04 → 2004-07-29 (+86d) | 2004-05-17 → 2004-08-04 (+79d) | 10d → 5d |  | 10d → 15d |  |
| 145 | **SWEA** | 2004-04-26 → 2004-07-21 (+86d) | 2004-06-07 → 2004-08-24 (+78d) | 30d → 25d |  | 24d → -22d |  |
| 146 | Test SWEA FM 2 LVPS | 2004-04-26 → 2004-07-21 (+86d) | 2004-05-14 → 2004-08-10 (+88d) |  |  | 24d → -22d |  |
| 147 | Coat & Stake SWEA LVPS FM 2 Boards | 2004-05-17 → 2004-08-11 (+86d) | 2004-05-21 → 2004-08-17 (+88d) |  |  | 24d → -22d |  |
| 148 | Retest SWEA LVPS FM 2 Boards | 2004-05-24 → 2004-08-18 (+86d) | 2004-06-07 → 2004-08-24 (+78d) | 10d → 5d |  | 24d → -22d |  |
| 149 | **PLASTIC** | 2004-04-09 → 2004-05-28 A (+49d) | 2004-05-20 → 2004-07-26 (+67d) | 30d → 40d | 0% → 57% | 12d → 16d |  |
| 150 | Test PLASTIC FM 2 LVPS | 2004-04-09 → 2004-05-28 A (+49d) | 2004-04-29 → 2004-07-12 (+74d) | 15d → 30d | 0% → 77% | 12d → 16d | 108 → 108FS-36d |
| 151 | Coat & Stake PLASTIC LVPS FM 2 Boards | 2004-04-30 → 2004-07-13 (+74d) | 2004-05-06 → 2004-07-19 (+74d) |  |  | 12d → 16d |  |
| 152 | Retest PLASTIC LVPS FM 2 Boards | 2004-05-07 → 2004-07-20 (+74d) | 2004-05-20 → 2004-07-26 (+67d) | 10d → 5d |  | 12d → 16d |  |
| 153 | **SIT** | 2004-04-02 → 2004-06-28 (+87d) | 2004-05-13 → 2004-08-16 (+95d) | 30d → 35d |  | 7d → -36d |  |
| 154 | Test SIT FM 2 HVPS | 2004-04-02 → 2004-06-28 (+87d) | 2004-04-22 → 2004-08-02 (+102d) |  |  | 7d → -36d | 109 → 109FS-10d |
| 155 | Coat & Stake SIT FM 2 HVPS Boards | 2004-04-23 → 2004-08-03 (+102d) | 2004-04-29 → 2004-08-09 (+102d) |  |  | 7d → -36d |  |
| 156 | Retest SIT FM 2 HVPS Boards | 2004-04-30 → 2004-08-10 (+102d) | 2004-05-13 → 2004-08-16 (+95d) | 10d → 5d |  | 7d → -36d |  |
| 207 | **IDPU - UCB** |  | 2004-09-07 → 2004-10-27 (+50d) | 340d → 374d | 76% → 86% | 0d → -14d |  |
| 208 | **Deliveries** | 2004-06-15 → 2004-07-27 (+42d) | 2004-07-27 → 2004-08-31 (+35d) | 30d → 25d |  | 13d → -12d |  |
| 209 | IDPU FM 1 Complete (to UCB for Boom I&T, then to CIT for SEP I&T, Suite EMC, BO & Final Boom I&T) | 2004-06-15 → 2004-07-27 (+42d) | 2004-06-15 → 2004-07-27 (+42d) |  |  | 13d → -12d | 224 → 222 |
| 210 | IDPU FM 2 Complete (to CIT for SEP I&T, then to UCB for Boom I&T, Boom EMC, BO & Final Boom I&T) | 2004-07-27 → 2004-08-31 (+35d) | 2004-07-27 → 2004-08-31 (+35d) |  |  | 19d → -1d | 228 → 226 |
| 211 | **Flight Software** |  | 2004-04-13 → 2004-08-11 (+120d) | 237d → 321d | 89% → 92% | 83d → 29d |  |
| 213 | IDPU S/W Build #3 (also goes to UNH) |  | 2004-04-13 → 2004-08-11 (+120d) | 165d → 249d | 81% → 88% | 83d → 29d |  |
| 214 | **GSE** |  | 2004-09-07 → 2004-09-08 (+1d) |  | 72% → 87% |  |  |
| 217 | GSE Continued Development (LOE) |  | 2004-09-07 → 2004-09-08 (+1d) |  | 54% → 79% |  |  |
| 218 | **Integration & Test** |  | 2004-07-27 → 2004-10-27 (+92d) | 203d → 266d |  | 19d → -14d |  |
| 221 | **FM 1** | 2004-05-18 → 2004-07-21 (+64d) | 2004-06-15 → 2004-10-27 (+134d) | 20d → 69d |  | 13d → -19d |  |
| 222 | IDPU FM 1 I & T | 2004-05-18 → 2004-07-21 (+64d) | 2004-05-24 → 2004-07-27 (+64d) |  |  | 13d → -12d |  |
| 223 | IDPU FM 1 Vibration | 2004-05-25 → 2004-10-06 (+134d) | 2004-06-01 → 2004-10-13 (+134d) |  |  | 13d → -19d | 222 → 222, 19 |
| 224 | IDPU FM 1 Thermal Vacuum & Bake Out | 2004-06-02 → 2004-10-14 (+134d) | 2004-06-15 → 2004-10-27 (+134d) |  |  | 13d → -19d |  |
| 225 | **FM 2** | 2004-06-30 → 2004-08-25 (+56d) | 2004-07-27 → 2004-10-06 (+71d) | 20d → 30d |  | 19d → -1d |  |
| 226 | IDPU FM 2 I & T | 2004-06-30 → 2004-08-25 (+56d) | 2004-07-06 → 2004-08-31 (+56d) |  |  | 19d → -1d |  |
| 227 | IDPU FM 2 Vibration | 2004-07-07 → 2004-09-16 (+71d) | 2004-07-13 → 2004-09-22 (+71d) |  |  | 19d → 0d | 226 → 863FS+2d |
| 228 | IDPU FM 2 Thermal Vacuum & Bake Out | 2004-07-14 → 2004-09-23 (+71d) | 2004-07-27 → 2004-10-06 (+71d) |  |  | 19d → 0d |  |

| ID | Task | Start | Finish | Duration | Complete | Total float | Predecessors | Other |
| --- | --- | --- | --- | --- | --- | --- | --- | --- |
| 229 | **BOOM Suite - UCB** |  | 2004-10-06 → 2004-11-30 (+55d) | 321d → 356d | 72% → 91% | 14d → -22d |  |  |
| 230 | **BOOM Structure - UCB** |  | 2004-07-19 → 2004-09-16 (+59d) | 216d → 257d | 85% → 94% | 49d → 12d |  |  |
| 231 | **Deliveries** |  | 2004-07-19 → 2004-09-16 (+59d) | 133d → 174d |  | 49d → 12d |  |  |
| 233 | Deliver Boom Structure FM 1 (stays at UCB for Boom Suite FM 1 I&T) | 2004-06-02 → 2004-07-20 (+48d) | 2004-06-02 → 2004-07-20 (+48d) |  |  | 20d → -9d | FM 1 Boom Structure Post Environmental Deployment Test → 261 |  |
| 234 | Deliver Boom Structure FM 2 (stays at UCB for Boom Suite FM 2 I&T) | 2004-07-19 → 2004-09-16 (+59d) | 2004-07-19 → 2004-09-16 (+59d) |  |  | 49d → 12d | FM 2 Boom Structure Post Environmental Deployment Test → 282 |  |
| 241 | **FM 1** |  | 2004-06-02 → 2004-07-20 (+48d) | 170d → 203d | 79% → 95% | 20d → 0d |  |  |
| 257 | **Integration & Test** | 2004-03-15 → 2004-03-16 A (+1d) | 2004-06-02 → 2004-07-20 (+48d) | 57d → 89d | 0% → 84% | 20d → 0d |  |  |
| 258 | Integrate FM 1 Boom Structure subassemblies & Harness Completion | 2004-03-15 → 2004-03-16 A (+1d) | 2004-04-09 → 2004-06-08 A (+60d) | 20d → 60d | 0% → 100% | 20d → none | 247, 253, 279FS-5d → 247, 253FS+5d |  |
| 259 | FM 1 Boom Structure Deployment Test | 2004-04-12 → 2004-06-09 A (+58d) | 2004-04-23 → 2004-06-11 A (+49d) | 10d → 3d | 0% → 100% | 20d → none |  |  |
| 260 | FM 1 Boom Structure Vibration Test | 2004-04-30 → 2004-06-23 A (+54d) | 2004-05-05 → 2004-06-28 A (+54d) |  | 0% → 100% | 20d → none |  |  |
| 261 | FM 1 Boom Structure Themal Vac & Bake Out | 2004-05-06 → 2004-06-29 A (+54d) | 2004-05-26 → 2004-07-20 (+55d) |  | 0% → 13% | 20d → -9d |  |  |
| 262 | **FM 2** |  | 2004-07-19 → 2004-09-16 (+59d) | 203d → 244d | 83% → 90% | 49d → 12d |  |  |
| 278 | **Integration & Test** | 2004-03-10 → 2004-03-29 A (+19d) | 2004-07-19 → 2004-09-16 (+59d) | 93d → 121d | 0% → 69% | 20d → 12d |  |  |
| 279 | Integrate FM 2 Boom Structure subassemblies & Harness Completion | 2004-03-10 → 2004-03-29 A (+19d) | 2004-03-19 → 2004-07-13 (+116d) | 8d → 75d | 0% → 89% | 20d → 32d | 268, 274 → 268, 274, 258SS+10d |  |
| 280 | FM 2 Boom Structure Deployment Test | 2004-03-22 → 2004-07-14 (+114d) | 2004-04-02 → 2004-07-16 (+105d) | 10d → 3d |  | 97d → 32d |  |  |
| 281 | FM 2 Boom Structure Vibration Test | 2004-06-17 → 2004-08-20 (+64d) | 2004-06-22 → 2004-08-25 (+64d) |  |  | 49d → 12d |  |  |
| 282 | FM 2 Boom Structure Themal Vac & Bake Out | 2004-06-23 → 2004-08-26 (+64d) | 2004-07-13 → 2004-09-16 (+65d) |  |  | 49d → 12d |  |  |
| 283 | **MAG - GSFC** |  | 2004-03-29 → 2004-05-18 A (+50d) | 27d → 63d | 22% → 100% | 84d → none |  |  |
| 284 | **Deliveries** | 2004-03-26 → 2004-04-28 A (+33d) | 2004-03-29 → 2004-05-18 A (+50d) | 2d → 15d | 0% → 100% | 39d → none |  |  |
| 285 | Deliver MAG FM 1 (to UCB for IDPU/BOOM Suite FM 1 I&T) | 2004-03-26 → 2004-04-28 A (+33d) | 2004-03-29 → 2004-04-29 A (+31d) |  | 0% → 100% | 39d → none |  |  |
| 286 | Deliver MAG FM 2 (to UCB for IDPU/BOOM Suite FM 2 I&T) | 2004-03-26 → 2004-05-17 A (+52d) | 2004-03-29 → 2004-05-18 A (+50d) |  | 0% → 100% | 84d → none |  |  |
| 287 | **FM 1** |  | 2004-03-25 → 2004-04-27 A (+33d) | 25d → 48d | 24% → 100% | 39d → none |  |  |
| 288 | FM 1 MAG Testing |  | 2004-03-04 → 2004-03-18 A (+14d) | 10d → 20d | 60% → 100% | 39d → none |  |  |
| 289 | MAG FM 1 Calibration | 2004-03-05 → 2004-03-26 A (+21d) | 2004-03-25 → 2004-04-27 A (+33d) | 15d → 22d | 0% → 100% | 39d → none | 288 → 288FS+10d |  |
| 290 | **FM 2** | 2004-02-20 A → 2004-03-05 A (+14d) | 2004-03-25 → 2004-05-14 A (+50d) | 25d → 51d | 24% → 100% | 84d → none |  |  |
| 291 | FM 2 MAG Testing | 2004-02-20 A → 2004-03-05 A (+14d) | 2004-03-04 → 2004-04-01 A (+28d) | 10d → 20d | 60% → 100% | 84d → none | none → 288FF+10d | constraint start no earlier than 2004-02-20 → none |
| 292 | MAG FM 2 Calibration | 2004-03-05 → 2004-04-16 A (+42d) | 2004-03-25 → 2004-05-14 A (+50d) | 15d → 21d | 0% → 100% | 84d → none | 291 → 291FS+10d |  |
| 293 | **SWEA - CESR** |  | 2004-05-05 → 2004-06-07 A (+33d) | 104d → 126d | 27% → 100% | 56d → none |  |  |
| 294 | **Deliveries** |  | 2004-05-05 → 2004-06-07 A (+33d) | 104d → 126d | 50% → 100% | 56d → none |  |  |
| 296 | SWEA FM 2 Delivery to UCB | 2004-05-03 → 2004-06-03 A (+31d) | 2004-05-05 → 2004-06-07 A (+33d) |  | 0% → 100% | 56d → none | 299 → 299FS+7d |  |
| 297 | **FM 2** |  | 2004-04-30 → 2004-05-21 A (+21d) | 35d → 50d | 21% → 100% | 56d → none |  |  |
| 299 | SWEA FM 2 Calibration | 2004-04-06 → 2004-03-22 A (-15d) | 2004-04-30 → 2004-05-21 A (+21d) | 19d → 45d | 0% → 100% | 56d → none | 298FS+11d → 298 |  |
| 300 | **STE - UCB** |  | 2004-06-10 → 2004-08-13 (+64d) | 196d → 241d | 70% → 92% | 49d → 12d |  |  |
| 301 | **Deliveries** | 2004-04-16 → 2004-06-14 A (+59d) | 2004-06-10 → 2004-08-13 (+64d) | 38d → 43d |  | 22d → 12d |  |  |
| 302 | Deliver STE-D FM 1 (stays at UCB for SWEA/STE-D FM 1 I&T) | 2004-04-16 → 2004-06-14 A (+59d) | 2004-04-16 → 2004-06-14 A (+59d) |  | 0% → 100% | 22d → none |  |  |
| 303 | Deliver STE-D FM 2 (stays at UCB for SWEA/STE-D FM 2 I&T) | 2004-06-10 → 2004-08-13 (+64d) | 2004-06-10 → 2004-08-13 (+64d) |  |  | 31d → -5d |  |  |
| 304 | Deliver STE-U FM 1 (stays at UCB for BOOM Suite FM 1 I&T) | 2004-04-22 → 2004-06-16 A (+55d) | 2004-04-22 → 2004-06-16 A (+55d) |  | 0% → 100% | 21d → none |  |  |
| 305 | Deliver STE-U FM 2 (stays at UCB for BOOM Suite FM 2 I&T) | 2004-06-10 → 2004-08-13 (+64d) | 2004-06-10 → 2004-08-13 (+64d) |  |  | 49d → 12d |  |  |
| 309 | **STE-U/D Detector Boards** |  | 2004-06-10 → 2004-08-13 (+64d) | 196d → 241d | 61% → 90% | 49d → 12d |  |  |
| 311 | **FM 1** |  | 2004-04-22 → 2004-06-16 A (+55d) | 162d → 200d | 64% → 100% | 21d → none |  |  |
| 315 | **Integration & Test** |  | 2004-04-22 → 2004-06-16 A (+55d) | 46d → 84d | 11% → 100% | 21d → none |  |  |
| 316 | Integrate & Test STE-U/D FM 1 Detectors W/ FM 1 Housings |  | 2004-04-06 → 2004-04-23 A (+17d) | 34d → 47d | 21% → 100% | 21d → none |  |  |
| 317 | Calibrate STE-U/D FM 1 | 2004-03-24 → 2004-04-12 A (+19d) | 2004-04-16 → 2004-06-14 A (+59d) | 18d → 45d | 0% → 100% | 21d → none |  |  |
| 318 | STE-U FM 1 Thermal Vacuum/Balance/Bake Out | 2004-04-05 → 2004-04-26 A (+21d) | 2004-04-22 → 2004-06-16 A (+55d) | 14d → 31d | 0% → 100% | 21d → none | 317FS-10d → 317FS-6d |  |
| 319 | **FM 2** |  | 2004-06-10 → 2004-08-13 (+64d) | 196d → 241d | 53% → 79% | 49d → 12d |  |  |
| 321 | Load STE FM 2 Detector Printed Wiring Board |  | 2004-03-12 A |  | 84% → 100% | 51d → none |  |  |
| 322 | Test STE FM 2 Detector Printed Wiring Board | 2004-03-15 A | 2004-03-19 → 2004-06-14 A (+87d) | 5d → 65d | 0% → 100% | 51d → none |  |  |
| 323 | **Integration & Test** | 2004-04-19 → 2004-06-15 A (+57d) | 2004-06-10 → 2004-08-13 (+64d) | 38d → 43d | 0% → 21% | 31d → 12d |  |  |
| 324 | Integrate & Test STE-U/D FM 2 Detectors W/ FM 2 Housings | 2004-04-19 → 2004-06-15 A (+57d) | 2004-05-14 → 2004-07-13 (+60d) |  | 0% → 60% | 31d → -5d |  |  |
| 325 | Calibrate STE-U/D FM 2 | 2004-05-03 → 2004-07-07 (+65d) | 2004-06-10 → 2004-08-13 (+64d) |  |  | 31d → -5d | 324FS-10d → 324FS-5d |  |
| 326 | STE-U FM 2 Thermal Vacuum/Bake Out | 2004-05-27 → 2004-08-02 (+67d) | 2004-06-10 → 2004-08-13 (+64d) |  |  | 49d → 12d |  |  |
| 327 | **STE and SWEA - UCB** |  | 2004-09-07 → 2004-11-04 (+58d) | 300d → 340d | 72% → 90% | 14d → -22d |  |  |
| 328 | **Deliveries** | 2004-03-26 → 2004-05-14 A (+49d) | 2004-09-07 → 2004-11-04 (+58d) | 115d → 120d |  | 14d → -22d |  |  |
| 329 | Deliver STE-U FM 1 Interface (stays at UCB for IDPU FM 1 I&T) | 2004-03-26 → 2004-05-14 A (+49d) | 2004-03-26 → 2004-05-14 A (+49d) |  | 0% → 100% | 49d → none |  |  |
| 330 | Deliver STE-U FM 2 Interface (stays at UCB for IDPU FM 2 I&T) | 2004-04-02 → 2004-06-09 A (+68d) | 2004-04-02 → 2004-06-09 A (+68d) |  | 0% → 100% | 80d → none |  |  |
| 331 | Deliver SWEA/STE-D FM 1 (stays at UCB for Boom Suite FM 1 I&T) | 2004-06-21 → 2004-09-03 (+74d) | 2004-06-21 → 2004-09-03 (+74d) |  |  | 7d → -42d | 384 → 383 |  |
| 332 | Deliver SWEA/STE-D FM 2 (stays at UCB for Boom Suite FM 2 I&T) | 2004-09-07 → 2004-11-04 (+58d) | 2004-09-07 → 2004-11-04 (+58d) |  |  | 14d → -22d |  |  |
| 336 | **STE-D Pre-Amp Board** |  | 2004-03-15 → 2004-05-14 A (+60d) | 119d → 163d | 89% → 100% | 63d → none |  |  |
| 337 | **FM 1** |  | 2004-03-15 → 2004-05-14 A (+60d) | 119d → 163d | 87% → 100% | 16d → none |  |  |
| 339 | Load STE-D FM 1 Preamp Printed Wiring Board | 2004-03-09 A | 2004-03-15 → 2004-05-14 A (+60d) | 5d → 49d | 0% → 100% | 16d → none |  |  |
| 340 | **FM 2** |  | 2004-03-15 → 2004-05-14 A (+60d) | 119d → 163d | 87% → 100% | 63d → none |  |  |
| 342 | Load STE-D FM 2 Preamp Printed Wiring Board | 2004-03-09 A | 2004-03-15 → 2004-05-14 A (+60d) | 5d → 49d | 0% → 100% | 63d → none |  |  |
| 344 | **STE-D Shaper Board** |  | 2004-05-21 A |  | 78% → 100% | 14d → none |  |  |
| 345 | **FM 1** |  | 2004-03-11 A |  | 67% → 100% | 18d → none |  |  |
| 347 | Load STE-D FM 1 Shaper Printed Wiring Board | 2004-03-05 A | 2004-03-11 A |  | 0% → 100% | 18d → none |  |  |
| 348 | **FM 2** |  | 2004-05-21 A |  | 67% → 100% | 14d → none |  |  |
| 350 | Load STE-D FM 2 Shaper Printed Wiring Board | 2004-05-17 → 2004-05-03 A (-14d) | 2004-05-21 A | 5d → 15d | 0% → 100% | 14d → none | 351, 382 → 351FS+78d |  |
| 352 | **STE-D Interface Board** |  | 2004-05-21 A |  | 78% → 100% | 14d → none |  |  |
| 353 | **FM 1** |  | 2004-03-11 A |  | 67% → 100% | 18d → none |  |  |
| 355 | Load SWEA / STE-D FM 1 Digital to Analog Converter Printed Wiring Board | 2004-03-05 A | 2004-03-11 A |  | 0% → 100% | 18d → none |  |  |

| ID | Task | Start | Finish | Duration | Complete | Total float | Predecessors | Other |
| --- | --- | --- | --- | --- | --- | --- | --- | --- |
| 356 | **FM 2** |  | 2004-05-21 A |  | 67% → 100% | 14d → none |  |  |
| 358 | Load SWEA / STE-D FM 2 Digital to Analog Converter Printed Wiring Board | 2004-05-17 → 2004-05-03 A (-14d) | 2004-05-21 A | 5d → 15d | 0% → 100% | 14d → none |  |  |
| 360 | **STE-U Pre-Amp Board** |  | 2004-03-15 → 2004-05-11 A (+57d) | 119d → 160d | 95% → 100% | 89d → none |  |  |
| 364 | **FM 2** |  | 2004-03-15 → 2004-05-11 A (+57d) | 119d → 160d | 87% → 100% | 89d → none |  |  |
| 366 | Load STE-U FM 2 Preamp Printed Wiring Board | 2004-03-09 A | 2004-03-15 → 2004-05-11 A (+57d) | 5d → 46d | 0% → 100% | 89d → none |  |  |
| 368 | **STE-U Shaper & Interface Board** |  | 2004-03-26 A |  | 66% → 100% | 80d → none |  |  |
| 369 | **FM 1** |  | 2004-03-19 A |  | 43% → 100% | 49d → none |  |  |
| 371 | Load STE-U FM 1 Shaper & Interface Printed Wiring Board | 2004-03-03 A | 2004-03-19 A |  | 0% → 100% | 49d → none |  |  |
| 372 | **FM 2** |  | 2004-03-26 A |  | 67% → 100% | 80d → none |  |  |
| 374 | Load STE-U FM 2 Shaper & Interface Printed Wiring Board | 2004-03-22 A | 2004-03-26 A |  | 0% → 100% | 80d → none |  |  |
| 376 | **Integration & Test** | 2004-03-16 → 2004-03-22 A (+6d) | 2004-09-07 → 2004-11-04 (+58d) | 124d → 160d | 0% → 51% | 14d → -22d |  |  |
| 377 | **FM 1** | 2004-03-16 → 2004-03-22 A (+6d) | 2004-09-07 → 2004-11-02 (+56d) | 124d → 158d | 0% → 56% | 11d → -23d |  |  |
| 378 | Integrate & Test STE-U FM 1 Interface Boards | 2004-03-22 A | 2004-03-26 → 2004-05-14 A (+49d) | 5d → 40d | 0% → 100% | 49d → none |  |  |
| 379 | Integrate & Test SWEA/STE-D FM 1 Interface Boards | 2004-03-16 → 2004-05-24 A (+69d) | 2004-04-12 → 2004-06-21 A (+70d) |  | 0% → 100% | 16d → none | 334, 339, 347, 355 → 334, 339, 347, 355, 350 |  |
| 380 | Integrate & Test SWEA/STE-D FM 1 Interface with SWEA/STE-D FM 1 LVPS | 2004-04-26 → 2004-07-26 (+91d) | 2004-05-07 → 2004-08-06 (+91d) |  |  | 7d → -42d |  |  |
| 381 | Clean/Coat/Stake SWEA/STE-D Interface | 2004-04-13 → 2004-06-22 A (+70d) | 2004-04-26 → 2004-07-06 (+71d) |  | 0% → 70% | 16d → -19d |  |  |
| 382 | Integrate & Test SWEA/STE-D FM 1 Combined | 2004-05-10 → 2004-08-09 (+91d) | 2004-05-14 → 2004-08-13 (+91d) |  |  | 7d → -42d |  |  |
| 383 | Calibrate SWEA/STE FM 1 | 2004-05-17 → 2004-08-16 (+91d) | 2004-06-14 → 2004-09-03 (+81d) | 20d → 15d |  | 7d → -42d |  |  |
| 384 | SWEA/STE FM 1 Vibration | 2004-06-15 → 2004-10-06 (+113d) | 2004-06-21 → 2004-10-13 (+114d) |  |  | 7d → -23d | 383 → 383, 19 |  |
| 385 | SWEA/STE-D FM 1 Thermal Vac/Thermal Balance/Bake Out | 2004-08-18 → 2004-10-14 (+57d) | 2004-09-07 → 2004-11-02 (+56d) |  |  | 11d → -23d | 19 → 384 |  |
| 386 | **FM 2** | 2004-03-29 → 2004-05-12 A (+44d) | 2004-09-07 → 2004-11-04 (+58d) | 115d → 123d | 0% → 44% | 14d → -22d |  |  |
| 387 | Integrate & Test STE-U FM 2 Interface Boards | 2004-03-29 → 2004-05-12 A (+44d) | 2004-04-02 → 2004-06-09 A (+68d) | 5d → 20d | 0% → 100% | 80d → none |  |  |
| 388 | Integrate & Test SWEA/STE-D FM 2 Interface Boards | 2004-05-24 A | 2004-06-21 A |  | 0% → 100% | 14d → none |  |  |
| 389 | Integrate & Test SWEA/STE-D FM 2 Interface with SWEA/STE-D FM 2 LVPS | 2004-06-22 → 2004-08-25 (+64d) | 2004-07-05 → 2004-09-08 (+65d) |  |  | 14d → -22d |  |  |
| 390 | Integrate & Test SWEA/STE-D FM 2 Combined | 2004-07-06 → 2004-09-09 (+65d) | 2004-07-19 → 2004-09-22 (+65d) |  |  | 14d → -22d |  |  |
| 391 | Calibrate SWEA/STE FM 2 | 2004-07-20 → 2004-09-23 (+65d) | 2004-08-16 → 2004-10-14 (+59d) | 20d → 15d |  | 14d → -22d |  |  |
| 392 | SWEA/STE FM 2 Vibration | 2004-08-17 → 2004-10-15 (+59d) | 2004-08-23 → 2004-10-21 (+59d) |  |  | 14d → -22d |  |  |
| 393 | SWEA/STE-D FM 2 Thermal Vac & bake Out | 2004-08-24 → 2004-10-22 (+59d) | 2004-09-07 → 2004-11-04 (+58d) |  |  | 14d → -22d |  |  |
| 394 | **Boom Suite I&T - UCB** | 2004-04-26 → 2004-06-17 A (+52d) | 2004-10-06 → 2004-11-30 (+55d) | 116d → 114d | 0% → 11% | 14d → -22d |  |  |
| 395 | **FM 1** | 2004-04-26 → 2004-06-17 A (+52d) | 2004-09-21 → 2004-11-09 (+49d) | 105d → 101d | 0% → 27% | 11d → -23d |  |  |
| 396 | FM 1 Boom/MAG/STE-U I&T | 2004-04-26 → 2004-06-17 A (+52d) | 2004-04-29 → 2004-06-22 A (+54d) |  | 0% → 100% | 20d → none |  |  |
| 397 | FM 1 Boom/SWEA/STE/MAG I&T | 2004-06-22 → 2004-09-07 (+77d) | 2004-06-23 → 2004-09-08 (+77d) |  |  | 7d → -42d |  |  |
| 398 | FM 1 Integrated Boom/IDPU I&T | 2004-06-24 → 2004-09-09 (+77d) | 2004-06-29 → 2004-09-14 (+77d) |  |  | 7d → -42d |  |  |
| 399 | Final BOOM Suite FM 1 I & T | 2004-09-08 → 2004-11-03 (+56d) | 2004-09-21 → 2004-11-09 (+49d) | 10d → 5d |  | 11d → -23d | 398, 385 → 398, 385, 224 |  |
| 400 | **FM 2** | 2004-06-11 → 2004-08-16 (+66d) | 2004-10-06 → 2004-11-30 (+55d) | 83d → 73d |  | 14d → -22d |  |  |
| 401 | FM 2 Boom/MAG/STE-U I&T | 2004-06-11 → 2004-08-16 (+66d) | 2004-06-16 → 2004-08-19 (+64d) |  |  | 49d → 12d |  |  |
| 402 | FM 2 Boom/SWEA/STE/MAG I&T | 2004-09-08 → 2004-11-05 (+58d) | 2004-09-09 → 2004-11-08 (+60d) |  |  | 14d → -22d |  |  |
| 403 | FM 2 Integrated Boom/IDPU I&T | 2004-09-10 → 2004-11-09 (+60d) | 2004-09-15 → 2004-11-15 (+61d) |  |  | 14d → -22d | 402, 234, 863 → 402, 234, 228 |  |
| 404 | Boom Suite FM 2 EMC | 2004-09-16 → 2004-11-16 (+61d) | 2004-09-22 → 2004-11-22 (+61d) |  |  | 14d → -22d |  |  |
| 405 | Final BOOM Suite FM 2 I & T | 2004-09-23 → 2004-11-23 (+61d) | 2004-10-06 → 2004-11-30 (+55d) | 10d → 5d |  | 14d → -22d |  |  |
| 406 | **SEP Suite - CIT** |  | 2004-10-26 → 2004-12-20 (+55d) | 355d → 391d | 56% → 80% | 277d → -35d |  |  |
| 407 | **SEP Mechanical - Sandy Shuman (GSFC)** |  | 2004-07-07 → 2004-09-23 (+78d) | 115d → 169d | 27% → 72% | 26d → -29d |  |  |
| 408 | **SIT Electronics Enclosure (Priority 1)** |  | 2004-04-30 → 2004-05-17 A (+17d) | 59d → 70d | 37% → 100% | 28d → none |  |  |
| 410 | Fabrication of SIT Enclosure | 2004-04-08 A | 2004-04-21 → 2004-05-06 A (+15d) | 10d → 21d | 0% → 100% | 28d → none |  |  |
| 411 | Inspection and Final Assembly of SIT Enclosure | 2004-04-22 → 2004-05-07 A (+15d) | 2004-04-29 → 2004-05-14 A (+15d) |  | 0% → 100% | 28d → none |  |  |
| 412 | Deliver SIT Enclosure to UMD | 2004-04-30 → 2004-05-17 A (+17d) | 2004-04-30 → 2004-05-17 A (+17d) |  | 0% → 100% | 28d → none |  |  |
| 413 | **SEP FM 1 & FM 2 LVPS Boxes (Priority 2)** |  | 2004-04-28 → 2004-04-22 A (-6d) | 57d → 53d | 75% → 100% | 13d → none |  |  |
| 416 | Inspection of SEP LVPS Boxes (Final Assembly at UCB) | 2004-04-12 → 2004-04-06 A (-6d) | 2004-04-23 → 2004-04-19 A (-4d) |  | 0% → 100% | 13d → none | 415FS+4d → 415 | was named Inspection and Final Assembly of SEP LVPS Boxes |
| 417 | Deliver SEP LVPS Boxes to UCB | 2004-04-26 → 2004-04-20 A (-6d) | 2004-04-28 → 2004-04-22 A (-6d) |  | 0% → 100% | 13d → none |  |  |
| 418 | **SEP Electronics Enclosure (Priority 3)** |  | 2004-05-21 → 2004-06-24 A (+34d) | 69d → 92d | 46% → 100% | 24d → none |  |  |
| 419 | Complete Design/Drawings for SEP Enclosure |  | 2004-04-19 → 2004-05-27 A (+38d) | 45d → 73d | 71% → 100% | -10d → none |  |  |
| 420 | Fabrication of SEP Enclosure | 2004-04-20 → 2004-05-21 A (+31d) | 2004-05-10 → 2004-06-11 A (+32d) |  | 0% → 100% | 24d → none | 419 → 419FS-5d |  |
| 421 | Inspection and Final Assembly of SEP Enclosure | 2004-05-11 → 2004-06-14 A (+34d) | 2004-05-18 → 2004-06-21 A (+34d) |  | 0% → 100% | 24d → none |  |  |
| 422 | Deliver SEP Enclosure to CIT | 2004-05-19 → 2004-06-22 A (+34d) | 2004-05-21 → 2004-06-24 A (+34d) |  | 0% → 100% | 24d → none |  |  |
| 423 | **SEP Central Bias Supply Shields (Priority 4)** | 2004-04-15 → 2004-05-25 A (+40d) | 2004-05-12 → 2004-06-22 A (+41d) |  | 0% → 100% | -10d → none |  |  |
| 424 | Complete Design/Drawings for Bias Supply Shields | 2004-04-15 → 2004-05-25 A (+40d) | 2004-04-21 → 2004-06-01 A (+41d) |  | 0% → 100% | -10d → none |  |  |
| 425 | Fabrication of Bias Supply Shields | 2004-04-22 → 2004-06-02 A (+41d) | 2004-05-05 → 2004-06-15 A (+41d) |  | 0% → 100% | -10d → none |  |  |
| 426 | Inspection and Delivery (to CIT) of Bias Supply Shields | 2004-05-06 → 2004-06-16 A (+41d) | 2004-05-12 → 2004-06-22 A (+41d) |  | 0% → 100% | -10d → none |  |  |
| 427 | **LET Telescope (Priority 5)** | 2004-04-22 → 2004-05-25 A (+33d) | 2004-06-02 → 2004-06-28 A (+26d) | 29d → 24d | 0% → 100% | 0d → none |  |  |
| 428 | Complete Design/Drawings for LET Telescope | 2004-04-22 → 2004-05-25 A (+33d) | 2004-05-03 → 2004-06-01 A (+29d) | 8d → 5d | 0% → 100% | 0d → none | 424 → 424FS-5d |  |
| 429 | Fabrication of LET Telescope | 2004-05-04 → 2004-06-02 A (+29d) | 2004-05-17 → 2004-06-15 A (+29d) |  | 0% → 100% | 3d → none |  |  |
| 430 | Inspection and Final Assembly of LET Telescope (CIT has detectors) | 2004-05-18 → 2004-06-16 A (+29d) | 2004-05-27 → 2004-06-25 A (+29d) |  | 0% → 100% | 3d → none |  |  |
| 431 | Deliver LET Telescope to CIT | 2004-05-28 → 2004-06-28 A (+31d) | 2004-06-02 → 2004-06-28 A (+26d) | 3d → 1d | 0% → 100% | 3d → none |  |  |
| 432 | **HET Electronics Enclosure (Priority 6)** |  | 2004-05-25 → 2004-06-23 A (+29d) | 47d → 67d | 21% → 100% | -3d → none |  |  |
| 433 | Complete Design/Drawings for HET Enclosure |  | 2004-05-04 → 2004-06-02 A (+29d) |  | 35% → 100% | 0d → none |  |  |
| 434 | Fabrication of HET Enclosure | 2004-05-05 → 2004-06-03 A (+29d) | 2004-05-18 → 2004-06-16 A (+29d) |  | 0% → 100% | -3d → none |  |  |
| 435 | Inspection and Final Assembly of HET Enclosure | 2004-05-19 → 2004-06-17 A (+29d) | 2004-05-25 → 2004-06-23 A (+29d) |  | 0% → 100% | -3d → none |  |  |
| 436 | Deliver HET Enclosure (stays at GSFC) | 2004-05-25 → 2004-06-23 A (+29d) | 2004-05-25 → 2004-06-23 A (+29d) |  | 0% → 100% | -3d → none |  |  |
| 437 | **HET Telescope (Priority 7)** |  | 2004-06-04 → 2004-06-18 A (+14d) | 92d → 102d | 32% → 100% | -3d → none |  |  |
| 438 | On Going work for HET Telescope (Complete Design/Drawings & Prep for Fab) |  | 2004-04-14 → 2004-06-02 A (+49d) | 56d → 89d | 41% → 100% | 1d → none | none → 433FF | constraint start no earlier than 2004-01-27 → finish no earlier than 2004-06-01 |

| ID | Task | Start | Finish | Duration | Complete | Total float | Predecessors | Other |
| --- | --- | --- | --- | --- | --- | --- | --- | --- |
| 439 | Fabrication of HET Telescope | 2004-04-15 → 2004-05-28 A (+43d) | 2004-04-28 → 2004-06-11 A (+44d) |  | 0% → 100% | 16d → none | 438 → 438FS-3d |  |
| 440 | Inspection and Final Assembly of HET Telescope | 2004-05-26 → 2004-06-14 A (+19d) | 2004-06-04 → 2004-06-18 A (+14d) | 7d → 5d | 0% → 100% | -3d → none | 439, 436 → 439, 435SS-3d, 436FS-8d |  |
| 441 | Deliver HET Telescope (stays at GSFC) | 2004-06-04 → 2004-06-18 A (+14d) | 2004-06-04 → 2004-06-18 A (+14d) |  | 0% → 100% | -3d → none |  |  |
| 442 | **SIT Telescope (Priority 9)** | 2004-04-15 → 2004-07-13 (+89d) | 2004-06-09 → 2004-08-31 (+83d) | 39d → 36d |  | 1d → -40d |  | was named SIT Telescope (Priority 8) |
| 443 | Complete Design/Drawings for SIT Telescope | 2004-04-15 → 2004-07-13 (+89d) | 2004-05-10 → 2004-08-09 (+91d) | 18d → 20d |  | 1d → -40d | 438 → 886, 887 |  |
| 444 | Fabrication of SIT Telescope | 2004-05-11 → 2004-07-27 (+77d) | 2004-05-24 → 2004-08-23 (+91d) | 10d → 20d |  | 1d → -40d | 443 → 443FS-10d |  |
| 445 | Inspection and Final Assembly of SIT Telescope | 2004-05-25 → 2004-08-24 (+91d) | 2004-06-08 → 2004-08-30 (+83d) | 10d → 5d |  | 1d → -40d |  |  |
| 446 | Deliver SIT Telescope to UMD (Includes the Foils and Detectors) | 2004-06-09 → 2004-08-31 (+83d) | 2004-06-09 → 2004-08-31 (+83d) |  |  | 1d → -40d |  |  |
| 447 | **Shipping Containers for HET, SIT & SEP Central (Priority 8)** | 2004-05-11 → 2004-05-10 A (-1d) | 2004-06-11 → 2004-06-24 A (+13d) | 23d → 33d | 0% → 100% | 3d → none |  | was named Shipping Containers for HET, SIT & SEP Central (Priority 9) |
| 448 | Design | 2004-05-11 → 2004-05-10 A (-1d) | 2004-05-17 → 2004-05-28 A (+11d) | 5d → 15d | 0% → 100% | 3d → none | 443 → none | constraint none → start no earlier than 2004-05-10 |
| 449 | Fabrication/Machining | 2004-05-18 → 2004-06-01 A (+14d) | 2004-06-01 → 2004-06-14 A (+13d) |  | 0% → 100% | 17d → none |  |  |
| 450 | Inspection and Assembly | 2004-06-02 → 2004-06-15 A (+13d) | 2004-06-08 → 2004-06-21 A (+13d) |  | 0% → 100% | 17d → none |  |  |
| 451 | HET Container stays at GSFC | 2004-06-08 → 2004-06-21 A (+13d) | 2004-06-08 → 2004-06-21 A (+13d) |  | 0% → 100% | 17d → none |  |  |
| 452 | SIT Container to UMD | 2004-06-09 → 2004-06-22 A (+13d) | 2004-06-09 → 2004-06-22 A (+13d) |  | 0% → 100% | 19d → none |  |  |
| 453 | SEP Central Container to CIT | 2004-06-09 → 2004-06-22 A (+13d) | 2004-06-11 → 2004-06-24 A (+13d) |  | 0% → 100% | 34d → none |  |  |
| 469 | **SIT Door (Priority 13)** | 2004-05-18 → 2004-08-17 (+91d) | 2004-06-24 → 2004-09-23 (+91d) |  |  | 3d → -29d |  | was named SIT Door (Priority 10) |
| 470 | Complete Design/Drawings for SIT Door | 2004-05-18 → 2004-08-17 (+91d) | 2004-06-01 → 2004-08-30 (+90d) |  |  | 3d → -29d | 448 → 465 |  |
| 471 | Fabrication | 2004-06-02 → 2004-08-31 (+90d) | 2004-06-15 → 2004-09-14 (+91d) |  |  | 35d → -29d |  |  |
| 472 | Inspection | 2004-06-16 → 2004-09-15 (+91d) | 2004-06-22 → 2004-09-21 (+91d) |  |  | 35d → -29d |  |  |
| 473 | Final Assembly | 2004-06-23 → 2004-09-22 (+91d) | 2004-06-23 → 2004-09-22 (+91d) |  |  | 35d → -29d |  |  |
| 474 | Deliver SIT Door (stay at GSFC for Environmental Testing) | 2004-06-24 → 2004-09-23 (+91d) | 2004-06-24 → 2004-09-23 (+91d) |  |  | 35d → -29d |  |  |
| 475 | **LET Radiation Test Fixture (Priority 14)** | 2004-06-02 → 2004-08-10 (+69d) | 2004-07-07 → 2004-09-15 (+70d) |  |  | 3d → -38d |  | was named LET Radiation Test Fixture (Priority 11) |
| 476 | Design | 2004-06-02 → 2004-08-10 (+69d) | 2004-06-08 → 2004-08-16 (+69d) |  |  | 3d → -38d | 470 → 443 |  |
| 477 | Fabrication | 2004-06-09 → 2004-08-17 (+69d) | 2004-06-22 → 2004-08-30 (+69d) |  |  | 3d → -38d |  |  |
| 478 | Inspection and Assembly | 2004-06-23 → 2004-08-31 (+69d) | 2004-07-06 → 2004-09-14 (+70d) |  |  | 3d → -38d |  |  |
| 479 | Deliver to CIT for SEP I&T | 2004-07-07 → 2004-09-15 (+70d) | 2004-07-07 → 2004-09-15 (+70d) |  |  | 3d → -38d |  |  |
| 480 | **SEP Central - CIT** |  | 2004-06-21 → 2004-08-19 (+59d) | 223d → 265d | 56% → 81% | 37d → 2d |  |  |
| 481 | **Deliveries** | 2004-04-14 → 2004-06-28 A (+75d) | 2004-06-21 → 2004-08-19 (+59d) | 47d → 37d |  | 37d → 2d |  |  |
| 482 | Deliver all SEP Cen FM 1 Boards to SEP I&T (stays at CIT) | 2004-06-21 → 2004-06-28 A (+7d) | 2004-06-21 → 2004-06-28 A (+7d) |  | 0% → 100% | 4d → none | 506 → 491, 494, 501, 67FS+19d |  |
| 483 | Deliver all SEP Cen FM 2 Boards & FM 2 LVPS to SEP I&T (stays at CIT) | 2004-06-21 → 2004-06-29 A (+8d) | 2004-06-21 → 2004-06-29 A (+8d) |  | 0% → 100% | 37d → none | 506 → 73, 426, 492, 495, 502 |  |
| 484 | SEP Central Build 3 Software Complete | 2004-04-14 → 2004-06-30 (+77d) | 2004-04-14 → 2004-06-30 (+77d) |  |  | 51d → 37d |  |  |
| 485 | Final SEP Central Flight Software Complete | 2004-06-03 → 2004-08-19 (+77d) | 2004-06-03 → 2004-08-19 (+77d) |  |  | 30d → -20d |  |  |
| 486 | **Logic Board** |  | 2004-03-26 → 2004-05-28 A (+63d) | 30d → 75d | 33% → 100% | 33d → none |  |  |
| 490 | **Test** | 2004-03-01 A | 2004-03-26 → 2004-05-28 A (+63d) | 20d → 65d | 0% → 100% | 33d → none |  |  |
| 491 | Test FM 1 SEP Central Logic board (initial) | 2004-03-01 A | 2004-03-26 A |  | 0% → 100% | 33d → none |  |  |
| 492 | Test FM 2 SEP Central Logic board (initial) | 2004-03-01 A | 2004-03-26 → 2004-05-28 A (+63d) | 20d → 65d | 0% → 100% | 33d → none |  |  |
| 496 | **SEP Solid State Detector Bias Supply Board** |  | 2004-05-26 → 2004-04-06 A (-50d) | 91d → 55d | 56% → 100% | -10d → none |  |  |
| 497 | **Assembly & Initial Test** |  | 2004-03-16 A |  | 70% → 100% | 31d → none |  |  |
| 498 | Assemble and Initial Test FM 1 SSD Bias Supply Board |  | 2004-03-16 A |  | 70% → 100% | 31d → none |  |  |
| 499 | Assemble and Initial Test FM 2 SSD Bias Supply Board |  | 2004-03-16 A |  | 70% → 100% | 31d → none |  |  |
| 500 | **Final Test** | 2004-05-13 → 2004-03-17 A (-57d) | 2004-05-26 → 2004-04-06 A (-50d) | 10d → 15d | 0% → 100% | -10d → none |  |  |
| 501 | Final Test FM 1 SSD Bias Supply Board | 2004-05-13 → 2004-03-17 A (-57d) | 2004-05-26 → 2004-04-06 A (-50d) | 10d → 15d | 0% → 100% | -10d → none | 498, 426 → 498 |  |
| 502 | Final Test FM 2 SSD Bias Supply Board | 2004-05-13 → 2004-03-17 A (-57d) | 2004-05-26 → 2004-04-06 A (-50d) | 10d → 15d | 0% → 100% | -10d → none | 499, 426 → 499 |  |
| 503 | **Conformal Coat, Mass Properties and Bake Out (SEP Central, LET, SEP LVPS)** | 2004-05-27 → 2004-07-21 (+55d) | 2004-06-21 → 2004-08-10 (+50d) | 17d → 15d |  | -10d → -17d |  |  |
| 504 | Stake/Conformal Coat All SEP Central and LET Boards | 2004-05-27 → 2004-07-21 (+55d) | 2004-06-10 → 2004-07-30 (+50d) | 10d → 8d |  | -10d → -17d | 491, 492, 494, 495, 501, 502, 582, 583 → 891 |  |
| 505 | Mass Properties/Photo All SEP Central and LET Boards | 2004-06-11 → 2004-08-02 (+52d) | 2004-06-16 → 2004-08-05 (+50d) |  |  | -10d → -17d |  |  |
| 506 | Bake Out All SEP Central/LET Boards and SEP LVPS FM 1 | 2004-06-17 → 2004-08-06 (+50d) | 2004-06-21 → 2004-08-10 (+50d) |  |  | -10d → -17d | 505, 73, 67 → 505, 67 | was named Bake Out All SEP Central/LET Boards and SEP LVPS (FM 1 & 2) |
| 507 | **Flight Software** |  | 2004-06-03 → 2004-08-19 (+77d) | 211d → 265d | 68% → 71% | 30d → -20d |  |  |
| 508 | SEP Central Build 3 |  | 2004-04-14 → 2004-06-30 (+77d) | 176d → 230d | 81% → 82% | 30d → -20d |  |  |
| 509 | Final Flight S/W Build | 2004-04-15 → 2004-07-01 (+77d) | 2004-06-03 → 2004-08-19 (+77d) |  |  | 30d → -20d |  |  |
| 510 | **HET - Tycho (GSFC)** |  | 2004-07-29 → 2004-09-09 (+42d) | 145d → 173d | 48% → 89% | 15d → -6d |  |  |
| 511 | **Deliveries** | 2004-05-18 → 2004-06-28 A (+41d) | 2004-07-29 → 2004-09-09 (+42d) |  | 0% → 60% | 15d → -6d |  |  |
| 512 | Deliver HET FM 1w/o replacement detectors (to CIT for SEP Suite I&T) | 2004-07-07 → 2004-06-28 A (-9d) | 2004-07-08 → 2004-06-29 A (-9d) |  | 0% → 100% | -3d → none | 451, 561 → 451, 558 | was named Deliver HET FM 1 (to CIT for SEP Suite I&T) |
| 515 | Deliver HET FM 2 w/ replacement detectors (to CIT for SEP Suite I&T) | 2004-07-28 → 2004-09-08 (+42d) | 2004-07-29 → 2004-09-09 (+42d) |  |  | 15d → -6d | 564, 451 → 468, 567 | was named Deliver HET FM 2 (to CIT for SEP Suite I&T) |
| 516 | Deliver Final HET Flight Software to SEP I&T | 2004-05-18 → 2004-06-28 A (+41d) | 2004-05-19 → 2004-06-29 A (+41d) |  | 0% → 100% | 32d → none |  |  |
| 522 | **Replacement HET Detectors (Batch 2)** |  | 2004-06-14 → 2004-08-13 (+60d) | 66d → 109d | 0% → 73% | 11d → 0d |  |  |
| 525 | Detector Mounting at Micron | 2004-04-15 A | 2004-05-12 A |  | 0% → 100% | 11d → none |  |  |
| 526 | Detector Delivery to GSFC | 2004-05-13 A | 2004-05-14 → 2004-06-28 A (+45d) | 2d → 32d | 0% → 100% | 11d → none |  |  |
| 527 | Detector Testing at GSFC | 2004-05-17 A | 2004-06-14 → 2004-08-13 (+60d) | 20d → 63d | 0% → 51% | 11d → -26d | 526 → 526FS-20d |  |
| 528 | **Electronics Board** |  | 2004-05-11 → 2004-08-05 (+86d) | 78d → 138d | 42% → 76% | 48d → 14d |  |  |
| 529 | **Assembly** |  | 2004-03-16 A |  | 50% → 100% | 59d → none |  |  |
| 532 | Complete Population of HET Electronics FM 2 Board (Flight ACTEL) | 2004-03-15 A | 2004-03-16 A |  | 0% → 100% | 59d → none |  |  |
| 533 | **Test** |  | 2004-05-11 → 2004-08-05 (+86d) | 76d → 136d | 42% → 75% | 48d → 14d |  |  |
| 534 | **FM 1** |  | 2004-03-26 → 2004-08-05 (+132d) | 44d → 136d | 55% → 77% | 46d → -20d |  |  |
| 538 | Retest HET FM 1 Electronics Board w/Flight ACTEL | 2004-03-01 A | 2004-03-12 A |  | 0% → 100% | 46d → none |  |  |
| 539 | Clean, Bake, Conformal Coat HET FM 1 Electronics Board | 2004-03-15 → 2004-07-23 (+130d) | 2004-03-19 → 2004-07-29 (+132d) |  |  | 46d → -20d | 538 → 538FS+61d, 559 |  |
| 540 | Retest Conformal Coated HET FM 1 Electronics Board | 2004-03-22 → 2004-07-30 (+130d) | 2004-03-26 → 2004-08-05 (+132d) |  |  | 46d → -20d |  |  |
| 541 | **FM 2** |  | 2004-05-11 → 2004-08-05 (+86d) | 40d → 100d | 28% → 71% | 48d → 14d |  |  |
| 542 | Test HET FM 2 Electronics Board |  | 2004-04-27 → 2004-04-20 A (-7d) | 30d → 25d | 37% → 100% | 48d → none |  |  |
| 543 | Clean, Bake, Conformal Coat HET FM 2 Electronics Board | 2004-04-28 → 2004-07-23 (+86d) | 2004-05-04 → 2004-07-29 (+86d) |  |  | 48d → 14d | 542 → 565 |  |

| ID | Task | Start | Finish | Duration | Complete | Total float | Predecessors | Other |
| --- | --- | --- | --- | --- | --- | --- | --- | --- |
| 544 | Retest Conformal Coated HET FM 2 Electronics Board | 2004-05-05 → 2004-07-30 (+86d) | 2004-05-11 → 2004-08-05 (+86d) |  |  | 48d → 14d | 543, 540 → 543 |  |
| 545 | **Flight Software** |  | 2004-05-17 → 2004-06-25 A (+39d) | 82d → 110d | 32% → 100% | 10d → none |  |  |
| 546 | **Design** |  | 2004-02-23 A → 2004-04-30 A (+67d) | 22d → 71d |  |  |  |  |
| 549 | **Coding** |  | 2004-03-22 → 2004-05-21 A (+60d) | 20d → 64d | 20% → 100% | 10d → none |  |  |
| 550 | Code HET PH Event Processing Update for Flight |  | 2004-03-08 → 2004-05-14 A (+67d) | 10d → 59d | 40% → 100% | 10d → none |  |  |
| 551 | Code HET Telemetry Formatting Update for Flight | 2004-03-09 → 2004-03-12 A (+3d) | 2004-03-22 → 2004-05-21 A (+60d) | 10d → 34d | 0% → 100% | 10d → none | 550 → 550FS-15d |  |
| 552 | **Test** | 2004-03-23 A | 2004-05-17 → 2004-06-25 A (+39d) | 40d → 68d | 0% → 100% | 10d → none |  |  |
| 553 | Test Integrated HET S/W with Simulated Data | 2004-03-23 A | 2004-04-12 → 2004-06-18 A (+67d) | 15d → 63d | 0% → 100% | 10d → none | 551 → none | constraint none → start no later than 2004-03-23 |
| 554 | Verify HET On-Board Software | 2004-04-13 → 2004-06-21 A (+69d) | 2004-05-17 → 2004-06-25 A (+39d) | 25d → 5d | 0% → 100% | 10d → none | 553 → 548, 553 |  |
| 555 | **Integration & Test** | 2004-06-07 → 2004-06-21 A (+14d) | 2004-07-27 → 2004-08-17 (+21d) | 37d → 41d | 0% → 71% | -3d → 8d |  |  |
| 556 | **FM 1** | 2004-06-07 → 2004-06-21 A (+14d) | 2004-07-06 → 2004-08-17 (+42d) | 22d → 41d | 0% → 71% | -3d → -26d |  |  |
| 557 | Integrate HET FM 1 Electronics Telescope (Ahead) | 2004-06-07 → 2004-06-21 A (+14d) | 2004-06-11 → 2004-06-23 A (+12d) | 5d → 3d | 0% → 100% | -3d → none | 521, 554, 441, 540 → 521, 554FS-10d, 441 |  |
| 558 | Test HET FM 1 Telescope (Ahead) | 2004-06-14 → 2004-06-24 A (+10d) | 2004-07-02 → 2004-06-25 A (-7d) | 15d → 2d | 0% → 100% | -3d → none |  |  |
| 560 | Install new HET Flight Detectors in FM 1 | 2004-07-05 → 2004-08-16 (+42d) | 2004-07-05 → 2004-08-16 (+42d) |  |  | -3d → -26d | 527, 558 → 527, 559, 540 |  |
| 561 | Performance Test FM 1 with New Flight Detectors | 2004-07-06 → 2004-08-17 (+42d) | 2004-07-06 → 2004-08-17 (+42d) |  |  | -3d → -26d | 560 → 560, 551 |  |
| 562 | **FM 2** | 2004-06-14 → 2004-06-21 A (+7d) | 2004-07-27 → 2004-08-17 (+21d) | 32d → 41d | 0% → 71% | 15d → 8d |  |  |
| 563 | Integrate HET FM 2 Electronics Telescope (Behind) | 2004-06-14 → 2004-06-21 A (+7d) | 2004-06-18 → 2004-06-23 A (+5d) | 5d → 3d | 0% → 100% | 26d → none | 557, 521, 554, 441, 544 → 521, 554FS-10d, 441, 542 |  |
| 564 | Test HET FM 2 Telescope (Behind) | 2004-07-07 → 2004-06-24 A (-13d) | 2004-07-27 → 2004-06-25 A (-32d) | 15d → 2d | 0% → 100% | 15d → none | 566 → 563 |  |
| 566 | Install new HET Flight Detectors in FM 2 | 2004-07-06 → 2004-08-16 (+41d) | 2004-07-06 → 2004-08-16 (+41d) |  |  | 15d → 8d | 563, 527, 560 → 527, 565, 544 |  |
| 568 | **LET - CIT** |  | 2004-07-19 → 2004-07-01 A (-18d) | 257d → 245d | 76% → 100% | 23d → none |  |  |
| 569 | **Deliveries** | 2004-05-04 → 2004-06-25 A (+52d) | 2004-07-19 → 2004-07-01 A (-18d) | 53d → 4d | 0% → 100% | 23d → none |  |  |
| 570 | Deliver LET FM 1 (stays at CIT for SEP I&T) | 2004-07-19 → 2004-07-01 A (-18d) | 2004-07-19 → 2004-07-01 A (-18d) |  | 0% → 100% | -10d → none |  |  |
| 571 | Deliver LET FM 2 (stays at CIT for SEP I&T) | 2004-07-19 → 2004-07-01 A (-18d) | 2004-07-19 → 2004-07-01 A (-18d) |  | 0% → 100% | 23d → none |  |  |
| 572 | Deliver LET Flight Software Build 3 | 2004-05-04 → 2004-06-25 A (+52d) | 2004-05-04 → 2004-06-25 A (+52d) |  | 0% → 100% | 43d → none |  |  |
| 573 | **Detectors** |  | 2004-03-12 A |  | 94% → 100% | 60d → none |  |  |
| 574 | Complete LET Flight Detector Testing |  | 2004-03-12 A |  | 94% → 100% | 60d → none |  |  |
| 577 | **Detector/Misc Board** | 2004-03-02 A | 2004-03-30 → 2004-06-24 A (+86d) | 21d → 82d | 0% → 100% | 31d → none |  |  |
| 578 | **Assembly** | 2004-03-02 A | 2004-03-15 A |  | 0% → 100% | 31d → none |  |  |
| 579 | Assemble LET FM 1 Detector Board | 2004-03-02 A | 2004-03-15 A |  | 0% → 100% | 31d → none |  |  |
| 580 | Assemble LET FM 2 Detector Board | 2004-03-02 A | 2004-03-15 A |  | 0% → 100% | 31d → none |  |  |
| 581 | **Test** | 2004-03-16 A | 2004-03-30 → 2004-06-24 A (+86d) | 11d → 72d | 0% → 100% | 31d → none |  |  |
| 582 | Test LET FM 1 Detector Board | 2004-03-16 A | 2004-03-30 → 2004-06-24 A (+86d) | 11d → 72d | 0% → 100% | 31d → none |  |  |
| 583 | Test LET FM 2 Detector Board | 2004-03-16 A | 2004-03-30 → 2004-06-24 A (+86d) | 11d → 72d | 0% → 100% | 31d → none |  |  |
| 584 | **Flight Software** |  | 2004-05-04 → 2004-06-25 A (+52d) | 190d → 227d | 75% → 100% | 43d → none |  |  |
| 585 | Let Flight Software Build 3 |  | 2004-05-04 → 2004-06-25 A (+52d) | 190d → 227d | 75% → 100% | 43d → none |  |  |
| 586 | **Integration & Test** | 2004-06-22 → 2004-06-29 A (+7d) | 2004-07-19 → 2004-07-01 A (-18d) | 20d → 3d | 0% → 100% | -10d → none |  |  |
| 587 | **FM 1** | 2004-06-22 → 2004-06-29 A (+7d) | 2004-07-19 → 2004-07-01 A (-18d) | 20d → 3d | 0% → 100% | -10d → none |  |  |
| 588 | Integrate LET FM 1 Housing With Detectors | 2004-06-22 → 2004-06-29 A (+7d) | 2004-07-19 → 2004-07-01 A (-18d) | 20d → 3d | 0% → 100% | -10d → none | 574, 506, 431 → 574, 431, 582 |  |
| 589 | **FM 2** | 2004-06-22 → 2004-06-29 A (+7d) | 2004-07-19 → 2004-07-01 A (-18d) | 20d → 3d | 0% → 100% | 23d → none |  |  |
| 590 | Integrate LET FM 2 Housing With Detectors | 2004-06-22 → 2004-06-29 A (+7d) | 2004-07-19 → 2004-07-01 A (-18d) | 20d → 3d | 0% → 100% | 23d → none | 574, 506, 431 → 574, 431, 583 |  |
| 591 | **SEPT - Kiel/ESTEC** |  | 2004-09-02 → 2004-11-29 (+88d) | 271d → 328d | 90% → 76% | 23d → -26d |  |  |
| 592 | **Deliveries** | 2004-03-15 → 2004-08-23 (+161d) | 2004-09-02 → 2004-11-29 (+88d) | 123d → 67d |  | 23d → -31d |  |  |
| 593 | Deliver SEPT-NS FM 1 to CIT for SEP I&T and Suite EMC | 2004-03-15 → 2004-08-23 (+161d) | 2004-03-19 → 2004-08-27 (+161d) |  |  | 73d → -31d | 633, 634 → 640 |  |
| 594 | Deliver SEPT-E FM 1 to CIT for SEP I&T and Suite EMC | 2004-03-15 → 2004-08-23 (+161d) | 2004-03-19 → 2004-08-27 (+161d) |  |  | 73d → -31d | 650, 649 → 656 |  |
| 595 | Final Delivery of SEPT FM 1 to APL | 2004-09-01 → 2004-11-12 (+72d) | 2004-09-02 → 2004-11-15 (+74d) |  |  | 23d → -26d | 642, SEPT-E FM 1 Thermal Balance (at GSFC after Suite EMC), 626 → 626, 644, 660 | was named Final Delivery of SEPT FM 1 to APL (after Therm Bal @ GSFC) |
| 596 | Deliver SEPT-NS FM 2 to CIT for Suite EMC and final delivery to APL | 2004-03-18 → 2004-11-22 (+249d) | 2004-03-24 → 2004-11-29 (+250d) |  |  | 103d → -26d | 666, 667 → 677 | was named Deliver SEPT-NS FM 2 to CIT for SEP I&T and Suite EMC |
| 597 | Deliver SEPT-E FM 2 to CIT for Suite EMC and final delivery to APL | 2004-03-18 → 2004-11-22 (+249d) | 2004-03-24 → 2004-11-29 (+250d) |  |  | 103d → -26d | 682, 683 → 693 | was named Deliver SEPT-E FM 2 to CIT for SEP I&T and Suite EMC |
| 607 | **Electronics** |  | 2004-05-21 → 2004-09-07 (+109d) | 198d → 272d | 94% → 90% | 94d → 19d |  |  |
| 608 | **Assembly** |  | 2004-04-15 A |  | 97% → 100% | 105d → none |  |  |
| 612 | **Spare** |  | 2004-04-15 A |  | 94% → 100% | 105d → none |  |  |
| 613 | Assemble SEPT FS Electronics |  | 2004-04-15 A |  | 94% → 100% | 105d → none |  |  |
| 614 | **Test** |  | 2004-05-21 → 2004-09-07 (+109d) | 113d → 187d | 70% → 71% | 94d → 19d |  |  |
| 615 | **FM 2** |  | 2004-01-30 A → 2004-08-31 (+214d) | 34d → 183d | 100% → 69% | none → 19d |  |  |
| 623 | **Spare** | 2004-04-26 A | 2004-05-21 → 2004-09-07 (+109d) | 20d → 94d | 0% → 76% | 94d → 19d |  |  |
| 624 | SEPT Flight Spare Electronics Test | 2004-04-26 A | 2004-04-30 A |  | 0% → 100% | 99d → none |  |  |
| 625 | Coat SEPT FS Electronics Board | 2004-05-10 A | 2004-05-14 → 2004-06-18 (+35d) | 5d → 29d | 0% → 83% | 94d → 3d |  |  |
| 626 | SEPT FS Mechanical Integration | 2004-05-17 → 2004-09-01 (+107d) | 2004-05-21 → 2004-09-07 (+109d) | 5d → 4d |  | 94d → 19d | 625 → 625, 622 |  |
| 627 | **Integration & Test** |  | 2004-08-31 → 2004-11-19 (+80d) | 164d → 218d | 84% → 62% | 23d → -26d |  |  |
| 628 | **FM 1** |  | 2004-08-31 → 2004-11-10 (+71d) | 164d → 212d | 73% → 62% | 23d → -26d |  |  |
| 629 | **SEPT-NS** |  | 2004-08-31 → 2004-11-10 (+71d) | 155d → 203d | 73% → 62% | 23d → -26d |  |  |
| 642 | SEPT-NS FM 1 Thermal Balance (at GSFC after Suite EMC) | 2004-08-18 → 2004-10-13 (+56d) | 2004-08-31 → 2004-10-26 (+56d) |  |  | 23d → -26d | 19 → 641 |  |
| 645 | **SEPT-E** |  | 2004-08-31 → 2004-11-10 (+71d) | 164d → 212d | 73% → 62% | 23d → -26d |  |  |
| 661 | **FM 2** |  | 2004-03-17 A → 2004-11-19 (+247d) | 46d → 218d | 100% → 62% | none → -26d |  |  |
| 662 | **SEPT-NS** |  | 2004-03-17 A → 2004-11-19 (+247d) | 41d → 213d | 100% → 62% | none → -26d |  |  |
| 678 | **SEPT-E** |  | 2004-03-17 A → 2004-11-19 (+247d) | 46d → 218d | 100% → 61% | none → -26d |  |  |
| 694 | **SIT - UMD** |  | 2004-10-22 → 2004-12-14 (+53d) | 353d → 387d | 51% → 82% | 279d → -36d |  |  |
| 695 | **Deliveries** | 2004-07-26 → 2004-09-16 (+52d) | 2004-10-22 → 2004-12-14 (+53d) | 63d → 61d |  | -13d → -40d |  |  |
| 696 | Deliver SIT FM 1 to CIT for SEP I&T and Suite EMC | 2004-07-26 → 2004-09-16 (+52d) | 2004-07-27 → 2004-09-17 (+52d) |  |  | -13d → -40d |  |  |
| 697 | Deliver SIT FM 1 back to GSFC for Environmental Testing (after EMC Test) | 2004-08-18 → 2004-10-06 (+49d) | 2004-08-19 → 2004-10-07 (+49d) |  |  | -3d → -37d |  |  |
| 698 | Final Delivery of SIT FM 1 to APL | 2004-10-12 → 2004-12-01 (+50d) | 2004-10-12 → 2004-12-01 (+50d) |  |  | -3d → -37d |  |  |

| ID | Task | Start | Finish | Duration | Complete | Total float | Predecessors | Other |
| --- | --- | --- | --- | --- | --- | --- | --- | --- |
| 699 | Final Delivery of SIT FM 2 to CIT for Suie EMC | 2004-10-22 → 2004-12-14 (+53d) | 2004-10-22 → 2004-12-14 (+53d) |  |  | 3d → -36d |  | was named Final Delivery of SIT FM 2 to APL |
| 700 | **ACTEL - for SIT Logic Board** | 2004-05-17 → 2004-05-24 A (+7d) | 2004-06-01 → 2004-05-24 A (-8d) | 11d → 1d | 0% → 100% | 8d → none |  |  |
| 701 | Burn Final SIT ACTEL Chip w/latest algorithm (at GSFC) | 2004-05-17 → 2004-05-24 A (+7d) | 2004-05-17 → 2004-05-24 A (+7d) |  | 0% → 100% | 8d → none |  | was named Burn Final SIT ACTEL Chip (at GSFC); constraint start no earlier than 2004-05-17 → start no earlier than 2004-05-24 |
| 702 | Evaluate (Test) SIT Final ACTEL Chip | 2004-05-18 → 2004-05-24 A (+6d) | 2004-06-01 → 2004-05-24 A (-8d) | 10d → 0d | 0% → 100% | 8d → none |  |  |
| 703 | **TOF Boards** |  | 2004-05-05 → 2004-07-30 (+86d) | 59d → 119d | 38% → 88% | 28d → -10d |  |  |
| 705 | Receive Analog and Digital TOF Boards (FM 2) | 2004-03-25 A | 2004-04-21 → 2004-05-28 A (+37d) |  | 0% → 100% | 28d → none | 708 → 708FS+32d |  |
| 706 | **Test** |  | 2004-05-05 → 2004-07-30 (+86d) | 48d → 108d | 64% → 78% | 28d → -10d |  |  |
| 709 | **FM 2** | 2004-04-22 → 2004-07-26 (+95d) | 2004-05-05 → 2004-07-30 (+86d) | 10d → 5d |  | 28d → -10d |  |  |
| 710 | FM 2 TOF Boards Functional Test | 2004-04-22 → 2004-07-26 (+95d) | 2004-05-05 → 2004-07-30 (+86d) | 10d → 5d |  | 28d → -10d | 704, 705 → 704, 705FS+38d |  |
| 711 | **Energy Board** |  | 2004-05-14 → 2004-06-04 A (+21d) | 129d → 143d | 81% → 100% | 21d → none |  |  |
| 712 | **Assembly** |  | 2004-04-23 A |  | 94% → 100% | 21d → none |  |  |
| 715 | **FM 2** |  | 2004-04-23 A |  | 88% → 100% | 21d → none |  |  |
| 716 | Assemble FM 2 Energy Board |  | 2004-04-23 A | 84d → 82d | 88% → 100% | 21d → none |  |  |
| 717 | **Test** | 2004-03-25 A | 2004-05-14 → 2004-06-04 A (+21d) | 37d → 51d | 0% → 100% | 12d → none |  |  |
| 718 | **FM 1** | 2004-03-25 A | 2004-04-14 → 2004-06-03 A (+50d) | 15d → 50d | 0% → 100% | 12d → none |  |  |
| 719 | Bench Test/Calibration | 2004-03-25 A | 2004-04-07 → 2004-05-28 A (+51d) | 10d → 47d | 0% → 100% | 12d → none |  |  |
| 720 | Thermal | 2004-04-08 → 2004-06-01 A (+54d) | 2004-04-12 → 2004-06-03 A (+52d) |  | 0% → 100% | 12d → none |  |  |
| 721 | Voltage Margin | 2004-04-13 → 2004-06-01 A (+49d) | 2004-04-14 → 2004-06-02 A (+49d) |  | 0% → 100% | 12d → none | 720 → 720SS |  |
| 722 | **FM 2** | 2004-04-26 → 2004-05-26 A (+30d) | 2004-05-14 → 2004-06-04 A (+21d) | 15d → 7d | 0% → 100% | 21d → none |  |  |
| 723 | FM 2 Energy Board Functional Test | 2004-04-26 → 2004-05-26 A (+30d) | 2004-05-14 → 2004-06-04 A (+21d) | 15d → 7d | 0% → 100% | 21d → none | 716, 721 → 716, 721FS-5d |  |
| 724 | **Logic Board** |  | 2004-07-30 → 2004-07-21 (-9d) | 183d → 175d | 61% → 94% | 1d → -3d |  |  |
| 729 | **Assembly** | 2004-04-14 → 2004-05-25 A (+41d) | 2004-07-28 → 2004-07-14 (-14d) | 75d → 35d | 0% → 73% | -13d → -3d |  |  |
| 730 | **FM 1** | 2004-04-14 → 2004-05-25 A (+41d) | 2004-07-05 → 2004-06-04 A (-31d) | 58d → 8d | 0% → 100% | -13d → none |  |  |
| 731 | Assemble FM 1 Logic Board with Flight ACTELs | 2004-04-14 → 2004-05-25 A (+41d) | 2004-04-28 → 2004-06-04 A (+37d) | 11d → 8d | 0% → 100% | -13d → none | 738FS+9d → 738, 702 | was named Assemble FM 1 Logic Board with ETU ACTELs |
| 732 | **FM 2** | 2004-04-14 → 2004-07-12 (+89d) | 2004-07-28 → 2004-07-14 (-14d) | 75d → 3d |  | 1d → -3d |  |  |
| 733 | Assemble FM 2 Logic Board with Flight ACTELS | 2004-04-14 → 2004-07-12 (+89d) | 2004-04-28 → 2004-07-14 (+77d) | 11d → 3d |  | 18d → -3d | 738FS+9d → 738, 702, 740FS+13d | was named Assemble FM 2 Logic Board with ETU ACTELS |
| 734 | **Test** |  | 2004-07-30 → 2004-07-21 (-9d) | 183d → 175d | 72% → 95% | 1d → -3d |  |  |
| 739 | **FM 1** | 2004-04-29 → 2004-06-07 A (+39d) | 2004-07-07 → 2004-06-21 A (-16d) | 49d → 11d | 0% → 100% | -13d → none |  |  |
| 740 | Functional Test of FM 1 Logic Board w/Flight ACTELS | 2004-04-29 → 2004-06-07 A (+39d) | 2004-05-19 → 2004-06-21 A (+33d) | 15d → 11d | 0% → 100% | -13d → none |  | was named Functional Test of FM 1 Logic Board w/ETU ACTELS |
| 741 | **FM 2** | 2004-05-20 → 2004-07-15 (+56d) | 2004-07-30 → 2004-07-21 (-9d) | 51d → 5d |  | 1d → -3d |  |  |
| 742 | Functional Test of FM 2 Logic Board w/Flight ACTELS | 2004-07-29 → 2004-07-15 (-14d) | 2004-07-30 → 2004-07-21 (-9d) | 2d → 5d |  | 1d → -3d | Reassemble FM 2 Logic Boards → 733 | baseline start 2004-07-08 → 2004-04-14; baseline finish 2004-07-09 → 2004-05-04 |
| 743 | **Mother Board** |  | 2004-05-24 → 2004-06-22 A (+29d) | 107d → 127d | 57% → 100% | 2d → none |  |  |
| 748 | **Fabrication** |  | 2004-04-19 A |  | 50% → 100% | -11d → none |  |  |
| 749 | **FM 1 & FM 2** |  | 2004-04-19 A |  | 50% → 100% | -11d → none |  |  |
| 751 | Refabricate FM1 & FM2 Mother Boards | 2004-03-30 A | 2004-04-19 A |  | 0% → 100% | -11d → none |  |  |
| 752 | **Assembly** | 2004-04-27 → 2004-05-10 A (+13d) | 2004-05-10 → 2004-05-21 A (+11d) |  | 0% → 100% | -11d → none |  |  |
| 753 | Assemble FM 1 Mother Board | 2004-04-27 → 2004-05-10 A (+13d) | 2004-05-10 → 2004-05-21 A (+11d) |  | 0% → 100% | -11d → none | 750, 758 → 750, 758FS+9d |  |
| 754 | Assemble FM 2 Mother Board | 2004-04-27 → 2004-05-10 A (+13d) | 2004-05-10 → 2004-05-21 A (+11d) |  | 0% → 100% | 7d → none |  |  |
| 755 | **Test** |  | 2004-05-24 → 2004-06-22 A (+29d) | 62d → 82d | 25% → 100% | 2d → none |  |  |
| 756 | **FM 1 & FM 2** |  | 2004-04-26 A |  | 50% → 100% | -11d → none |  |  |
| 758 | Coupon Testing of 2nd Mother Boards | 2004-04-20 A | 2004-04-26 A |  | 0% → 100% | -11d → none |  |  |
| 759 | **FM 1** | 2004-05-11 → 2004-06-14 A (+34d) | 2004-05-17 → 2004-06-22 A (+36d) | 5d → 7d | 0% → 100% | -11d → none |  |  |
| 760 | Functional Test FM 1 Mother Board | 2004-05-11 → 2004-06-14 A (+34d) | 2004-05-17 → 2004-06-22 A (+36d) | 5d → 7d | 0% → 100% | -11d → none | 753 → 753FS+14d |  |
| 761 | **FM 2** | 2004-05-18 → 2004-06-15 A (+28d) | 2004-05-24 → 2004-06-22 A (+29d) | 5d → 6d | 0% → 100% | 2d → none |  |  |
| 762 | Functional Test FM 2 Mother Board | 2004-05-18 → 2004-06-15 A (+28d) | 2004-05-24 → 2004-06-22 A (+29d) | 5d → 6d | 0% → 100% | 2d → none | 754, 760 → 754, 760SS+1d |  |
| 763 | **HVPS** |  | 2004-06-08 → 2004-09-01 (+85d) | 104d → 164d |  | 2d → -36d |  |  |
| 764 | **Test** |  | 2004-06-08 → 2004-09-01 (+85d) | 104d → 164d |  | 2d → -36d |  |  |
| 767 | **FM 2** | 2004-05-25 → 2004-08-19 (+86d) | 2004-06-08 → 2004-09-01 (+85d) |  |  | 2d → -36d |  |  |
| 768 | Functional Test SIT FM 2 HVPS | 2004-05-25 → 2004-08-19 (+86d) | 2004-06-08 → 2004-09-01 (+85d) |  |  | 2d → -36d |  |  |
| 769 | **Flight Software** |  | 2004-04-01 → 2004-05-06 A (+35d) | 210d → 235d | 89% → 100% | 48d → none |  |  |
| 770 | **Test** |  | 2004-04-01 → 2004-05-06 A (+35d) | 210d → 235d | 89% → 100% | 48d → none |  |  |
| 771 | **FM 1 & FM 2** |  | 2004-04-01 → 2004-05-06 A (+35d) | 210d → 235d | 89% → 100% | 48d → none |  |  |
| 772 | Validate SIT On-Board Code |  | 2004-04-01 → 2004-05-06 A (+35d) | 210d → 235d | 89% → 100% | 48d → none |  |  |
| 773 | **Integration & Test (using ETU Telescope for FM 1)** |  | 2004-08-12 → 2004-10-29 (+78d) | 121d → 174d | 4% → 9% | 1d → -36d |  |  |
| 774 | **FM 1 (Flight Telescope)** | 2004-07-08 → 2004-08-11 (+34d) | 2004-07-23 → 2004-09-15 (+54d) | 12d → 25d |  | -13d → -25d |  |  |
| 775 | Disassemble SIT FM 1 | 2004-07-08 → 2004-08-17 (+40d) | 2004-07-08 → 2004-08-17 (+40d) |  |  | -13d → -8d | Funtional Test of FM 1 Logic Board w/Flight ACTELS → 795 |  |
| 776 | Conformal Coat SIT FM 1 Boards (includes FM 1 LVPS) | 2004-07-09 → 2004-08-18 (+40d) | 2004-07-12 → 2004-08-19 (+38d) |  |  | -13d → -8d |  |  |
| 779 | Reassemble SIT FM 1 with Flight Telescope | 2004-07-13 → 2004-09-01 (+50d) | 2004-07-13 → 2004-09-02 (+51d) | 1d → 2d |  | -13d → -40d | 776, 446, 412 → 412, 446, 778 |  |
| 780 | Bench Calibration SIT FM 1 w/Flight Telescope | 2004-07-14 → 2004-09-03 (+51d) | 2004-07-16 → 2004-09-08 (+54d) |  |  | -13d → -40d |  |  |
| 781 | Vacuum Test SIT FM 1 w/Flight Telescope | 2004-07-19 → 2004-09-09 (+52d) | 2004-07-23 → 2004-09-15 (+54d) |  |  | -13d → -40d |  |  |
| 782 | **FM 2** | 2004-08-02 → 2004-10-19 (+78d) | 2004-08-12 → 2004-10-29 (+78d) |  |  | 1d → -36d |  |  |
| 783 | Disassemble SIT FM 2 | 2004-08-02 → 2004-10-19 (+78d) | 2004-08-02 → 2004-10-19 (+78d) |  |  | 1d → -36d | 742 → 804 |  |
| 784 | Conformal Coat SIT FM 2 Boards | 2004-08-03 → 2004-10-20 (+78d) | 2004-08-04 → 2004-10-21 (+78d) |  |  | 1d → -36d |  |  |
| 785 | Reassemble SIT FM 2 | 2004-08-05 → 2004-10-22 (+78d) | 2004-08-05 → 2004-10-22 (+78d) |  |  | 1d → -36d |  |  |
| 786 | Post-Coat Retest SIT FM 2 | 2004-08-06 → 2004-10-25 (+80d) | 2004-08-12 → 2004-10-29 (+78d) |  |  | 1d → -36d |  |  |
| 787 | **FM 1 (ETU Telescope)** |  | 2004-06-29 → 2004-08-16 (+48d) | 89d → 122d | 10% → 22% | -13d → -8d |  |  |
| 789 | Integrate Electronics to SIT ETU Telescope | 2004-05-20 → 2004-06-23 A (+34d) | 2004-05-21 → 2004-07-09 (+49d) | 2d → 12d | 0% → 50% | -13d → -8d |  |  |
| 790 | SIT FM 1 Debug | 2004-05-24 → 2004-07-12 (+49d) | 2004-05-28 → 2004-07-16 (+49d) |  |  | -13d → -8d |  |  |
| 791 | SIT FM 1 Bench Test | 2004-06-01 → 2004-07-19 (+48d) | 2004-06-07 → 2004-07-23 (+46d) |  |  | -13d → -8d |  |  |
| 792 | SIT FM 1 Alpha TEST | 2004-06-08 → 2004-07-26 (+48d) | 2004-06-14 → 2004-07-30 (+46d) |  |  | -13d → -8d |  |  |

| ID | Task | Start | Finish | Duration | Complete | Total float | Predecessors |
| --- | --- | --- | --- | --- | --- | --- | --- |
| 793 | SIT FM 1 Noise Removal | 2004-06-15 → 2004-08-02 (+48d) | 2004-06-21 → 2004-08-06 (+46d) |  |  | -13d → -8d |  |
| 794 | SIT FM 1 Thermal Test | 2004-06-22 → 2004-08-09 (+48d) | 2004-06-28 → 2004-08-13 (+46d) |  |  | -13d → -8d |  |
| 795 | SIT FM 1 Functional Test | 2004-06-29 → 2004-08-16 (+48d) | 2004-06-29 → 2004-08-16 (+48d) |  |  | -13d → -8d |  |
| 796 | **FM 2** | 2004-06-10 → 2004-09-02 (+84d) | 2004-07-22 → 2004-10-18 (+88d) |  |  | 1d → -36d |  |
| 797 | Integrate SIT FM 2 HVPS and SIT FM 2 Telescope Without Electronics | 2004-06-10 → 2004-09-02 (+84d) | 2004-06-14 → 2004-09-07 (+85d) |  |  | 1d → -36d |  |
| 798 | Integrate Electronics to SIT FM 2 Telescope | 2004-06-15 → 2004-09-08 (+85d) | 2004-06-16 → 2004-09-09 (+85d) |  |  | 1d → -36d | Functional Test of FM 2 Logic Board w/ETU ACTELS, 710, 762, 723, 797 → 742, 710, 762, 723, 797 |
| 799 | SIT FM 2 Debug | 2004-06-17 → 2004-09-10 (+85d) | 2004-06-23 → 2004-09-16 (+85d) |  |  | 1d → -36d |  |
| 800 | SIT FM 2 Bench Test | 2004-06-24 → 2004-09-17 (+85d) | 2004-06-30 → 2004-09-23 (+85d) |  |  | 1d → -36d |  |
| 801 | SIT FM 2 Alpha Test | 2004-07-01 → 2004-09-24 (+85d) | 2004-07-07 → 2004-09-30 (+85d) |  |  | 1d → -36d |  |
| 802 | SIT FM 2 Noise Removal | 2004-07-08 → 2004-10-01 (+85d) | 2004-07-14 → 2004-10-07 (+85d) |  |  | 1d → -36d |  |
| 803 | SIT FM 2 Thermal Test | 2004-07-15 → 2004-10-08 (+85d) | 2004-07-21 → 2004-10-15 (+86d) |  |  | 1d → -36d |  |
| 804 | SIT FM 2 Functional Test | 2004-07-22 → 2004-10-18 (+88d) | 2004-07-22 → 2004-10-18 (+88d) |  |  | 1d → -36d |  |
| 805 | Integrate SIT Door FM 1 | 2004-08-20 → 2004-10-08 (+49d) | 2004-08-20 → 2004-10-08 (+49d) |  |  | -3d → -37d |  |
| 806 | Integrate SIT Door FM 2 | 2004-09-02 → 2004-10-12 (+40d) | 2004-09-02 → 2004-10-12 (+40d) |  |  | 313d → -23d | Deliver SIT FM 2 back to GSFC for Environmental Testing, 805 → 805 |
| 807 | **Environmental Testing at GSFC (FM 1)** | 2004-08-23 → 2004-10-12 (+50d) | 2004-10-08 → 2004-11-30 (+53d) |  |  | -3d → -37d |  |
| 808 | SIT FM 1 Vibration and Acoustics | 2004-08-23 → 2004-10-12 (+50d) | 2004-09-03 → 2004-10-25 (+52d) |  |  | -3d → -37d |  |
| 809 | Functional Test | 2004-09-07 → 2004-10-26 (+49d) | 2004-09-07 → 2004-10-26 (+49d) |  |  | -3d → -37d |  |
| 810 | SIT FM 1 Thermal Balance | 2004-09-08 → 2004-10-27 (+49d) | 2004-09-14 → 2004-11-02 (+49d) |  |  | -3d → -37d |  |
| 811 | SIT FM 1 Thermal Vac | 2004-09-15 → 2004-11-03 (+49d) | 2004-09-28 → 2004-11-17 (+50d) |  |  | -3d → -37d |  |
| 812 | Disassemble SIT Instruments | 2004-09-29 → 2004-11-18 (+50d) | 2004-09-30 → 2004-11-19 (+50d) |  |  | -3d → -37d |  |
| 813 | Bake Out | 2004-10-01 → 2004-11-22 (+52d) | 2004-10-05 → 2004-11-24 (+50d) |  |  | -3d → -37d |  |
| 814 | Reassemble Instruments | 2004-10-06 → 2004-11-26 (+51d) | 2004-10-07 → 2004-11-29 (+53d) |  |  | -3d → -37d |  |
| 815 | Functional Test | 2004-10-08 → 2004-11-30 (+53d) | 2004-10-08 → 2004-11-30 (+53d) |  |  | -3d → -37d |  |
| 816 | **Environmental Testing at GSFC (FM 2)** | 2004-09-02 → 2004-11-01 (+60d) | 2004-10-21 → 2004-12-13 (+53d) | 34d → 29d |  | 3d → -36d |  |
| 817 | SIT FM 2 Vibration and Acoustics | 2004-09-02 → 2004-11-01 (+60d) | 2004-09-16 → 2004-11-15 (+60d) |  |  | 3d → -36d | Deliver SIT FM 2 back to GSFC for Environmental Testing → 806, 786 |
| 818 | Functional Test | 2004-09-17 → 2004-11-16 (+60d) | 2004-09-17 → 2004-11-16 (+60d) |  |  | 3d → -36d |  |
| 819 | SIT FM 2 Thermal Vac | 2004-09-27 → 2004-11-17 (+51d) | 2004-10-08 → 2004-12-01 (+54d) |  |  | 3d → -36d | SIT FM 2 Thermal Balance → 818 |
| 820 | Disassemble SIT Instruments | 2004-10-12 → 2004-12-02 (+51d) | 2004-10-13 → 2004-12-03 (+51d) |  |  | 3d → -36d |  |
| 821 | Bake Out | 2004-10-14 → 2004-12-06 (+53d) | 2004-10-18 → 2004-12-08 (+51d) |  |  | 3d → -36d |  |
| 822 | Reassemble Instruments | 2004-10-19 → 2004-12-09 (+51d) | 2004-10-20 → 2004-12-10 (+51d) |  |  | 3d → -36d |  |
| 823 | Functional Test | 2004-10-21 → 2004-12-13 (+53d) | 2004-10-21 → 2004-12-13 (+53d) |  |  | 3d → -36d |  |
| 824 | **Emulators/Simulators/GSE** |  | 2004-10-13 → 2004-11-16 (+34d) | 209d → 231d | 10% → 84% | 9d → -18d |  |
| 825 | **Simulators** |  | 2004-04-12 → 2004-05-14 A (+32d) | 80d → 104d | 13% → 100% | 98d → none |  |
| 826 | Labview CPU Ready |  | 2004-04-12 → 2004-05-14 A (+32d) | 80d → 104d | 13% → 100% | 0d → none |  |
| 827 | Test Simulator |  | 2004-04-12 → 2004-05-14 A (+32d) | 80d → 104d | 13% → 100% | 98d → none |  |
| 828 | **GSE** | 2004-08-17 → 2004-09-20 (+34d) | 2004-10-13 → 2004-11-16 (+34d) |  |  | 9d → -18d |  |
| 829 | Pulse Generator | 2004-08-17 → 2004-09-20 (+34d) | 2004-10-13 → 2004-11-16 (+34d) |  |  | 9d → -18d | 696, Deliver SIT FM 2 to CIT for SEP I&T, 827 → 696, 827 |
| 830 | **SEP Suite I&T - CIT** |  | 2004-10-26 → 2004-12-20 (+55d) | 312d → 348d | 39% → 62% | 2d → -35d |  |
| 833 | **FM 1 & FM 2** | 2004-03-09 → 2004-06-16 A (+99d) | 2004-07-22 → 2004-09-14 (+54d) | 97d → 63d | 0% → 29% | -8d → -36d |  |
| 834 | Generate HET integration & test procedure | 2004-06-28 → 2004-06-17 A (-11d) | 2004-07-02 → 2004-06-23 A (-9d) |  | 0% → 100% | 2d → none |  |
| 835 | Generate LET integration & test procedure | 2004-06-16 A | 2004-06-22 A |  | 0% → 100% | 9d → none | 853FS-10d → 844FS-10d |
| 836 | Generate SEPT integration & test procedure | 2004-03-09 → 2004-08-30 (+174d) | 2004-03-15 → 2004-09-03 (+172d) |  |  | 78d → -35d |  |
| 837 | Generate SEP-IDPU integration procedure | 2004-07-08 → 2004-08-27 (+50d) | 2004-07-14 → 2004-09-02 (+50d) |  |  | -9d → -39d | 844FS-10d → 846FS-10d |
| 838 | Generate SEP-IDPU test procedure | 2004-07-15 → 2004-09-03 (+50d) | 2004-07-21 → 2004-09-10 (+51d) |  |  | -9d → -39d |  |
| 839 | Generate SIT integration & test procedure | 2004-07-15 → 2004-09-07 (+54d) | 2004-07-21 → 2004-09-13 (+54d) |  |  | -8d → -35d |  |
| 840 | Generate SEP system test procedure | 2004-07-16 → 2004-09-08 (+54d) | 2004-07-22 → 2004-09-14 (+54d) |  |  | -8d → -40d |  |
| 841 | **FM 1** | 2004-03-22 → 2004-06-29 A (+99d) | 2004-08-03 → 2004-09-21 (+49d) | 96d → 59d | 0% → 25% | -13d → -40d |  |
| 842 | Integrate/test SEP Central FM 1 | 2004-06-22 → 2004-07-01 A (+9d) | 2004-06-28 → 2004-07-02 A (+4d) | 5d → 2d | 0% → 100% | 4d → none |  |
| 843 | Receive & inspect HET FM 1 | 2004-07-09 → 2004-06-30 A (-9d) | 2004-07-09 → 2004-06-30 A (-9d) |  | 0% → 100% | -3d → none |  |
| 844 | Integrate & test HET FM 1 | 2004-07-21 → 2004-06-29 A (-22d) | 2004-07-21 → 2004-06-29 A (-22d) |  | 0% → 100% | -10d → none | 834, 845, 843 → 834, 842FS-4d |
| 845 | Integrate & test LET FM 1 | 2004-07-20 → 2004-07-02 (-18d) | 2004-07-20 → 2004-07-02 (-18d) |  |  | -10d → -38d | 835, 853, 570, 572 → 844, 835, 570 |
| 848 | Integrate SEP FM 1 - IDPU FM 1 | 2004-07-22 → 2004-09-15 (+55d) | 2004-07-22 → 2004-09-15 (+55d) |  |  | -10d → -42d | 837, 844 → 837, 398 |
| 849 | Test SEP FM 1 - IDPU FM 1 | 2004-07-23 → 2004-09-16 (+55d) | 2004-07-23 → 2004-09-16 (+55d) |  |  | -10d → -42d | 838, 848, 398 → 848, 838 |
| 850 | Receive & inspect SIT FM 1 | 2004-07-28 → 2004-09-20 (+54d) | 2004-07-28 → 2004-09-20 (+54d) |  |  | -13d → -40d |  |
| 851 | Integrate & test SIT FM 1 | 2004-07-29 → 2004-09-21 (+54d) | 2004-07-29 → 2004-09-21 (+54d) |  |  | -13d → -40d | 839, 844, 850, 849 → 850, 839 |
| 852 | Receive & inspect SEPT FM 1 | 2004-03-22 → 2004-09-13 (+175d) | 2004-03-22 → 2004-09-13 (+175d) |  |  | 73d → -40d | 593, 594 → 593, 594, 846 |
| 853 | Integrate & test SEPT FM 1 | 2004-06-29 → 2004-09-14 (+77d) | 2004-06-29 → 2004-09-14 (+77d) |  |  | 4d → -40d | 836, 842, 852 → 852, 836 |
| 854 | SEP system test FM 1 | 2004-07-30 → 2004-09-17 (+49d) | 2004-08-03 → 2004-09-21 (+49d) |  |  | -13d → -42d | 840, 851, 479 → 840, 853, 849, 847 |
| 855 | **FM 2** | 2004-03-25 → 2004-06-30 A (+97d) | 2004-08-23 → 2004-09-17 (+25d) | 107d → 56d | 0% → 7% | 2d → -8d |  |
| 856 | Receive & inspect HET FM 2 | 2004-07-30 → 2004-06-30 A (-30d) | 2004-07-30 → 2004-06-30 A (-30d) |  | 0% → 100% | 15d → none | 515 → 514 |
| 857 | Integrate & test HET FM 2 | 2004-08-02 → 2004-07-01 (-32d) | 2004-08-02 → 2004-07-01 (-32d) |  |  | 15d → 36d | 834, 858, 856 → 856, 834 |
| 858 | Integrate & test LET FM 2 | 2004-07-20 → 2004-07-02 (-18d) | 2004-07-20 → 2004-07-02 (-18d) |  |  | 23d → -38d | 835, 881, 571, 572 → 571, 572, 835 |
| 859 | Integrate/testSEP Central FM 2 | 2004-06-22 → 2004-07-06 (+14d) | 2004-06-28 → 2004-07-12 (+14d) |  |  | 37d → 35d | 483, 484, 422 → 483, 484, 422, 858, 857 |
| 862 | Integrate SEP FM 2 - IDPU FM 2 | 2004-08-03 → 2004-09-03 (+31d) | 2004-08-03 → 2004-09-03 (+31d) |  |  | 15d → -3d | 837, 857, 210 → 210, 837 |
| 863 | Test SEP FM 2 - IDPU FM 2 | 2004-08-04 → 2004-09-13 (+40d) | 2004-08-04 → 2004-09-13 (+40d) |  |  | 15d → -7d |  |
| 864 | SEP FM 2 system test | 2004-08-19 → 2004-09-15 (+27d) | 2004-08-23 → 2004-09-17 (+25d) |  |  | 1d → -8d | 840, 882 → 840, 863, 861 |
| 865 | **Environmental Test (at JPL)** |  | 2004-10-26 → 2004-12-20 (+55d) | 114d → 150d |  | 2d → -35d |  |
| 868 | **FM 1** | 2004-08-30 → 2004-09-23 (+24d) | 2004-10-26 → 2004-12-08 (+43d) | 40d → 52d |  | -13d → -41d |  |
| 869 | FM 1 LET/HET/SEP Central Vibration/Acoustics Test | 2004-08-30 → 2004-10-12 (+43d) | 2004-09-13 → 2004-10-25 (+42d) |  |  | -13d → -42d | 19FS+3d, 866, 867, 886FS+3d → 19FS+3d, 866, 867, 886 |
| 870 | FM 1 LET/HET/SEP Central Thermal Balance Test | 2004-09-14 → 2004-10-26 (+42d) | 2004-09-20 → 2004-11-01 (+42d) |  |  | -13d → -42d |  |

| ID | Task | Start | Finish | Duration | Complete | Total float | Predecessors | Other |
| --- | --- | --- | --- | --- | --- | --- | --- | --- |
| 871 | FM 1 LET/HET/SEP Central T/V Test | 2004-09-21 → 2004-11-02 (+42d) | 2004-10-12 → 2004-11-23 (+42d) |  |  | -13d → -42d | 870, 883 → 870 |  |
| 872 | Evaluate SEP performance | 2004-10-13 → 2004-11-24 (+42d) | 2004-10-26 → 2004-12-08 (+43d) |  |  | -13d → -42d |  |  |
| 874 | Bakeout Clean SEP exterior & prepare for delivery | 2004-10-13 → 2004-11-24 (+42d) | 2004-10-15 → 2004-11-29 (+45d) |  |  | -6d → -35d |  |  |
| 875 | **FM 2** | 2004-08-24 → 2004-10-12 (+49d) | 2004-10-21 → 2004-12-20 (+60d) | 41d → 48d |  | 1d → -35d |  |  |
| 876 | FM 2 LET/HET/SEP Central Vibration/Acoustics Test | 2004-08-31 → 2004-10-12 (+42d) | 2004-09-14 → 2004-10-25 (+41d) |  |  | 5d → -23d | 887FS+3d, 883 → 864, 869SS |  |
| 877 | FM 2 LET/HET/SEP Central T/V Test | 2004-09-15 → 2004-10-26 (+41d) | 2004-10-05 → 2004-11-16 (+42d) |  |  | 5d → -23d | 883, 876 → 876 |  |
| 878 | Evaluate SEP performance | 2004-10-06 → 2004-11-17 (+42d) | 2004-10-20 → 2004-12-01 (+42d) |  |  | 5d → -23d |  |  |
| 879 | Generate test reports | 2004-10-06 → 2004-10-14 (+8d) | 2004-10-21 → 2004-10-28 (+7d) |  |  | 5d → -23d |  |  |
| 880 | Bakeout Clean SEP exterior & prepare for delivery | 2004-10-06 → 2004-11-17 (+42d) | 2004-10-08 → 2004-11-19 (+42d) |  |  | 12d → -21d |  |  |
| 881 | Integrate & test SEPT FM 2 | 2004-06-29 → 2004-11-30 (+154d) | 2004-06-29 → 2004-11-30 (+154d) |  |  | 37d → -26d | 836, 859, Receive & inspect SEPT FM 2 → 880, 596, 597 | baseline start 2004-05-18 → none; baseline finish 2004-05-18 → none |
| 882 | Integrate & test SIT FM 2 | 2004-08-18 → 2004-12-15 (+119d) | 2004-08-18 → 2004-12-15 (+119d) |  |  | 1d → -36d | 839, Receive & inspect SIT FM 2 → 881, 699 | baseline start 2004-08-06 → none; baseline finish 2004-08-06 → none |
| 883 | FM 2 EMI/EMC Test at CalTech | 2004-08-24 → 2004-12-16 (+114d) | 2004-08-30 → 2004-12-17 (+109d) | 5d → 2d |  | 1d → -36d | 864 → 874, 882 |  |
| 885 | **Accelerator Test (at MSU)** | 2004-08-18 → 2004-07-10 (-39d) | 2004-08-24 → 2004-07-22 (-33d) | 5d → 9d |  | -13d → -42d |  |  |
| 886 | FM 1 LET-HET/SEP Cen end-to-end test at Accelerator | 2004-08-18 → 2004-07-10 (-39d) | 2004-08-24 → 2004-07-12 (-43d) | 5d → 3d |  | -13d → -44d | 898, 19, 453 → 898, 453, 845 | was named FM 1 LET/SEP Cen end-to-end test at Accelerator; constraint none → start no earlier than 2004-07-10 |
| 887 | FM 2 LET/SEP Cen end-to-end test at Accelerator | 2004-08-18 → 2004-07-10 (-39d) | 2004-08-24 → 2004-07-12 (-43d) | 5d → 3d |  | 6d → -44d | 886SS, 863 → 898, 858 | constraint none → start no earlier than 2004-07-10 |
| 894 | **GSE** |  | 2004-10-15 → 2004-10-18 (+3d) |  | 55% → 82% | 9d → 8d |  |  |
| 895 | **End-to-End Test Equipment** |  |  |  | 84% → 97% | 27d → -5d |  |  |
| 896 | Design |  | 2004-05-14 A |  | 95% → 100% | 27d → none |  |  |
| 897 | Assemble | 2004-05-17 A |  |  | 0% → 90% | 27d → -30d |  |  |
| 899 | **GSE software** |  | 2004-10-15 → 2004-10-18 (+3d) |  | 34% → 74% | 9d → 8d |  |  |
| 900 | Build GSE software release 2 |  | 2004-03-18 → 2004-07-02 (+106d) | 157d → 232d | 66% → 99% |  |  |  |
| 901 | Write user's guide | 2004-03-22 → 2004-06-21 A (+91d) | 2004-03-31 → 2004-07-02 (+93d) | 8d → 10d | 0% → 80% | 31d → 51d | 900 → 900FS-10d |  |
| 902 | Build GSE software release 3 | 2004-05-03 A | 2004-10-15 → 2004-10-18 (+3d) |  | 0% → 36% | 9d → 8d | 901 → 901FS-45d |  |
| 903 | Write user's guide supplement | 2004-09-15 → 2004-09-20 (+5d) | 2004-10-15 → 2004-10-18 (+3d) | 22d → 20d |  | 9d → 8d | 902FS-22d → 902FS-20d |  |
| 904 | **SWEA and SIT Retest (after S/C Environmental Testing)** |  |  |  |  |  |  | was named SWEA and SIT Refurbishment (after S/C Environmental Testing) |
